# NGAO Design v7

Schedule from MS Project, 2005-10-03 to 2010-05-21, costs in $, A marks actual dates.
CARA

## Calendars

- Standard: Mon-Fri 08:00-12:00, 13:00-17:00; Sat-Sun off.

## Resources

| Resource | Group | Rate |
| --- | --- | --- |
| Dekany | COO |  |
| Gavel | UCO | 75 |
| Max | UCO |  |
| Wizinowich | WMKO | 75 |
| Adkins | WMKO | 75 |
| McGrath | UCO | 75 |
| Tyau | WMKO | 75 |
| Bell | WMKO | 75 |
| Chin | WMKO | 75 |
| Kupke | UCO | 75 |
| Lockwood | UCO | 75 |
| Neyman | WMKO | 75 |
| Reinig | UCO | 75 |
| Velur | COO | 75 |
| Free | WMKO |  |
| Johansson | WMKO | 75 |
| Wetherell | WMKO | 75 |
| Medeiros | WMKO | 75 |
| Nance | WMKO | 75 |
| Summers | WMKO | 75 |
| Mogensen | WMKO | 75 |
| Bouchez | COO | 75 |
| Chock | WMKO | 75 |
| Panteleev | WMKO | 75 |
| Morrison | WMKO | 75 |
| Macintosh | UCO | 75 |
| Peck | UCO | 75 |
| Delacroix | COO | 75 |
| Hale | COO | 75 |
| Grace | WMKO | 75 |
| Doyle | WMKO | 75 |
| Brown | COO | 75 |
| Marchis | UCB |  |
| Lu | COO |  |
| Johnson | WMKO | 75 |
| Stalcup | WMKO | 75 |
| Lyke | WMKO | 75 |
| Conrad | WMKO | 75 |
| Cohen | WMKO | 75 |
| Kwok | WMKO | 75 |
| Stomski | WMKO | 75 |
| UCO analyst | UCO | 75 |
| Devenot | WMKO | 75 |
| Ragland | WMKO |  |
| Crepp | COO | 75 |
| Troy | UCO | 75 |

## Schedule

| ID | WBS | Task | Duration | Start | Finish | Complete | Remaining | Baseline start | Baseline finish | Baseline duration | Total slack | Free slack | Constraint | Resources | Work | Actual work | Cost | Baseline cost | Actual cost |
| --- | --- | --- | --- | --- | --- | --- | --- | --- | --- | --- | --- | --- | --- | --- | --- | --- | --- | --- | --- |
| 1 | 1 | **NGAO Design** | 1210d? | 2005-10-03 A | 2010-05-21 | 31% | 838.72d? | 2005-10-03 | 2010-08-13 | 1270d? | 0d |  |  |  | 36427h | 20750.1h | 2,518,368.16 | 2,722,086.86 | 1,419,227.28 |
| 2 | 1.1 | Proposal | 195d? | 2005-10-03 | 2006-06-30 |  |  | 2005-10-03 | 2006-06-30 | 195d? | 1015d |  | finish no earlier than 2006-06-30 |  |  |  |  |  |  |
| 3 | 1.2 | System Design | 413d? | 2006-10-02 | 2008-04-30 |  |  | 2006-10-02 | 2008-04-30 | 413d? | 537d |  | finish no earlier than 2008-04-30 |  |  |  |  |  |  |
| 4 | 1.3 | **Preliminary Design** | 537d? | 2008-05-01 A | 2010-05-21 | 31% | 368.52d? | 2008-04-01 | 2010-08-13 | 619d? | 0d |  |  |  | 36427h | 20750.1h | 2,518,368.16 | 2,722,086.86 | 1,419,227.28 |
| 5 | 1.3.1 | PD Part I (May/08 through Apr/09) | 261d? | 2008-05-01 A | 2009-04-30 A | 100% |  | 2008-05-01 | 2009-04-30 | 261d? |  |  | finish no earlier than 2009-04-30 |  | 10301h | 10301h | 701,268 | 590,991 | 701,268 |
| 6 | 1.3.2 | **PD Phase Management** | 276d? | 2009-05-01 A | 2010-05-21 | 52% | 131.93d? | 2009-05-01 | 2010-05-21 | 276d? | 0d |  |  |  | 5183h | 2198.75h | 336,825.1 | 390,630.86 | 133,293.84 |
| 7 | 1.3.2.1 | **Planning** | 231d? | 2009-05-01 A | 2010-03-19 | 25% | 174.36d? | 2009-05-01 | 2010-01-29 | 196d? | 45d |  |  |  | 1430h | 70h | 104,700 | 109,200 | 5,250 |
| 8 | 1.3.2.1.1 | **Replans (PD phase)** | 30d? | 2009-05-04 A | 2009-06-12 A | 100% |  | 2009-05-04 | 2009-06-12 | 30d? |  |  |  |  | 50h | 50h | 3,750 | 3,750 | 3,750 |
| 9 | 1.3.2.1.1.1 | B2C Replan | 30d? | 2009-05-04 A | 2009-06-12 A | 100% |  | 2009-05-04 | 2009-06-12 | 30d? |  |  | start no earlier than 2009-05-04 | Dekany [3.3%]; Gavel [3.3%]; Wizinowich [10%]; Velur [0.8%]; Neyman [0.8%]; Johansson [1.7%]; Bell [0.8%] | 50h | 50h | 3,750 | 3,750 | 3,750 |
| 10 | 1.3.2.1.2 | **WMKO FY Plans** | 21d? | 2009-05-01 A | 2009-05-29 A | 100% |  | 2009-05-01 | 2009-08-27 | 85d? |  |  |  |  | 20h | 20h | 1,500 | 2,250 | 1,500 |
| 11 | 1.3.2.1.2.1 | Support WMKO FY10 Planning | 21d? | 2009-05-01 A | 2009-05-29 A | 100% |  | 2009-05-01 | 2009-08-27 | 85d? |  |  | start no earlier than 2009-05-01 | Wizinowich [11.9%] | 20h | 20h | 1,500 | 2,250 | 1,500 |
| 12 | 1.3.2.1.3 | **Systems Engineering Management Plan** | 178d? | 2009-07-15 | 2010-03-19 |  |  | 2009-05-01 | 2010-01-29 | 196d? | 45d |  |  |  | 1360h |  | 99,450 | 103,200 |  |
| 13 | 1.3.2.1.3.1 | **Project Plan** | 70d? | 2009-12-07 | 2010-03-12 |  |  | 2009-11-02 | 2010-01-08 | 50d? | 50d |  |  |  | 985h |  | 72,375 | 74,250 |  |
| 14 | 1.3.2.1.3.1.1 | PBS, WBS & Task Definition | 25d? | 2009-12-07 | 2010-01-08 |  |  | 2009-11-02 | 2009-11-20 | 15d? | 95d |  | finish no earlier than 2010-01-08 | Dekany [20%]; Gavel [20%]; Wizinowich [15%]; Max [5%]; Reinig [7.5%]; Wetherell [5%]; Johansson [7.5%]; Lyke [7.5%]; Neyman [5%]; Bell [5%]; Velur [20%]; Lockwood [7.5%] | 250h |  | 18,000 | 18,750 |  |
| 15 | 1.3.2.1.3.1.2 | Cost Estimation | 40d? | 2010-01-04 | 2010-02-26 |  |  | 2009-11-23 | 2009-12-18 | 20d? | 60d |  | start no earlier than 2010-01-04 | Dekany [38%]; Gavel [25%]; Max [6.2%]; Wizinowich [37.5%]; Neyman [18.8%]; Bell [25%]; Johansson [25%]; Wetherell [9.4%]; Reinig [12.5%]; Kupke [9.4%]; Lockwood [12.5%]; Velur [9.4%]; Brown [25%]; Lyke [6.2%]; Hale [9.4%]; Delacroix [9.4%] | 455h |  | 33,375 | 35,250 |  |
| 16 | 1.3.2.1.3.1.3 | Full Schedule (MS Project Plan) | 30d? | 2010-02-01 | 2010-03-12 |  |  | 2009-12-07 | 2010-01-08 | 25d? | 50d |  | finish no earlier than 2010-03-12 | Wizinowich [14.6%]; Dekany [12.5%]; Gavel [12.5%]; Velur [14.6%]; Bell [4.2%]; Neyman [4.2%]; Lyke [6.2%]; Johansson [8.3%]; Chin [4.2%]; Lockwood [6.2%]; Reinig [8.3%]; Stomski [20.8%] | 280h |  | 21,000 | 20,250 |  |
| 17 | 1.3.2.1.3.2 | **Detailed Design Phase Plan** | 102d? | 2009-07-15 | 2009-12-03 |  |  | 2009-05-01 | 2009-12-03 | 155d? | 121d |  |  |  | 295h |  | 21,375 | 23,250 |  |
| 18 | 1.3.2.1.3.2.1 | Detailed Design Plan v1 (TSIP proposal) | 18d? | 2009-07-15 | 2009-08-07 |  |  | 2009-07-15 | 2009-08-07 | 18d? | 205d |  | start no earlier than 2009-07-15 | Wizinowich [22.2%]; Dekany [27.8%]; Gavel [27.8%] | 40h |  | 3,000 | 3,000 |  |
| 19 | 1.3.2.1.3.2.2 | Detailed Design Plan Final Version | 19d? | 2009-11-09 | 2009-12-03 |  |  | 2009-11-09 | 2009-12-03 | 19d? | 121d |  | start no earlier than 2009-11-09 | Wizinowich [19.7%]; Dekany [19.7%]; Gavel [19.7%]; Max [6.6%]; Lockwood [6.6%]; Chin [6.6%]; Bell [6.6%]; Neyman [3.3%]; Lyke [6.6%]; Johansson [6.6%]; Reinig [13.2%]; Velur [19.7%]; Stomski [32.9%] | 255h |  | 18,375 | 17,250 |  |
| 20 | 1.3.2.1.3.3 | SEMP Document | 25d? | 2010-02-15 | 2010-03-19 |  |  | 2010-01-11 | 2010-01-29 | 15d? | 44d | 9d | finish no earlier than 2010-03-19 | Wizinowich [18%]; Dekany [12%]; Gavel [8%]; Max [2%] | 80h |  | 5,700 | 5,700 |  |
| 21 | 1.3.2.2 | **Project Management & Meetings** | 261d? | 2009-05-01 A | 2010-04-30 | 50% | 129.97d? | 2009-05-01 | 2010-04-30 | 261d? | 15d |  |  |  | 1195h | 776.75h | 85,875 | 86,250 | 55,818.75 |
| 22 | 1.3.2.2.1 | **Senior Management Committee** | 261d? | 2009-05-01 A | 2010-04-30 | 65% | 91.35d? | 2009-05-01 | 2010-04-30 | 261d? | 15d |  |  |  | 300h | 195h | 18,750 | 18,750 | 12,187.5 |
| 23 | 1.3.2.2.1.1 | Senior Management Activities | 261d? | 2009-05-01 A | 2010-04-30 | 65% | 91.35d? | 2009-05-01 | 2010-04-30 | 261d? | 15d |  | finish no earlier than 2010-04-30 | Dekany [1.8%]; Gavel [1.8%]; Max [0.6%]; Wizinowich [3%] | 150h | 97.5h | 10,312.5 | 10,312.5 | 6,703.12 |
| 24 | 1.3.2.2.1.2 | Senior Management Telecons | 261d? | 2009-05-01 A | 2010-04-30 | 65% | 91.35d? | 2009-05-01 | 2010-04-30 | 261d? | 15d |  | finish no earlier than 2010-04-30 | Dekany [1.8%]; Gavel [1.8%]; Max [1.8%]; Wizinowich [1.8%] | 150h | 97.5h | 8,437.5 | 8,437.5 | 5,484.38 |

Notes:
- 6: PW
- 7: PW
- 12: PW
- 14: PW
- 15: RD
- 16: PW
- 17: PW
- 18: PW
- 19: PW
- 20: PW
- 21: PW
- 22: PW

| ID | WBS | Task | Type | Duration | Start | Finish | Complete | Remaining | Baseline start | Baseline finish | Baseline duration | Total slack | Constraint | Resources | Work | Actual work | Cost | Baseline cost | Actual cost |
| --- | --- | --- | --- | --- | --- | --- | --- | --- | --- | --- | --- | --- | --- | --- | --- | --- | --- | --- | --- |
| 25 | 1.3.2.2.2 | **Team Meetings** |  | 238d? | 2009-05-01 A | 2010-03-30 | 65% | 83.3d? | 2009-05-01 | 2010-03-30 | 237.55d? | 38d |  |  | 895h | 581.75h | 67,125 | 67,500 | 43,631.25 |
| 26 | 1.3.2.2.2.1 | Meeting Participation |  | 238d? | 2009-05-01 A | 2010-03-30 | 65% | 83.3d? | 2009-05-01 | 2010-03-30 | 72.48d? | 38d | start no earlier than 2009-05-01 | Dekany [4.2%]; Gavel [4.2%]; Wizinowich [4.2%]; Lyke [2.1%]; Johansson [4.2%]; Neyman [4.2%]; Bell [3.2%]; Adkins [4.2%]; Kupke [2.1%]; Lockwood [2.1%]; Velur [4.2%]; Wetherell [2.1%]; Reinig [2.1%]; Delacroix [2.1%]; McGrath [1.8%] | 895h | 581.75h | 67,125 | 67,500 | 43,631.25 |
| 27 | 1.3.2.2.3 | **NSAT Meetings/Telecons** |  | 232d | 2009-06-11 | 2010-04-30 |  |  | 2009-05-08 | 2009-11-06 | 130d | 15d |  |  |  |  |  |  |  |
| 28 | 1.3.2.2.3.1 | NSAT Meeting #1 | milestone | 0d | 2009-06-11 | 2009-06-11 |  |  | 2009-05-08 | 2009-05-08 | 0d | 247d | start no earlier than 2009-06-11 |  |  |  |  |  |  |
| 29 | 1.3.2.2.3.2 | NSAT Meetings/Telecons |  | 224d | 2009-06-23 | 2010-04-30 |  |  | 2009-11-06 | 2009-11-06 | 0d | 15d | finish no earlier than 2010-04-30 |  |  |  |  |  |  |
| 30 | 1.3.2.3 | **Tracking & Reporting** |  | 261d? | 2009-05-01 A | 2010-04-30 | 57% | 112.91d? | 2009-05-01 | 2010-04-30 | 261d? | 15d |  |  | 378h | 257.5h | 26,850 | 26,580.88 | 18,337.5 |
| 31 | 1.3.2.3.1 | **Monthly Status Reports** |  | 261d? | 2009-05-01 A | 2010-04-30 | 65% | 91.35d? | 2009-05-01 | 2010-04-30 | 261d? | 15d |  |  | 270h | 175.5h | 18,750 | 19,455.88 | 12,187.5 |
| 32 | 1.3.2.3.1.1 | Monthly Team Status Reports |  | 238.5d? | 2009-05-01 A | 2010-03-31 | 65% | 83.47d? | 2009-05-01 | 2010-04-30 | 261d? | 37.5d | start no earlier than 2009-05-01 | Wizinowich [1%]; Max [0.5%]; Gavel [1%]; Dekany [1%]; Reinig [0.5%]; Johansson [0.6%]; Lyke [0.6%]; Velur [1%]; Kupke [0.4%]; Neyman [0.5%]; Lockwood [0.4%]; Bell [0.3%]; Wetherell [0.3%] | 160h | 104h | 11,250 | 12,000 | 7,312.5 |
| 33 | 1.3.2.3.1.2 | Monthly Project Reports (TSIP, Directors) |  | 261d? | 2009-05-01 A | 2010-04-30 | 65% | 91.35d? | 2009-05-01 | 2010-04-30 | 261d? | 15d | start no earlier than 2009-05-01 | Wizinowich [2.4%]; Dekany [0.5%]; Gavel [0.5%]; Adkins [0.5%]; Max [0.5%] | 90h | 58.5h | 6,000 | 5,955.88 | 3,900 |
| 34 | 1.3.2.3.1.3 | TSIP Project Report Telecons |  | 261d? | 2009-05-01 A | 2010-04-30 | 65% | 91.35d? | 2009-05-01 | 2010-04-30 | 261d? | 15d | start no earlier than 2009-05-01 | Adkins [0.5%]; Wizinowich [0.5%] | 20h | 13h | 1,500 | 1,500 | 975 |
| 35 | 1.3.2.3.2 | **SSC Meetings** |  | 207.88d? | 2009-07-08 A | 2010-04-23 | 38% | 129.92d? | 2009-06-17 | 2010-02-02 | 164.88d? | 20.12d |  |  | 52h | 26h | 3,900 | 2,925 | 1,950 |
| 36 | 1.3.2.3.2.1 | SSC Meeting (Keck) |  | 1.12d | 2009-07-08 A | 2009-07-09 A | 100% |  | 2009-06-17 | 2009-06-18 | 1.12d |  | start no earlier than 2009-07-08 | Dekany; Gavel; Wizinowich | 13h | 13h | 975 | 975 | 975 |
| 37 | 1.3.2.3.2.2 | SSC Meeting (Caltech) |  | 1.12d | 2009-11-03 A | 2009-11-04 A | 100% |  | 2009-11-03 | 2009-11-04 | 1.12d |  | start no earlier than 2009-11-03 | Dekany; Gavel; Wizinowich | 13h | 13h | 975 | 975 | 975 |
| 38 | 1.3.2.3.2.3 | SSC Meeting (Keck) |  | 1.88d? | 2010-02-24 | 2010-02-25 |  |  | 2010-02-01 | 2010-02-02 | 1.88d? | 61.12d | start no earlier than 2010-02-24 | Dekany [50%]; Gavel [50%]; Wizinowich [60%] | 13h |  | 975 | 975 |  |
| 39 | 1.3.2.3.2.4 | SSC Meeting (Caltech) |  | 1.88d? | 2010-04-22 | 2010-04-23 |  |  |  |  |  | 20.12d | start no earlier than 2010-04-22 | Dekany [50%]; Gavel [50%]; Wizinowich [60%] | 13h |  | 975 |  |  |
| 40 | 1.3.2.3.3 | **Other Presentations** |  | 111d? | 2009-05-01 A | 2009-10-02 | 3% | 108.08d? | 2009-05-01 | 2009-10-02 | 111d? | 165d |  |  | 56h | 56h | 4,200 | 4,200 | 4,200 |
| 41 | 1.3.2.3.3.1 | Keck Science Meeting 09 |  | 3d | 2009-09-17 A | 2009-09-21 A | 100% |  | 2009-09-17 | 2009-09-21 | 3d |  | start no earlier than 2009-09-17 | Dekany; Gavel; Wizinowich | 56h | 56h | 4,200 | 4,200 | 4,200 |
| 42 | 1.3.2.3.3.2 | Other |  | 111d? | 2009-05-01 | 2009-10-02 |  |  | 2009-05-01 | 2009-10-02 | 111d? | 165d | start no earlier than 2009-05-01 |  |  |  |  |  |  |
| 43 | 1.3.2.4 | **Proposals** |  | 216d? | 2009-05-01 A | 2010-02-26 | 56% | 95.9d? | 2009-05-01 | 2009-09-30 | 109d? | 60d |  |  | 580h | 415h | 3,000 | 3,000 | 3,000 |
| 44 | 1.3.2.4.1 | Advancement Support |  | 216d? | 2009-05-01 A | 2010-02-26 | 25% | 162d? | 2009-05-01 | 2009-08-24 | 81.75d? | 60d | start no earlier than 2009-05-01 | Free [3.5%] | 60h | 15h |  |  |  |
| 45 | 1.3.2.4.2 | MRI-R2 Proposals |  | 72d? | 2009-05-01 A | 2009-08-10 A | 100% |  |  |  |  |  | finish no earlier than 2009-08-10 | Dekany; Gavel [13.9%]; Free [27.8%] | 200h | 200h | 3,000 |  | 3,000 |
| 46 | 1.3.2.4.3 | TSIP Proposal |  | 77d? | 2009-06-01 A | 2009-09-15 A | 100% |  |  |  |  |  | start no earlier than 2009-06-01 | Free [13%] | 80h | 80h |  |  |  |
| 47 | 1.3.2.4.4 | ATI Proposal(s) |  | 55d? | 2009-09-15 A | 2009-11-30 A | 100% |  |  |  |  |  | start no earlier than 2009-09-15 | Free [27.3%] | 120h | 120h |  |  |  |
| 48 | 1.3.2.4.5 | MRI 2010 Proposal |  | 44d? | 2009-12-01 | 2010-01-29 |  |  | 2009-09-10 | 2009-09-30 | 15d? | 80d | finish no earlier than 2010-01-29 | Free [34.1%] | 120h |  |  |  |  |

Notes:
- 25: PW
- 27: PW
- 30: PW
- 31: PW
- 35: PW
- 40: PW
- 43: PW

| ID | WBS | Task | Type | Duration | Start | Finish | Predecessors | Complete | Remaining | Baseline start | Baseline finish | Baseline duration | Total slack | Free slack | Constraint | Resources | Work | Actual work | Cost | Baseline cost | Actual cost |
| --- | --- | --- | --- | --- | --- | --- | --- | --- | --- | --- | --- | --- | --- | --- | --- | --- | --- | --- | --- | --- | --- |
| 49 | 1.3.2.5 | **Programmatic Risk Assessment & Mitigation** |  | 174d? | 2009-05-01 A | 2009-12-30 |  | 45% | 95.19d? | 2009-05-01 | 2009-12-30 | 174d? | 102d |  |  |  | 132h | 40h | 9,900 | 10,500 | 3,000 |
| 50 | 1.3.2.5.1 | **Risk Assessment** |  | 4.5d? | 2009-06-24 | 2009-06-30 |  |  |  | 2009-06-24 | 2009-06-30 | 4.29d? | 233d |  |  |  | 52h |  | 3,900 | 4,500 |  |
| 51 | 1.3.2.5.1.1 | Programmatic Risk Assessment |  | 4.5d? | 2009-06-24 | 2009-06-30 |  |  |  | 2009-06-24 | 2009-06-30 | 4.29d? | 233d |  | finish no earlier than 2009-06-30 | Wizinowich; Dekany [22.2%]; Gavel [22.2%] | 52h |  | 3,900 | 4,500 |  |
| 52 | 1.3.2.5.2 | **Risk Mitigation** |  | 174d? | 2009-05-01 A | 2009-12-30 |  | 46% | 94.17d? | 2009-05-01 | 2009-12-30 | 174d? | 102d |  |  |  | 80h | 40h | 6,000 | 6,000 | 3,000 |
| 53 | 1.3.2.5.2.1 | Science Instruments |  | 174d? | 2009-05-01 A | 2009-12-30 |  | 43% | 99.26d? | 2009-05-01 | 2009-12-30 | 174d? | 102d |  | finish no earlier than 2009-12-30 | Wizinowich [14.3%] | 40h | 20h | 3,000 | 3,000 | 1,500 |
| 54 | 1.3.2.5.2.2 | Funding |  | 174d? | 2009-05-01 A | 2009-12-30 |  | 49% | 89.08d? | 2009-05-01 | 2009-12-30 | 174d? | 102d |  | finish no earlier than 2009-12-30 | Wizinowich [5.3%] | 40h | 20h | 3,000 | 3,000 | 1,500 |
| 55 | 1.3.2.6 | **Preliminary Design Review** |  | 235d? | 2009-06-29 A | 2010-05-21 |  | 2% | 229.35d? | 2009-06-29 | 2010-05-21 | 235d? | 0d |  |  |  | 498h | 4h | 33,750 | 34,350 | 225 |
| 56 | 1.3.2.6.1 | Define Success Criteria for all Reviews |  | 9d? | 2009-06-29 | 2009-07-09 |  |  |  | 2009-06-29 | 2009-07-09 | 8.33d? | 226d |  | start no earlier than 2009-06-29 | Wizinowich [60%]; Dekany [5.6%]; Gavel [5.6%]; Max [6%] | 52h |  | 3,600 | 4,200 |  |
| 57 | 1.3.2.6.2 | Review Setup (Date, Participants, Charter) |  | 5d? | 2009-11-06 A | 2009-11-12 |  | 25% | 3.75d? | 2009-11-06 | 2009-11-12 | 5d? | 136d |  | start no earlier than 2009-11-06 | Wizinowich [30%]; Max [10%] | 16h | 4h | 900 | 900 | 225 |
| 58 | 1.3.2.6.3 | Preliminary Design Report |  | 12d? | 2010-03-12 | 2010-03-29 |  |  |  | 2010-03-12 | 2010-03-29 | 12d? | 38d | 3d | start no earlier than 2010-03-12 | Wizinowich [52.1%]; Dekany [15.6%]; Gavel [15.6%]; Max [4.2%]; Neyman [2.1%]; Lyke [2.1%]; Johansson [2.1%]; Reinig [3.1%]; Velur [5.2%]; Kupke [2.1%] | 100h |  | 7,200 | 7,200 |  |
| 59 | 1.3.2.6.4 | Review Package Distributed |  | 1d? | 2010-04-02 | 2010-04-02 | 58, 20, 227 |  |  | 2010-03-26 | 2010-03-26 | 1d? | 35d |  | start no earlier than 2010-04-02 | Wizinowich [75%] | 6h |  | 450 | 450 |  |
| 60 | 1.3.2.6.5 | Reviewer Comments Received | milestone | 0d | 2010-04-16 | 2010-04-16 |  |  |  | 2010-04-09 | 2010-04-09 | 0d | 26d |  | start no earlier than 2010-04-16 |  |  |  |  |  |  |
| 61 | 1.3.2.6.6 | Reviewer Comments Addressed |  | 5d? | 2010-04-19 | 2010-04-23 |  |  |  | 2010-04-12 | 2010-04-16 | 5d? | 20d |  | start no earlier than 2010-04-19 | Wizinowich [50%]; Dekany [30%]; Gavel [30%]; Max [40%]; Reinig [5%]; Velur [15%]; Bell [2.5%]; Wetherell [2.5%]; Neyman [5%]; Lyke [5%]; Johansson [5%]; Kupke [5%]; Lockwood [5%] | 80h |  | 4,800 | 4,800 |  |
| 62 | 1.3.2.6.7 | PDR Presentation Preparation |  | 13d? | 2010-04-05 | 2010-04-21 |  |  |  | 2010-04-01 | 2010-04-21 | 15d? | 22d |  | start no earlier than 2010-04-05 | Wizinowich [19.2%]; Dekany [11.5%]; Gavel [11.5%]; Reinig [3.8%]; Kupke [1.9%]; Lockwood [1.9%]; Velur [5.8%]; Wetherell [1%]; Bell [1%]; Neyman [1.9%]; Lyke [2.9%]; Johansson [2.9%] | 68h |  | 5,100 | 5,100 |  |
| 63 | 1.3.2.6.8 | Preliminary Design Review |  | 2d? | 2010-04-28 | 2010-04-29 |  |  |  | 2010-04-22 | 2010-04-22 | 1d? | 16d |  | finish no earlier than 2010-04-29 | Wizinowich [1250%]; Dekany [1250%]; Max [1250%]; Gavel [1250%]; Delacroix [50%]; Velur [50%]; Reinig [50%]; Lockwood [50%]; Kupke [50%]; Wetherell [50%]; Conrad [50%]; Neyman [50%]; Johansson [50%]; Lyke [50%] | 128h |  | 8,700 | 8,700 |  |
| 64 | 1.3.2.6.9 | Reviewer Report Received | milestone | 0d | 2010-05-14 | 2010-05-14 |  |  |  | 2010-05-14 | 2010-05-14 | 0d | 6d |  | start no earlier than 2010-05-14 |  |  |  |  |  |  |
| 65 | 1.3.2.6.10 | Response to Reviewer Report |  | 5d? | 2010-05-17 | 2010-05-21 |  |  |  | 2010-05-17 | 2010-05-21 | 5d? | 0d |  | start no earlier than 2010-05-17 | Wizinowich [40%]; Dekany [20%]; Gavel [20%]; Max [20%]; Reinig [5%]; Kupke [2.5%]; Velur [5%]; Neyman [2.5%]; Lyke [2.5%]; Johansson [2.5%] | 48h |  | 3,000 | 3,000 |  |
| 66 | 1.3.2.7 | **Project Support** |  | 261d? | 2009-05-01 A | 2010-04-30 |  | 67% | 85.46d? | 2009-05-01 | 2010-04-30 | 261d? | 15d |  |  |  | 970h | 635.5h | 72,750.1 | 120,749.99 | 47,662.59 |
| 67 | 1.3.2.7.1 | Administrative/Contract Support |  | 261d? | 2009-05-01 A | 2010-04-30 |  | 65% | 91.35d? | 2009-05-01 | 2010-04-30 | 194d? | 15d |  | finish no earlier than 2010-04-30 | Tyau [35.9%]; UCO analyst [5.7%] | 870h | 565.5h | 65,250.1 | 56,249.99 | 42,412.59 |
| 68 | 1.3.2.7.2 | Shared Infrastructure |  | 215d? | 2009-05-04 A | 2010-02-26 |  | 70% | 64.5d? | 2009-05-04 | 2010-02-26 | 215d? | 60d |  | finish no earlier than 2010-02-26 | Chock [5.8%] | 100h | 70h | 7,500 | 7,500 | 5,250 |
| 69 | 1.3.3 | **Systems Engineering** |  | 261d? | 2009-05-01 A | 2010-04-30 |  | 41% | 154.84d? | 2008-05-01 | 2010-08-13 | 597d? | 15d |  |  |  | 8620h | 3846.98h | 556,650.01 | 627,451.25 | 254,410.43 |
| 70 | 1.3.3.1 | **Science Case Requirements** |  | 261d? | 2009-05-01 A | 2010-04-30 |  | 38% | 160.79d? | 2008-05-01 | 2010-01-29 | 457d? | 15d |  |  |  | 3092h | 1337.98h | 164,850 | 232,800 | 74,035.4 |
| 71 | 1.3.3.1.1 | **Science Case Requirements** |  | 238d? | 2009-05-01 A | 2010-03-30 |  | 28% | 171.84d? | 2008-05-01 | 2010-01-15 | 447d? | 38d |  |  |  | 1588h | 628.8h | 70,800 | 166,500 | 28,225.4 |
| 72 | 1.3.3.1.1.1 | **Science Simulations** |  | 238d? | 2009-05-01 A | 2010-03-30 |  | 28% | 170.51d? | 2008-05-01 | 2009-01-12 | 183d? | 38d |  |  |  | 1362h | 540.8h | 60,900 | 24,000 | 24,673.4 |
| 73 | 1.3.3.1.1.1.1 | High-z Galaxies |  | 227d? | 2009-05-01 A | 2010-03-15 |  | 55% | 102.15d? | 2009-05-01 | 2010-03-15 | 227d? | 49d |  | start no earlier than 2009-05-01 | McGrath [19.4%]; Max [5.5%]; Marchis [8.8%]; Neyman [1.1%] | 632h | 347.6h | 27,900 | 27,900 | 15,345 |
| 74 | 1.3.3.1.1.1.2 | BH Measurements in Nearby AGN |  | 207d? | 2009-05-01 A | 2010-02-15 |  | 50% | 103.5d? | 2009-05-01 | 2010-02-15 | 207d? | 69d |  | start no earlier than 2009-05-01 | McGrath [7.2%]; Max [6%] | 220h | 110h | 9,000 | 9,000 | 4,500 |
| 75 | 1.3.3.1.1.1.3 | Galactic Center |  | 186d? | 2009-05-01 | 2010-01-15 |  |  |  | 2009-05-01 | 2010-01-15 | 186d? | 90d |  | finish no earlier than 2010-01-15 | Max [1.3%] | 20h |  |  |  |  |
| 76 | 1.3.3.1.1.1.4 | Extrasolar Planets |  | 110d? | 2009-06-22 A | 2009-11-20 |  | 3% | 106.24d? | 2009-06-22 | 2009-11-20 | 110d? | 130d |  | start no earlier than 2009-06-22 | McGrath [4.5%]; Max [2.3%]; Marchis [9.1%]; Neyman [9.1%]; Macintosh [4.5%]; Crepp | 260h | 39h | 15,000 | 12,000 | 2,668.4 |
| 77 | 1.3.3.1.1.1.5 | Asteroids |  | 86d? | 2009-07-06 | 2009-11-02 |  |  |  | 2009-07-06 | 2009-11-02 | 86d? | 144d |  | start no earlier than 2009-07-06 | Marchis [5.8%] | 40h |  |  |  |  |
| 78 | 1.3.3.1.1.1.6 | Resolved Stellar Populations |  | 30d? | 2010-01-05 A | 2010-02-15 |  | 25% | 22.5d? | 2010-01-05 | 2010-02-15 | 30d? | 69d |  | start no earlier than 2010-01-05 | McGrath [16.7%]; Max [16.7%] | 80h | 20h | 3,000 | 3,000 | 750 |
| 79 | 1.3.3.1.1.1.7 | Debris Disks and QSO Host Galaxies |  | 32d? | 2009-11-02 A | 2009-12-15 |  | 7% | 29.76d? | 2009-11-02 | 2009-12-15 | 32d? | 113d |  | start no earlier than 2009-11-02 | McGrath [15.6%]; Max [7.8%] | 60h | 4.2h | 3,000 | 3,000 | 210 |
| 80 | 1.3.3.1.1.1.8 | Other Science Write-ups |  | 61d? | 2010-01-05 A | 2010-03-30 |  | 40% | 36.6d? | 2010-01-05 | 2010-03-30 | 61d? | 38d |  | start no earlier than 2010-01-05 | McGrath [8.2%]; Max [2%] | 50h | 20h | 3,000 | 3,000 | 1,200 |

Notes:
- 49: PW
- 50: PW
- 52: PW
- 55: PW
- 66: PW
- 69: RD
- 70: CM
- 71: CM
- 72: EM

| ID | WBS | Task | Duration | Start | Finish | Complete | Remaining | Baseline start | Baseline finish | Baseline duration | Total slack | Constraint | Resources | Work | Actual work | Cost | Baseline cost | Actual cost |
| --- | --- | --- | --- | --- | --- | --- | --- | --- | --- | --- | --- | --- | --- | --- | --- | --- | --- | --- |
| 81 | 1.3.3.1.1.2 | **Extend SCRD Discussion of Science Drivers** | 39d? | 2010-01-05 | 2010-02-26 |  |  | 2008-05-01 | 2008-12-22 | 168d? | 60d |  |  | 46h |  | 2,400 | 37,500 |  |
| 82 | 1.3.3.1.1.2.1 | Nearby AGNs | 39d? | 2010-01-05 | 2010-02-26 |  |  | 2010-01-05 | 2010-02-26 | 39d? | 60d | start no earlier than 2010-01-05 | McGrath [2.6%]; Max [1.9%] | 14h |  | 600 | 600 |  |
| 83 | 1.3.3.1.1.2.2 | Gravitational Lensing | 35d? | 2010-01-11 | 2010-02-26 |  |  | 2010-01-11 | 2010-02-26 | 35d? | 60d | start no earlier than 2010-01-11 | McGrath [1.4%]; Max [1.4%] | 8h |  | 300 | 300 |  |
| 84 | 1.3.3.1.1.2.3 | Backup Science | 20d? | 2010-02-01 | 2010-02-26 |  |  | 2010-02-01 | 2010-02-26 | 20d? | 60d | start no earlier than 2010-02-01 | McGrath [12.5%]; Max [2.5%] | 24h |  | 1,500 | 1,500 |  |
| 85 | 1.3.3.1.1.3 | Science Requirements Summary Matrix | 22d? | 2010-02-15 A | 2010-03-16 | 96% | 0.88d? | 2009-05-25 | 2010-01-08 | 165d? | 48d | start no earlier than 2010-02-15 | McGrath [122.7%]; Max [218.2%] | 40h | 16h | 1,500 | 6,000 | 852 |
| 86 | 1.3.3.1.1.4 | Review Science Requirements in Requirements Database | 43d? | 2009-05-18 A | 2009-07-15 | 90% | 4.3d? | 2009-05-18 | 2009-07-15 | 43d? | 222d | start no earlier than 2009-05-18 | McGrath [11.6%]; Max [11.6%] | 80h | 72h | 3,000 | 3,000 | 2,700 |
| 87 | 1.3.3.1.1.5 | SEMP Input | 75d? | 2009-12-07 | 2010-03-19 |  |  | 2009-10-05 | 2010-01-15 | 75d? | 45d | start no earlier than 2009-12-07 | McGrath [6.7%]; Max [3.3%] | 60h |  | 3,000 | 3,000 |  |
| 88 | 1.3.3.1.2 | **Science Observing Planning & Execution** | 43d? | 2009-05-01 A | 2009-06-30 | 65% | 15.05d? | 2008-08-04 | 2010-01-14 | 379d? | 233d |  |  | 66h | 42.9h | 2,700 | 31,500 | 1,755 |
| 89 | 1.3.3.1.2.1 | Develop Observing Scenarios for all Key Science Drivers | 43d? | 2009-05-01 A | 2009-06-30 | 65% | 15.05d? | 2009-05-01 | 2009-06-30 | 43d? | 233d | start no earlier than 2009-05-01 | McGrath [10.5%]; Max [8.7%] | 66h | 42.9h | 2,700 | 2,700 | 1,755 |
| 90 | 1.3.3.1.3 | **Science Performance Input** | 216d? | 2009-05-01 A | 2010-02-26 | 41% | 126.52d? | 2008-10-06 | 2009-12-18 | 315d? | 60d |  |  | 66h | 26.6h | 3,900 | 9,750 | 1,470 |
| 91 | 1.3.3.1.3.1 | Define Specific Science Driver Parameters for Performance Budgets | 110d? | 2009-06-22 | 2009-11-20 |  |  | 2009-06-22 | 2009-11-20 | 110d? | 130d | start no earlier than 2009-06-22 | McGrath [0.5%]; Max [0.5%] | 8h |  | 300 | 300 |  |
| 92 | 1.3.3.1.3.2 | Input to User Interfaces, Planning & Observing Tools | 39d? | 2010-01-05 | 2010-02-26 |  |  | 2010-01-05 | 2010-02-26 | 39d? | 60d | finish no earlier than 2010-02-26 | McGrath [6.4%] | 20h |  | 1,500 | 1,500 |  |
| 93 | 1.3.3.1.3.3 | Input to Preliminary Operations Concept Document | 216d? | 2009-05-01 A | 2010-02-26 | 70% | 64.8d? | 2009-05-01 | 2010-02-26 | 216d? | 60d | start no earlier than 2009-05-01 | McGrath [1.6%]; Max [0.6%] | 38h | 26.6h | 2,100 | 2,100 | 1,470 |
| 94 | 1.3.3.1.4 | **Science Competitiveness** | 231d? | 2009-05-01 A | 2010-03-19 | 32% | 158.23d? | 2008-07-07 | 2009-12-18 | 380d? | 45d |  |  | 62h | 19.68h | 2,850 | 7,800 | 900 |
| 95 | 1.3.3.1.4.1 | Update List of Science Goals for Other Facilities | 231d? | 2009-05-01 A | 2010-03-19 | 33% | 154.77d? | 2008-07-07 | 2009-12-18 | 380d? | 45d | start no earlier than 2009-05-01 | McGrath [1.1%]; Max [0.9%] | 36h | 11.88h | 1,500 | 3,300 | 495 |
| 96 | 1.3.3.1.4.2 | Evaluate NGAO Potential to Compliment Other Facilities | 231d? | 2009-05-01 A | 2010-03-19 | 30% | 161.7d? | 2008-07-07 | 2009-12-18 | 380d? | 45d | start no earlier than 2009-05-01 | McGrath [1%]; Max [0.4%] | 26h | 7.8h | 1,350 | 3,000 | 405 |
| 97 | 1.3.3.1.5 | **User Community Liaison** | 261d? | 2009-05-01 A | 2010-04-30 | 45% | 144.58d? | 2008-05-19 | 2010-01-29 | 445d? | 15d |  |  | 230h | 76h | 9,600 | 5,250 | 3,585 |
| 98 | 1.3.3.1.5.1 | **SSC & Keck Science Meeting** | 238d? | 2009-05-01 A | 2010-03-30 | 31% | 164.22d? | 2008-06-02 | 2010-01-29 | 435d? | 38d |  |  | 150h | 40.2h | 3,600 | 3,750 | 900 |
| 99 | 1.3.3.1.5.1.1 | Prepare & Give Presentations | 238d? | 2009-05-01 A | 2010-03-30 | 22% | 185.64d? | 2008-06-02 | 2010-01-29 | 435d? | 38d | start no earlier than 2009-05-01 | Max [3.7%]; McGrath [2.1%] | 110h | 24.2h | 3,000 | 3,000 | 660 |
| 100 | 1.3.3.1.5.1.2 | Obtain & Document Feedback | 238d? | 2009-05-01 A | 2010-03-30 | 40% | 142.8d? | 2008-06-02 | 2010-01-29 | 435d? | 38d | start no earlier than 2009-05-01 | Max [1.7%]; McGrath [0.4%] | 40h | 16h | 600 | 750 | 240 |
| 101 | 1.3.3.1.5.2 | Proposal Writing | 238d? | 2009-05-01 A | 2010-03-30 | 33% | 159.46d? | 2009-05-01 | 2010-03-30 | 238d? | 38d | start no earlier than 2009-05-01 | McGrath [3.2%] | 60h | 19.8h | 4,500 | 4,500 | 1,485 |
| 102 | 1.3.3.1.5.3 | Progress Reporting | 261d? | 2009-05-01 A | 2010-04-30 | 80% | 52.2d? | 2009-05-01 | 2010-04-30 | 261d? | 15d | start no earlier than 2009-05-01 | McGrath [1%] | 20h | 16h | 1,500 | 1,500 | 1,200 |
| 103 | 1.3.3.1.6 | **Science Advisory Team Meetings** | 261d? | 2009-05-01 A | 2010-04-30 | 47% | 137.39d? | 2008-06-09 | 2009-11-27 | 385d? | 15d |  |  | 120h | 64h | 3,000 | 12,000 | 2,100 |
| 104 | 1.3.3.1.6.1 | Prepare Minutes, Presentations & KAONs | 261d? | 2009-05-01 A | 2010-04-30 | 70% | 78.3d? | 2008-06-09 | 2009-11-27 | 385d? | 15d | start no earlier than 2009-05-01 | Max [1.9%]; McGrath [1.9%] | 80h | 56h | 3,000 | 7,500 | 2,100 |
| 105 | 1.3.3.1.6.2 | Evaluate Science Impact of Proposed Changes | 216d? | 2009-05-01 A | 2010-02-26 | 20% | 172.8d? | 2008-07-21 | 2009-11-27 | 355d? | 60d | start no earlier than 2009-05-01 | Max [2.3%] | 40h | 8h |  | 3,000 |  |
| 106 | 1.3.3.1.7 | Science Postdoc Research Time | 261d? | 2009-05-01 A | 2010-04-30 | 50% | 130.5d? | 2009-05-01 | 2010-04-30 | 261d? | 15d | finish no earlier than 2010-04-30 | McGrath [46%] | 960h | 480h | 72,000 | 72,000 | 36,000 |

Notes:
- 81: EM
- 88: EM
- 90: EM
- 94: CM
- 97: CM
- 103: CM
- 106: EM

| ID | WBS | Task | Duration | Start | Finish | Predecessors | Complete | Remaining | Baseline start | Baseline finish | Baseline duration | Total slack | Free slack | Constraint | Resources | Work | Actual work | Cost | Baseline cost | Actual cost |
| --- | --- | --- | --- | --- | --- | --- | --- | --- | --- | --- | --- | --- | --- | --- | --- | --- | --- | --- | --- | --- |
| 107 | 1.3.3.2 | **Requirements** | 239d? | 2009-05-01 A | 2010-03-31 |  | 44% | 133.29d? | 2009-05-01 | 2010-04-20 | 252.67d? | 37d |  |  |  | 1156h | 555.5h | 71,400.01 | 79,500 | 38,362.52 |
| 108 | 1.3.3.2.1 | **Operations Concept Document (OCD)** | 166d? | 2009-05-01 A | 2009-12-18 |  | 36% | 106.16d? | 2009-05-01 | 2009-12-18 | 166d? | 110d |  |  |  | 356h | 96h | 11,400 | 11,250 | 3,900 |
| 109 | 1.3.3.2.1.1 | OOCD Release 1 | 31d? | 2009-05-01 A | 2009-06-12 A |  | 100% |  | 2009-05-01 | 2009-06-17 | 33.33d? |  |  | start no earlier than 2009-05-01 | Marchis [16.1%]; Bouchez [16.1%]; Wizinowich [4.8%]; Ragland [1.6%] | 96h | 96h | 3,900 | 5,250 | 3,900 |
| 110 | 1.3.3.2.1.2 | OOCD Release 2 | 55d? | 2009-10-05 | 2009-12-18 |  |  |  | 2009-10-05 | 2009-12-18 | 55d? | 110d |  | start no earlier than 2009-10-05 | Marchis [36.4%]; Bouchez [18.2%]; Neyman [2.3%]; Wizinowich [2.3%] | 260h |  | 7,500 | 6,000 |  |
| 111 | 1.3.3.2.2 | **System Requirements (SRD)** | 161d? | 2009-05-01 A | 2009-12-11 |  | 83% | 26.83d? | 2009-05-01 | 2009-12-11 | 161d? | 115d |  |  |  | 280h | 230h | 21,000 | 29,250 | 17,250 |
| 112 | 1.3.3.2.2.1 | SRD PD Release 1 | 50d? | 2009-05-01 A | 2009-07-09 A |  | 100% |  | 2009-05-01 | 2009-07-09 | 50d? |  |  | start no earlier than 2009-05-01 | Johansson [5%]; Neyman [12.5%]; Dekany [2.5%]; Velur [10%]; Gavel [10%]; Wizinowich [5%] | 180h | 180h | 13,500 | 21,750 | 13,500 |
| 113 | 1.3.3.2.2.2 | SRD PD Release 2 | 25d? | 2009-11-09 A | 2009-12-11 |  | 50% | 12.5d? | 2009-11-09 | 2009-12-11 | 25d? | 115d |  | start no earlier than 2009-11-09 | Johansson [5%]; Neyman [25%]; Dekany [5%]; Gavel [15%] | 100h | 50h | 7,500 | 7,500 | 3,750 |
| 114 | 1.3.3.2.3 | **Functional Requirements (FRD)** | 239d? | 2009-05-01 A | 2010-03-31 |  | 42% | 139.42d? | 2009-05-01 | 2010-04-20 | 252.67d? | 37d |  |  |  | 430h | 229.5h | 32,250.01 | 32,250 | 17,212.52 |
| 115 | 1.3.3.2.3.1 | FRD PD Release 1 | 50d? | 2009-05-01 A | 2009-07-09 |  | 78% | 11.25d? | 2009-05-01 | 2009-07-09 | 50d? | 226d |  | start no earlier than 2009-05-01 | Johansson [33%]; Wizinowich [15%]; Gavel [10%]; Velur [10%]; Chin [10%] | 270h | 229.5h | 20,250.01 | 20,250 | 17,212.52 |
| 116 | 1.3.3.2.3.2 | FRD PD Release 2 | 20d? | 2010-02-01 | 2010-02-26 |  |  |  | 2010-02-01 | 2010-03-10 | 28d? | 60d |  | finish no earlier than 2010-02-26 | Johansson [25%]; Dekany [7.1%]; Velur [15%]; Neyman [15%]; Chin [15%]; Wizinowich [15%] | 80h |  | 6,000 | 6,000 |  |
| 117 | 1.3.3.2.3.3 | Compliance Matrix | 23d? | 2010-03-01 | 2010-03-31 |  |  |  | 2010-03-15 | 2010-04-20 | 26.67d? | 37d |  | finish no earlier than 2010-03-31 | Johansson [43.5%] | 80h |  | 6,000 | 6,000 |  |
| 118 | 1.3.3.2.4 | Software Standards (Define & Document) | 25d? | 2009-05-01 | 2009-06-04 |  |  |  | 2009-05-01 | 2009-06-04 | 25d? | 251d |  | start no earlier than 2009-05-01 | Johansson [5%] | 10h |  | 750 | 750 |  |
| 119 | 1.3.3.2.5 | Component Standards (Define & Document) | 20d? | 2010-01-04 | 2010-01-29 |  |  |  | 2009-08-17 | 2010-01-01 | 100d? | 80d |  | finish no earlier than 2010-01-29 | Johansson [25%]; Wetherell [25%] | 80h |  | 6,000 | 6,000 |  |
| 120 | 1.3.3.3 | **Systems Engineering Analysis** | 252d? | 2009-05-01 A | 2010-04-19 |  | 46% | 137.01d? | 2009-04-16 | 2010-08-13 | 347d? | 24d |  |  |  | 1952h | 746.1h | 138,900 | 133,800 | 51,457.5 |
| 121 | 1.3.3.3.1 | **Performance Budgets** | 166.67d? | 2009-05-01 A | 2009-12-21 |  | 67% | 55.68d? | 2009-04-16 | 2010-01-22 | 202d? | 90.58d | 0d |  |  | 720h | 495.1h | 46,500 | 36,000 | 32,632.5 |
| 122 | 1.3.3.3.1.1 | **Wavefront Error and Ensquared Energy** | 132.29d? | 2009-05-01 A | 2009-11-03 |  | 87% | 17.29d? | 2009-04-16 | 2009-10-26 | 137.67d? | 124.96d |  |  |  | 206h | 161h | 15,450 | 15,000 | 12,075 |
| 123 | 1.3.3.3.1.1.1 | LOWFS Sharpening WFE Budgets | 50d? | 2009-05-08 A | 2009-07-16 A | 127 | 100% |  | 2009-05-08 | 2009-07-16 | 50d? |  |  | start no earlier than 2008-10-06 | Dekany [10%] | 40h | 40h | 3,000 | 3,000 | 3,000 |
| 124 | 1.3.3.3.1.1.2 | LOWFS Low-order/Blind mode WFE Budget vs. Sky Coverage (linked) | 15d? | 2009-08-12 | 2009-09-01 | 168 |  |  | 2009-07-14 | 2009-08-03 | 15d? | 169.25d |  | start no earlier than 2009-04-17 | Neyman [25%] | 30h |  | 2,250 | 2,250 |  |
| 125 | 1.3.3.3.1.1.3 | Truth WFS Performance Budget | 15.62d? | 2009-08-28 A | 2009-09-18 A | 123 | 100% |  | 2009-07-17 | 2009-08-27 | 30d? |  |  | start no earlier than 2009-08-28 | Troy [24%] | 30h | 30h | 2,250 | 1,800 | 2,250 |
| 126 | 1.3.3.3.1.1.4 | **Science Wavefront Error Flowdown Budgets** | 125.62d? | 2009-05-01 A | 2009-10-23 |  | 92% | 10.35d? | 2009-04-16 | 2009-10-15 | 131d? | 131.62d |  |  |  | 90h | 77h | 6,750 | 6,750 | 5,775 |
| 127 | 1.3.3.3.1.1.4.1 | Requirements Flowdown Methodology Memo | 5d? | 2009-05-01 A | 2009-05-07 A |  | 100% |  | 2009-05-01 | 2009-05-07 | 5d? |  |  | start no earlier than 2009-05-01 | Dekany [15%] | 6h | 6h | 450 | 450 | 450 |
| 128 | 1.3.3.3.1.1.4.2 | Laser Photoreturn Budget Flowdown | 10d? | 2009-05-04 A | 2009-05-15 A |  | 100% |  | 2009-04-20 | 2009-05-01 | 10d? |  |  | start no earlier than 2009-05-04 | Velur [15%] | 12h | 12h | 900 | 900 | 900 |
| 129 | 1.3.3.3.1.1.4.3 | Correction Latency Budget Flowdown | 10d? | 2009-10-09 A | 2009-10-23 | 147 | 75% | 2.5d? | 2009-10-02 | 2009-10-15 | 10d? | 129.96d | 0d | start no earlier than 2009-04-18 | Gavel [15%] | 12h | 9h | 900 | 900 | 675 |
| 130 | 1.3.3.3.1.1.4.4 | Science Transmission Budget Flowdown | 10d? | 2009-05-08 A | 2009-05-21 A | 127 | 100% |  | 2009-05-08 | 2009-05-21 | 10d? |  |  | start no earlier than 2009-05-01 | Kupke [15%] | 12h | 12h | 900 | 900 | 900 |
| 131 | 1.3.3.3.1.1.4.5 | Non-common Path WFE Budget Flowdown | 40d? | 2009-05-04 A | 2009-06-26 A |  | 100% |  | 2009-04-16 | 2009-04-27 | 8d? |  |  | start no earlier than 2009-05-04 | Velur [5%] | 16h | 16h | 1,200 | 1,200 | 1,200 |
| 132 | 1.3.3.3.1.1.4.6 | Uncorrectable Internal WFE Budget Flowdown | 6d? | 2009-05-04 A | 2009-05-11 A |  | 100% |  | 2009-04-16 | 2009-04-23 | 6d? |  |  | start no earlier than 2009-05-04 | Kupke [25%] | 12h | 12h | 900 | 900 | 900 |
| 133 | 1.3.3.3.1.1.4.7 | Actuator-Pupil Registration Budget Flowdown | 10d? | 2009-05-01 A | 2009-05-14 |  | 50% | 5d? | 2009-05-01 | 2009-05-14 | 10d? | 247.25d |  | start no earlier than 2009-05-01 | Delacroix [25%] | 20h | 10h | 1,500 | 1,500 | 750 |

Notes:
- 107: EJ
- 108: FM
- 109: FM
- 110: FM
- 111: EJ
- 112: EJ
- 113: CN
- 114: EJ
- 115: EJ
- 116: EJ
- 117: EJ
- 118: EJ
- 119: EJ
- 120: RD
- 121: RD
- 123: RD
- 124: CN
- 125: MT
- 127: RD
- 128: VV
- 129: DG
- 130: RK
- 131: VV
- 132: RK
- 133: VV

| ID | WBS | Task | Duration | Start | Finish | Predecessors | Complete | Remaining | Baseline start | Baseline finish | Baseline duration | Total slack | Free slack | Constraint | Resources | Work | Actual work | Cost | Baseline cost | Actual cost |
| --- | --- | --- | --- | --- | --- | --- | --- | --- | --- | --- | --- | --- | --- | --- | --- | --- | --- | --- | --- | --- |
| 134 | 1.3.3.3.1.1.5 | **LOWFS Wavefront Error Flowdown Budgets** | 131.29d? | 2009-05-04 A | 2009-11-03 |  | 88% | 16.41d? | 2009-04-20 | 2009-10-26 | 135.67d? | 124.96d |  |  |  | 16h | 14h | 1,200 | 1,200 | 1,050 |
| 135 | 1.3.3.3.1.1.5.1 | LOWFS Uncorrectable Internal WFE Budget Flowdown | 6.67d? | 2009-05-04 A | 2009-05-12 A |  | 100% |  | 2009-04-20 | 2009-04-28 | 6.67d? |  |  | start no earlier than 2009-05-04 | Velur [15%] | 8h | 8h | 600 | 600 | 600 |
| 136 | 1.3.3.3.1.1.5.2 | LOWFS Servo Latency Budget Flowdown | 6.67d? | 2009-10-23 A | 2009-11-03 | 129, 147 | 75% | 1.67d? | 2009-10-16 | 2009-10-26 | 6.67d? | 124.96d |  | start no earlier than 2009-04-18 | Gavel [15%] | 8h | 6h | 600 | 600 | 450 |
| 137 | 1.3.3.3.1.2 | **Astrometric Precision** | 125d? | 2009-05-04 A | 2009-10-23 |  | 55% | 56.63d? | 2009-04-20 | 2009-09-11 | 105d? | 131.25d |  |  |  | 204h | 109.6h | 7,800 | 7,800 | 3,720 |
| 138 | 1.3.3.3.1.2.1 | Develop Astrometric Budget Tool | 41.67d? | 2009-07-30 A | 2009-09-25 A | 143 | 100% |  | 2009-06-01 | 2009-08-14 | 55d? |  |  | start no earlier than 2009-06-01 | Lu [18%]; Crepp [12%] | 100h | 100h | 3,000 | 3,000 | 3,000 |
| 139 | 1.3.3.3.1.2.2 | Galactic Center Astrometric Analysis | 20d? | 2009-09-28 | 2009-10-23 | 138 |  |  | 2009-08-17 | 2009-09-11 | 20d? | 131.25d |  | start no earlier than 2009-01-05 | Lu [25%] | 40h |  |  |  |  |
| 140 | 1.3.3.3.1.2.3 | **Astrometric Precision Flowdown Budgets** | 20d? | 2009-05-04 A | 2009-05-29 |  | 15% | 17d? | 2009-04-20 | 2009-04-29 | 8d? | 236.25d |  |  |  | 64h | 9.6h | 4,800 | 4,800 | 720 |
| 141 | 1.3.3.3.1.2.3.1 | Dimensional Stability Budget Flowdown | 20d? | 2009-05-04 A | 2009-05-29 |  | 15% | 17d? | 2009-04-20 | 2009-04-29 | 8d? | 236.25d |  | start no earlier than 2009-05-04 | Kupke [10%]; Velur [10%]; Lockwood [10%]; Delacroix [10%] | 64h | 9.6h | 4,800 | 4,800 | 720 |
| 142 | 1.3.3.3.1.3 | **High Contrast** | 59.33d? | 2009-06-15 A | 2009-09-04 |  | 98% | 1.3d? |  |  |  | 166.92d |  |  |  | 160h | 156h | 12,000 |  | 11,700 |
| 143 | 1.3.3.3.1.3.1 | High Contrast Error Budget | 33.33d? | 2009-06-15 A | 2009-07-30 A |  | 100% |  |  |  |  |  |  | start no earlier than 2009-06-15 | Crepp [30%] | 80h | 80h | 6,000 |  | 6,000 |
| 144 | 1.3.3.3.1.3.2 | High Contrast Error Flowdown | 26d? | 2009-07-30 A | 2009-09-04 | 143 | 95% | 1.3d? |  |  |  | 166.92d |  |  | Crepp [38.5%] | 80h | 76h | 6,000 |  | 5,700 |
| 145 | 1.3.3.3.1.4 | **WFE/EE Budget Tool** | 166.67d? | 2009-05-01 A | 2009-12-21 |  | 47% | 87.7d? | 2009-04-20 | 2010-01-22 | 200d? | 90.58d |  |  |  | 150h | 68.5h | 11,250 | 13,200 | 5,137.5 |
| 146 | 1.3.3.3.1.4.1 | Science Cases Performance Analysis | 50d? | 2009-06-17 A | 2009-08-25 | 127 | 18% | 40.91d? | 2009-05-08 | 2009-08-17 | 71.43d? | 174.25d |  | start no earlier than 2009-06-17 | Troy [6%]; Dekany [5%] | 40h | 8h | 3,000 | 3,000 | 600 |
| 147 | 1.3.3.3.1.4.2 | Improved Servo Bandwidth Model | 15d? | 2009-09-18 A | 2009-10-09 | 125 | 25% | 11.25d? | 2009-08-28 | 2009-10-01 | 25d? | 137.46d | 0d | start no earlier than 2008-12-01 | Troy [15%]; Gavel [20%] | 42h | 10.5h | 3,150 | 3,600 | 787.5 |
| 148 | 1.3.3.3.1.4.3 | Update Star Density Model(s) | 10d? | 2009-07-27 A | 2009-08-07 A |  | 100% |  | 2009-08-03 | 2009-08-11 | 6.67d? |  |  | start no earlier than 2009-07-27 | Troy [10%] | 8h | 8h | 600 | 600 | 600 |
| 149 | 1.3.3.3.1.4.4 | Other WFE/EE Budget Tool Maintenance | 166.67d? | 2009-05-01 A | 2009-12-21 |  | 55% | 75d? | 2009-04-20 | 2010-01-22 | 200d? | 0d |  | start no earlier than 2009-05-01 | Dekany [3%]; Troy [3%] | 60h | 42h | 4,500 | 6,000 | 3,150 |
| 150 | 1.3.3.3.2 | **Engineering Budgets** | 191.67d? | 2009-05-01 A | 2010-01-25 |  | 80% | 38.79d? | 2009-04-21 | 2010-02-26 | 224d? | 84.33d |  |  |  | 140h | 115h | 10,500 | 10,500 | 8,625 |
| 151 | 1.3.3.3.2.1 | **Observing Efficiency** | 33.33d? | 2009-05-25 A | 2009-07-09 A |  | 100% |  | 2009-05-14 | 2009-06-30 | 33.33d? |  |  |  |  | 40h | 40h | 3,000 | 3,000 | 3,000 |
| 152 | 1.3.3.3.2.1.1 | Observing Efficiency Analysis | 33.33d? | 2009-05-25 A | 2009-07-09 A |  | 100% |  | 2009-05-14 | 2009-06-30 | 33.33d? |  |  | start no earlier than 2009-05-25 | Bouchez [15%] | 40h | 40h | 3,000 | 3,000 | 3,000 |
| 153 | 1.3.3.3.2.2 | **Observing Uptime** | 100d? | 2009-05-01 A | 2009-09-17 |  | 88% | 12.5d? | 2009-05-01 | 2009-09-17 | 100d? | 176d |  |  |  | 80h | 70h | 6,000 | 6,000 | 5,250 |
| 154 | 1.3.3.3.2.2.1 | Develop Observing Uptime Tool | 50d? | 2009-05-01 A | 2009-07-09 A |  | 100% |  | 2009-05-01 | 2009-07-09 | 50d? |  |  | start no earlier than 2009-05-01 | Neyman [10%] | 40h | 40h | 3,000 | 3,000 | 3,000 |
| 155 | 1.3.3.3.2.2.2 | Observing Uptime Analysis | 50d? | 2009-07-10 A | 2009-09-17 | 154 | 75% | 12.5d? | 2009-07-10 | 2009-09-17 | 50d? | 176d |  |  | Chin [1%]; Neyman [9%] | 40h | 30h | 3,000 | 3,000 | 2,250 |
| 156 | 1.3.3.3.2.3 | Electrical Power Usage Budget | 25d? | 2009-12-21 A | 2010-01-25 | 121 | 25% | 18.75d? | 2010-01-25 | 2010-02-26 | 25d? | 84.33d |  | start no earlier than 2009-04-16 | Wetherell [10%] | 20h | 5h | 1,500 | 1,500 | 375 |
| 157 | 1.3.3.3.2.4 | Heat Dissipation Budget | 1d? | 2009-05-15 | 2009-05-15 |  |  |  | 2009-04-21 | 2009-04-21 | 1d? | 265d |  | start no earlier than 2009-05-15 |  |  |  |  |  |  |

Notes:
- 135: VV
- 136: DG
- 137: PW
- 142: JC
- 145: RD
- 146: RD
- 147: DG
- 148: MT
- 149: RD
- 151: AB
- 153: CN
- 156: EW

| ID | WBS | Task | Duration | Start | Finish | Predecessors | Complete | Remaining | Baseline start | Baseline finish | Baseline duration | Total slack | Free slack | Constraint | Deadline | Resources | Work | Actual work | Cost | Baseline cost | Actual cost |
| --- | --- | --- | --- | --- | --- | --- | --- | --- | --- | --- | --- | --- | --- | --- | --- | --- | --- | --- | --- | --- | --- |
| 158 | 1.3.3.3.3 | **Modeling & Analysis** | 252d? | 2009-05-01 A | 2010-04-19 |  | 25% | 190.04d? | 2009-04-21 | 2010-08-13 | 344d? | 24d |  |  |  |  | 1012h | 136h | 75,900 | 87,300 | 10,200 |
| 159 | 1.3.3.3.3.1 | Sys Eng Support for Proposal Efforts | 239d? | 2009-05-01 A | 2010-03-31 |  | 50% | 119.5d? | 2009-05-01 | 2010-04-15 | 250d? | 37d |  | finish no earlier than 2010-03-31 |  | Dekany [2.1%] | 40h | 20h | 3,000 | 3,000 | 1,500 |
| 160 | 1.3.3.3.3.2 | Point and Shoot Subsystem Report | 23d? | 2009-11-16 | 2009-12-16 | 123, 172 |  |  | 2009-11-16 | 2010-01-22 | 50d? | 45.5d | 0d | start no earlier than 2009-11-16 |  | Neyman [54.3%]; Gavel [21.7%]; Delacroix [33%] | 180h |  | 13,500 | 15,000 |  |
| 161 | 1.3.3.3.3.3 | Performance vs T/T NGS Report | 25.5d? | 2009-12-17 | 2010-01-21 | 160 |  |  | 2010-01-25 | 2010-04-30 | 70d? | 45.5d | 0d | start no earlier than 2008-09-01 |  | Dekany [9.8%]; Neyman [33%] | 60h |  | 4,500 | 9,000 |  |
| 162 | 1.3.3.3.3.4 | Galactic Center Performance Report | 41d? | 2010-01-21 | 2010-03-19 | 161, 172 |  |  | 2010-05-03 | 2010-08-13 | 75d? | 45.5d |  | start no earlier than 2009-03-02 |  | Crepp [42.7%]; Neyman [12.2%] | 180h |  | 13,500 | 13,500 |  |
| 163 | 1.3.3.3.3.5 | PSF Libraries (moved by linked tasks) | 124d? | 2009-10-28 | 2010-04-19 | 172 |  |  | 2009-09-29 | 2010-04-26 | 150d? | 24d |  | finish no earlier than 2010-03-19 |  | Neyman [12.1%] | 120h |  | 9,000 | 9,000 |  |
| 164 | 1.3.3.3.3.6 | Additional Performance Modeling/Anchoring | 27.5d? | 2010-02-10 A | 2010-03-19 |  | 50% | 13.75d? | 2010-01-04 | 2010-05-21 | 100d? | 45d |  | finish no earlier than 2010-03-19 |  | Dekany [7.3%]; Neyman [18.2%]; Gavel [7.3%] | 72h | 36h | 5,400 | 10,800 | 2,700 |
| 165 | 1.3.3.3.3.7 | **Integrated modeling** | 107d? | 2009-06-01 A | 2009-10-27 |  | 13% | 93.52d? | 2009-04-21 | 2009-09-28 | 115d? | 148d |  |  |  |  | 360h | 80h | 27,000 | 27,000 | 6,000 |
| 166 | 1.3.3.3.3.7.1 | MOAO capabilities added to LAOS | 32d? | 2009-06-01 A | 2009-07-14 |  | 50% | 16d? | 2009-04-21 | 2009-06-15 | 40d? | 24d | 0d | start no earlier than 2009-06-01 |  | Neyman [62.5%] | 160h | 80h | 12,000 | 12,000 | 6,000 |
| 167 | 1.3.3.3.3.7.2 | Na Focus NGS focus | 20d? | 2009-07-15 | 2009-08-11 | 166 |  |  | 2009-06-16 | 2009-07-13 | 20d? | 203d |  | start no earlier than 2009-04-21 |  | Neyman [25%] | 40h |  | 3,000 | 3,000 |  |
| 168 | 1.3.3.3.3.7.3 | Tracking, Null mode & Blind Modes | 20d? | 2009-07-15 | 2009-08-11 | 166 |  |  | 2009-06-16 | 2009-07-13 | 20d? | 24d | 0d | start no earlier than 2009-04-21 |  | Neyman [25%] | 40h |  | 3,000 | 3,000 |  |
| 169 | 1.3.3.3.3.7.4 | Keck Pupil Rotation Effects (Analog Keck II PRC system) | 5d? | 2009-08-12 | 2009-08-18 | 168 |  |  | 2009-07-14 | 2009-07-20 | 5d? | 24d | 0d | start no earlier than 2009-04-21 |  | Neyman [25%] | 10h |  | 750 | 750 |  |
| 170 | 1.3.3.3.3.7.5 | WFS Physical Optics Effects (Na Var., Spot Var., DM-Lens Reg., etc.) | 25d? | 2009-08-19 | 2009-09-22 | 169 |  |  | 2009-07-21 | 2009-08-24 | 25d? | 24d | 0d | start no earlier than 2009-04-21 |  | Neyman [25%] | 50h |  | 3,750 | 3,750 |  |
| 171 | 1.3.3.3.3.7.6 | Cn2 Variability | 5d? | 2009-09-23 | 2009-09-29 | 170 |  |  | 2009-08-25 | 2009-08-31 | 5d? | 24d | 0d | start no earlier than 2009-04-21 |  | Neyman [50%] | 20h |  | 1,500 | 1,500 |  |
| 172 | 1.3.3.3.3.7.7 | "All- in" simulations (Suggested links to other tasks) | 20d? | 2009-09-30 | 2009-10-27 | 168, 171 |  |  | 2009-09-01 | 2009-09-28 | 20d? | 24d | 0d | start no earlier than 2009-04-21 |  | Neyman [25%] | 40h |  | 3,000 | 3,000 |  |
| 173 | 1.3.3.3.4 | PSF Calibration | 100d? | 2009-07-01 | 2009-11-17 |  |  |  | 2009-07-01 | 2009-11-17 | 100d? | 133d |  | start no earlier than 2009-07-01 |  | Conrad [10%] | 80h |  | 6,000 | 6,000 |  |
| 174 | 1.3.3.4 | **System Architecture** | 216d? | 2009-05-01 A | 2010-02-26 |  | 61% | 83.96d? | 2009-05-01 | 2010-04-02 | 241d? | 60d |  |  |  |  | 1440h | 996h | 108,000 | 93,450 | 74,700 |
| 175 | 1.3.3.4.1 | **System Hardware Architecture** | 176d? | 2009-05-08 A | 2010-01-08 |  | 70% | 52.8d? | 2009-05-08 | 2009-11-11 | 133.33d? | 95d |  |  |  |  | 180h | 126h | 13,500 | 13,500 | 9,450 |
| 176 | 1.3.3.4.1.1 | Maintain Hardware Architecture | 176d? | 2009-05-08 A | 2010-01-08 |  | 70% | 52.8d? | 2009-05-08 | 2009-11-11 | 133.33d? | 95d |  | start no earlier than 2009-05-08 |  | Neyman [3.7%]; Wizinowich [2.3%]; Gavel [2.3%]; Johansson [2.3%]; McGrath [2.3%] | 180h | 126h | 13,500 | 13,500 | 9,450 |
| 177 | 1.3.3.4.2 | **Software Architecture** | 66d? | 2009-05-01 A | 2009-07-31 |  | 80% | 13.02d? | 2009-05-01 | 2009-07-16 | 55d? | 210d |  |  |  |  | 660h | 600h | 49,500 | 46,500 | 45,000 |
| 178 | 1.3.3.4.2.1 | Container-Component Model | 5d? | 2009-05-01 A | 2009-05-07 A |  | 100% |  | 2009-05-01 | 2009-05-07 | 5d? |  |  | start no earlier than 2009-05-01 |  | Johansson [40%]; Morrison [50%]; Johnson [10%] | 40h | 40h | 3,000 | 2,700 | 3,000 |
| 179 | 1.3.3.4.2.2 | **Controls SW Infrastructure** | 41d? | 2009-05-08 A | 2009-07-03 A | 178 | 100% |  | 2009-05-08 | 2009-06-11 | 25d? |  |  |  |  |  | 300h | 300h | 22,500 | 24,300 | 22,500 |
| 180 | 1.3.3.4.2.2.1 | Class decomposition | 5d | 2009-05-08 A | 2009-05-14 A |  | 100% |  | 2009-05-08 | 2009-05-14 | 5d |  |  | start no earlier than 2009-05-08 | 2009-04-19 | Johansson [40%]; Morrison [50%]; Johnson [10%] | 40h | 40h | 3,000 | 2,700 | 3,000 |
| 181 | 1.3.3.4.2.2.2 | Command-response pattern | 2.5d | 2009-05-15 A | 2009-05-19 A | 180 | 100% |  | 2009-05-15 | 2009-05-19 | 2.5d |  |  | start no earlier than 2009-05-15 |  | Johansson [40%]; Morrison [50%]; Johnson [10%] | 20h | 20h | 1,500 | 1,350 | 1,500 |
| 182 | 1.3.3.4.2.2.3 | Base component definition | 5d | 2009-05-19 A | 2009-05-26 A | 181 | 100% |  | 2009-05-19 | 2009-05-26 | 5d |  |  | start no earlier than 2009-05-19 |  | Johansson [40%]; Morrison [50%]; Johnson [10%] | 40h | 40h | 3,000 | 2,700 | 3,000 |
| 183 | 1.3.3.4.2.2.4 | Middleware abstraction | 5d? | 2009-05-26 A | 2009-06-02 A | 182 | 100% |  | 2009-05-26 | 2009-06-02 | 5d? |  |  | start no earlier than 2009-05-26 |  | Johansson [40%]; Morrison [50%]; Johnson [10%] | 40h | 40h | 3,000 | 2,700 | 3,000 |
| 184 | 1.3.3.4.2.2.5 | Naming Scheme | 2.5d? | 2009-06-02 A | 2009-06-04 A | 183 | 100% |  | 2009-05-08 | 2009-05-12 | 2.5d? |  |  | start no earlier than 2009-05-08 |  | Johansson [40%]; Morrison [50%]; Johnson [10%] | 20h | 20h | 1,500 | 1,350 | 1,500 |
| 185 | 1.3.3.4.2.2.6 | Configuration | 11d | 2009-06-05 A | 2009-06-19 A | 184 | 100% |  | 2009-05-08 | 2009-05-28 | 15d |  |  | start no earlier than 2009-05-08 |  | Johansson [9.1%]; Morrison [52.3%]; Johnson [6.8%] | 60h | 60h | 4,500 | 8,100 | 4,500 |
| 186 | 1.3.3.4.2.2.7 | Common services | 10d? | 2009-06-22 A | 2009-07-03 A | 185 | 100% |  | 2009-05-29 | 2009-06-11 | 10d? |  |  | start no earlier than 2009-05-29 |  | Johansson [40%]; Morrison [50%]; Johnson [10%] | 80h | 80h | 6,000 | 5,400 | 6,000 |
| 187 | 1.3.3.4.2.3 | Sequencer Architecture | 5d? | 2009-07-06 A | 2009-07-10 A | 186 | 100% |  | 2009-06-12 | 2009-06-25 | 10d? |  |  | start no earlier than 2009-06-26 |  | Johansson [20%]; Morrison; Johnson [80%] | 80h | 80h | 6,000 | 5,400 | 6,000 |
| 188 | 1.3.3.4.2.4 | UI Architecture | 5d? | 2009-07-13 A | 2009-07-17 A | 187 | 100% |  | 2009-06-26 | 2009-07-02 | 5d? |  |  | start no earlier than 2009-06-26 |  | Johansson [10%]; Morrison [50%]; Johnson [40%] | 40h | 40h | 3,000 | 2,700 | 3,000 |
| 189 | 1.3.3.4.2.5 | Middleware Evaluation | 43d? | 2009-05-01 A | 2009-06-30 |  | 50% | 21.5d? | 2009-05-01 | 2009-06-30 | 43d? | 233d |  | finish no earlier than 2009-06-30 |  | Johansson [11.6%]; Morrison [11.6%]; Johnson [11.6%] | 120h | 60h | 9,000 | 6,000 | 4,500 |
| 190 | 1.3.3.4.2.6 | Document software architecture | 10d? | 2009-07-20 A | 2009-07-31 A | 188, 189 | 100% |  | 2009-07-03 | 2009-07-16 | 10d? |  |  | start no earlier than 2009-07-03 |  | Johansson [10%]; Morrison [50%]; Johnson [40%] | 80h | 80h | 6,000 | 5,400 | 6,000 |

Notes:
- 158: RD
- 159: RD
- 160: CN
- 161: CN
- 162: JC
- 163: CN
- 164: CN
- 165: CN
- 173: AC
- 174: PW
- 175: PW
- 177: EJ
- 179: EJ

| ID | WBS | Task | Duration | Start | Finish | Predecessors | Complete | Remaining | Baseline start | Baseline finish | Baseline duration | Total slack | Free slack | Constraint | Resources | Work | Actual work | Cost | Baseline cost | Actual cost |
| --- | --- | --- | --- | --- | --- | --- | --- | --- | --- | --- | --- | --- | --- | --- | --- | --- | --- | --- | --- | --- |
| 191 | 1.3.3.4.3 | **Control Systems Architecture** | 206d? | 2009-05-15 A | 2010-02-26 |  | 64% | 74.44d? | 2009-05-01 | 2010-04-02 | 241d? | 60d |  |  |  | 480h | 270h | 36,000 | 33,450 | 20,250 |
| 192 | 1.3.3.4.3.1 | Controls hierarchy and philosophy | 5d? | 2009-08-03 | 2009-08-07 | 190 |  |  | 2010-02-22 | 2010-02-26 | 5d? | 205d |  |  | Johansson [40%]; Morrison [50%]; Johnson [10%] | 40h |  | 3,000 | 2,700 |  |
| 193 | 1.3.3.4.3.2 | Common state machine design | 5d? | 2009-08-10 A | 2009-08-14 A | 192 | 100% |  | 2010-03-01 | 2010-03-05 | 5d? |  |  | start no earlier than 2008-07-17 | Johansson [40%]; Johnson [10%]; Morrison [50%] | 40h | 40h | 3,000 | 2,700 | 3,000 |
| 194 | 1.3.3.4.3.3 | Class-Responsibility-Collaborator model | 10d? | 2009-08-17 A | 2009-08-28 | 193 | 50% | 5d? | 2010-03-08 | 2010-03-19 | 10d? | 75.78d | 0d |  | Johansson [40%]; Johnson [10%]; Morrison [50%] | 80h | 40h | 6,000 | 5,400 | 3,000 |
| 195 | 1.3.3.4.3.4 | Main sequence definition | 10d? | 2009-08-31 A | 2009-09-11 | 194 | 50% | 5d? | 2010-03-22 | 2010-04-02 | 10d? | 70.78d | 0d |  | Johansson [40%]; Morrison [50%]; Johnson [10%] | 80h | 40h | 6,000 | 5,400 | 3,000 |
| 196 | 1.3.3.4.3.5 | Device control electronics architecture | 20d? | 2009-05-18 A | 2009-06-12 A |  | 100% |  | 2009-05-01 | 2009-05-28 | 20d? |  |  | start no earlier than 2009-05-18 | Wetherell [50%] | 80h | 80h | 6,000 | 6,000 | 6,000 |
| 197 | 1.3.3.4.3.6 | Motion control architecture update 1 | 33d? | 2009-05-15 A | 2009-06-30 A |  | 100% |  | 2009-05-01 | 2010-01-15 | 186d? |  |  | start no earlier than 2009-05-15 | Wetherell [11.4%] | 30h | 30h | 2,250 | 6,000 | 2,250 |
| 198 | 1.3.3.4.3.7 | Motion control architecture update 2 | 20d? | 2010-02-01 | 2010-02-26 |  |  |  |  |  |  | 60d |  | finish no earlier than 2010-02-26 | Wetherell [31.2%] | 50h |  | 3,750 |  |  |
| 199 | 1.3.3.4.3.8 | Document controls architecture | 16d? | 2009-09-14 A | 2009-10-05 | 196, 195 | 50% | 8d? | 2009-05-29 | 2009-06-19 | 15.62d? | 164d |  |  | Johansson [15.6%]; Wetherell [15.6%]; Johnson [15.6%]; Morrison [15.6%] | 80h | 40h | 6,000 | 5,250 | 3,000 |
| 200 | 1.3.3.4.4 | **Operations Sequences Architecture** | 65d? | 2009-07-13 | 2009-10-09 |  |  |  | 2009-05-01 | 2009-11-24 | 148d? | 160d |  |  |  | 120h |  | 9,000 | 9,000 |  |
| 201 | 1.3.3.4.4.1 | Define Required System Level Sequences | 25d? | 2009-07-13 | 2009-08-14 |  |  |  | 2009-05-01 | 2009-05-14 | 10d? | 200d |  | finish no earlier than 2009-08-14 | Bouchez [20%] | 40h |  | 3,000 | 3,000 |  |
| 202 | 1.3.3.4.4.2 | Sequences Definition Document | 40d? | 2009-08-17 | 2009-10-09 |  |  |  | 2009-08-17 | 2009-10-09 | 40d? | 160d |  | start no earlier than 2009-08-17 | Lyke [12.5%]; Bouchez [12.5%] | 80h |  | 6,000 | 6,000 |  |
| 203 | 1.3.3.5 | **External Interface Control** | 131d? | 2009-05-01 A | 2009-10-30 |  | 34% | 86.87d? | 2009-04-20 | 2009-10-21 | 132.67d? | 145d |  |  |  | 336h | 108.8h | 25,200 | 19,200 | 8,160.01 |
| 204 | 1.3.3.5.1 | **Observatory Interfaces** | 131d? | 2009-05-01 A | 2009-10-30 |  | 34% | 86.87d? | 2009-04-20 | 2009-10-21 | 132.67d? | 145d |  |  |  | 336h | 108.8h | 25,200 | 19,200 | 8,160.01 |
| 205 | 1.3.3.5.1.1 | AO to Telescope Optoelectromech ICD | 41d? | 2009-05-01 A | 2009-06-26 |  | 58% | 17.38d? | 2009-04-20 | 2009-05-26 | 26.67d? | 235d |  | finish no earlier than 2009-06-26 | Neyman [15%]; Gavel [4.9%]; Kupke [4.9%]; Lockwood [4.9%] | 80h | 56h | 6,000 | 6,000 | 4,200.01 |
| 206 | 1.3.3.5.1.2 | AO to Keck Interferometer ICD | 55d? | 2009-05-25 A | 2009-08-07 |  | 70% | 16.5d? | 2009-05-25 | 2009-07-17 | 40d? | 205d |  | finish no earlier than 2009-08-07 | Neyman [5.5%] | 24h | 16.8h | 1,800 | 1,800 | 1,260 |
| 207 | 1.3.3.5.1.3 | AO to Telescope Acq, Guiding, & Pointing ICD | 13.33d? | 2009-08-10 | 2009-08-27 |  |  |  | 2009-08-10 | 2009-08-27 | 13.33d? | 191.67d |  | start no earlier than 2009-08-10 | Johansson [15%]; Neyman [15%] | 32h |  | 2,400 | 2,400 |  |
| 208 | 1.3.3.5.1.4 | LGSF to Telescope Optoelectromech ICD | 88d? | 2009-07-01 | 2009-10-30 |  |  |  | 2009-07-01 | 2009-09-14 | 53.33d? | 145d |  | finish no earlier than 2009-10-30 | Chin [18.2%] | 128h |  | 9,600 | 4,800 |  |
| 209 | 1.3.3.5.1.5 | LGSF to Telescope Software ICD | 26.67d? | 2009-09-15 A | 2009-10-21 |  | 50% | 13.33d? | 2009-09-15 | 2009-10-21 | 26.67d? | 152.33d |  | start no earlier than 2009-09-15 | Chin [15%]; Morrison [18.8%] | 72h | 36h | 5,400 | 4,200 | 2,700 |
| 210 | 1.3.3.6 | **Internal Interface Control** | 148.67d? | 2009-06-15 A | 2010-01-07 |  | 19% | 120.75d? | 2009-06-15 | 2010-01-07 | 148.67d? | 96.33d |  |  |  | 296h | 48h | 22,200 | 24,000 | 3,600 |
| 211 | 1.3.3.6.1 | AO to NIR IFS ICD | 40d? | 2009-06-15 A | 2009-08-07 |  | 50% | 20d? | 2009-06-15 | 2009-08-07 | 40d? | 205d |  | start no earlier than 2009-06-15 | Kupke [5%]; Lockwood [2.5%]; Neyman [5%] | 40h | 20h | 3,000 | 4,800 | 1,500 |
| 212 | 1.3.3.6.2 | AO to LGSF ICD | 26.67d? | 2009-07-20 A | 2009-08-25 |  | 44% | 15d? | 2009-07-20 | 2009-08-25 | 26.67d? | 193.33d |  | start no earlier than 2009-07-20 | Chin [15%]; Neyman [15%] | 56h | 28h | 4,200 | 4,200 | 2,100 |
| 213 | 1.3.3.6.3 | Multicommand Sequencer ICD | 26.67d? | 2009-08-25 | 2009-09-30 |  |  |  | 2009-08-25 | 2009-09-30 | 26.67d? | 167.33d |  | start no earlier than 2009-08-25 | Morrison [15%]; Neyman [15%] | 56h |  | 4,200 | 4,200 |  |
| 214 | 1.3.3.6.4 | Data Server Telemetry ICD | 26.67d? | 2009-10-05 | 2009-11-10 |  |  |  | 2009-10-05 | 2009-11-10 | 26.67d? | 138.33d |  | start no earlier than 2009-10-05 | Johnson [15%]; Reinig [15%] | 56h |  | 4,200 | 4,200 |  |
| 215 | 1.3.3.6.5 | Data Server Diagnostics ICD | 26.67d? | 2009-12-02 | 2010-01-07 |  |  |  | 2009-12-02 | 2010-01-07 | 26.67d? | 96.33d |  | start no earlier than 2009-12-02 | Johnson [15%]; Neyman [15%] | 56h |  | 4,200 | 4,200 |  |
| 216 | 1.3.3.6.6 | Instrument to AO Science Tools ICD | 22d? | 2009-08-03 | 2009-09-01 |  |  |  | 2009-08-03 | 2009-09-01 | 21.33d? | 188d |  | start no earlier than 2009-08-03 | Morrison [9.4%]; Johansson [9.1%] | 32h |  | 2,400 | 2,400 |  |

Notes:
- 191: EJ
- 200: AB
- 203: CN
- 204: CN
- 205: CN
- 206: CN
- 207: CN
- 208: JC
- 209: JC
- 210: CN
- 211: SA
- 212: JC
- 213: EJ
- 214: JJ
- 215: JJ
- 216: TBD

| ID | WBS | Task | Duration | Start | Finish | Predecessors | Complete | Remaining | Baseline start | Baseline finish | Baseline duration | Total slack | Free slack | Constraint | Resources | Work | Actual work | Cost | Baseline cost | Actual cost |
| --- | --- | --- | --- | --- | --- | --- | --- | --- | --- | --- | --- | --- | --- | --- | --- | --- | --- | --- | --- | --- |
| 217 | 1.3.3.7 | **Configuration Control** | 41d? | 2009-10-05 A | 2009-11-30 |  | 40% | 24.6d? | 2009-09-14 | 2010-02-23 | 116.79d? | 124d |  |  |  | 80h | 32h | 6,000 | 16,351.25 | 2,400 |
| 218 | 1.3.3.7.1 | Change Control Guidelines & Tools Definition | 41d? | 2009-10-05 A | 2009-11-30 |  | 40% | 24.6d? | 2009-09-14 | 2010-02-23 | 116.79d? | 124d |  | finish no earlier than 2009-11-30 | Wetherell [6.1%]; Johansson [12.2%]; Bell [6.1%] | 80h | 32h | 6,000 | 16,351.25 | 2,400 |
| 219 | 1.3.3.8 | **Documentation Control** | 149.6d? | 2009-05-01 | 2009-11-26 |  |  |  | 2009-05-01 | 2010-03-03 | 218.17d? | 126.4d |  |  |  | 32h |  | 2,400 | 4,200 |  |
| 220 | 1.3.3.8.1 | Document Control Guidelines & Tools Definition | 149.6d? | 2009-05-01 | 2009-11-26 |  |  |  | 2009-05-01 | 2010-03-03 | 218.17d? | 126.4d |  | start no earlier than 2009-05-01 | Johansson [2.7%] | 32h |  | 2,400 | 4,200 |  |
| 221 | 1.3.3.9 | **Technical Risk Assessment & Mitigation** | 66d? | 2009-07-01 A | 2009-09-30 |  | 73% | 18.13d? | 2009-07-27 | 2009-12-18 | 105d? | 167d |  |  |  | 64h | 14h | 4,800 | 11,250 | 1,050 |
| 222 | 1.3.3.9.1 | **Risk Assessment** | 25d? | 2009-07-27 | 2009-08-28 |  |  |  | 2009-07-27 | 2009-08-28 | 25d? | 190d |  |  |  | 50h |  | 3,750 | 3,750 |  |
| 223 | 1.3.3.9.1.1 | Risk Assessment | 25d? | 2009-07-27 | 2009-08-28 |  |  |  | 2009-07-27 | 2009-08-28 | 25d? | 190d |  | finish no earlier than 2009-08-28 | Wizinowich [15%]; Gavel [15%] | 50h |  | 3,750 | 3,750 |  |
| 224 | 1.3.3.9.2 | **Risk Mitigation Efforts** | 66d? | 2009-07-01 A | 2009-09-30 A |  | 100% |  | 2009-08-03 | 2009-12-18 | 100d? |  |  |  |  | 14h | 14h | 1,050 | 7,500 | 1,050 |
| 225 | 1.3.3.9.2.1 | **PSF Calibration** | 66d? | 2009-07-01 A | 2009-09-30 A |  | 100% |  | 2009-08-03 | 2009-12-18 | 100d? |  |  |  |  | 14h | 14h | 1,050 | 7,500 | 1,050 |
| 226 | 1.3.3.9.2.1.1 | Support/Monitor Profiler Implementation | 66d? | 2009-07-01 A | 2009-09-30 A |  | 100% |  | 2009-08-03 | 2009-12-18 | 100d? |  |  | start no earlier than 2009-07-01 | Neyman [1.9%]; Wizinowich [0.8%] | 14h | 14h | 1,050 | 7,500 | 1,050 |
| 227 | 1.3.3.10 | Preliminary Design Manual | 20d? | 2010-03-05 A | 2010-04-01 |  | 4% | 19.14d? | 2010-03-15 | 2010-04-09 | 20d? | 35d | 0d | finish no earlier than 2010-04-01 | Wizinowich [125%]; Dekany [25%]; Gavel [25%]; Reinig [25%]; Velur [25%]; Neyman [25%]; Bouchez [25%]; Johansson [25%]; Kupke [25%]; Lockwood [25%] | 172h | 8.6h | 12,900 | 12,900 | 645 |
| 228 | 1.3.4 | **AO System Design** | 221.24d? | 2009-05-01 A | 2010-03-08 |  | 56% | 96.79d? | 2008-04-01 | 2010-03-05 | 504d? | 54.76d |  |  |  | 6040h | 3173.05h | 453,000.06 | 673,438.75 | 237,978.8 |
| 229 | 1.3.4.1 | AO Enclosure | 130d? | 2009-06-01 A | 2009-11-27 |  | 50% | 65d? | 2008-10-01 | 2009-03-31 | 130d? | 125d |  | start no earlier than 2009-06-01 | Bell [26%]; Mogensen [2.9%] | 300h | 150h | 22,500 | 22,500 | 11,250 |
| 230 | 1.3.4.2 | **Opto-Mechanical** | 221.24d? | 2009-05-01 A | 2010-03-08 |  | 59% | 89.84d? | 2008-04-01 | 2009-11-02 | 415d? | 54.76d |  |  |  | 2679h | 1453.5h | 200,925.02 | 333,075 | 109,012.49 |
| 231 | 1.3.4.2.1 | AO Support Structure | 45d? | 2009-06-01 A | 2009-07-31 A |  | 100% |  | 2008-11-03 | 2009-01-09 | 50d? |  |  | finish no earlier than 2009-07-31 | Lockwood [19.2%]; Gavel [2.8%] | 79h | 79h | 5,925 | 12,000 | 5,925 |
| 232 | 1.3.4.2.2 | Rotator | 43d? | 2009-08-03 A | 2009-09-30 |  | 90% | 4.47d? | 2009-03-12 | 2009-03-30 | 13d? | 0d |  | finish no earlier than 2009-09-30 | Lockwood [26.2%]; Kupke [17.3%]; Gavel [2.9%] | 104h | 93.6h | 7,800 | 9,000 | 7,019.99 |
| 233 | 1.3.4.2.3 | Optical Relays | 66d? | 2009-05-01 A | 2009-07-31 A |  | 100% |  | 2008-12-29 | 2009-04-17 | 80d? |  |  | finish no earlier than 2009-07-31 | Lockwood [13.3%]; Kupke [13.3%]; Gavel [3.2%] | 157h | 157h | 11,775 | 39,975 | 11,775 |
| 234 | 1.3.4.2.4 | Optical Switchyard | 15d? | 2009-06-01 A | 2009-06-19 A |  | 100% |  | 2008-08-04 | 2008-11-07 | 70d? |  |  | finish no earlier than 2009-06-19 | Lockwood [30%]; Kupke [33.3%]; Gavel [6.7%] | 84h | 84h | 6,300 | 30,000 | 6,300 |
| 235 | 1.3.4.2.5 | **LGS Wavefront Sensor Assembly** | 101.67d? | 2009-05-20 A | 2009-10-08 |  | 69% | 31.58d? | 2009-03-16 | 2009-08-28 | 120d | 48.75d | 0d |  |  | 830h | 582h | 62,250.02 | 87,900 | 43,650.01 |
| 236 | 1.3.4.2.5.1 | Review and conceptualize design for the LGS wavefront sensor unit | 10d | 2009-05-20 A | 2009-06-02 A |  | 100% |  | 2009-04-13 | 2009-05-22 | 30d |  |  | start no earlier than 2009-05-20 | Delacroix [50%]; Velur [50%] | 80h | 80h | 6,000 | 18,000 | 6,000 |
| 237 | 1.3.4.2.5.2 | Identify the issues with uplink TTM, asterism generation and OSM concepts to ensure it conforms to the dithering requirements | 15d | 2009-06-03 A | 2009-06-23 A | 236 | 100% |  | 2009-05-25 | 2009-06-12 | 15d |  |  |  | Velur [20%] | 24h | 24h | 1,800 | 6,000 | 1,800 |
| 238 | 1.3.4.2.5.3 | Develop optical design for the LGS Shack-Hartmann sensor | 10d? | 2009-06-24 A | 2009-07-07 A | 237 | 100% |  |  |  |  |  |  |  | Velur [50%] | 40h | 40h | 3,000 |  | 3,000 |
| 239 | 1.3.4.2.5.4 | Develop optical design for LGS WFS OSM arms | 20d? | 2009-07-08 A | 2009-08-04 A | 238 | 100% |  |  |  |  |  |  |  | Velur [25%] | 40h | 40h | 3,000 |  | 3,000 |
| 240 | 1.3.4.2.5.5 | Interface LGS WFS design to overall NGAO Optical design | 75d? | 2009-05-20 A | 2009-09-01 | 236SS | 85% | 11.25d? |  |  |  | 75.42d |  |  | Velur [5%]; Delacroix [5%] | 60h | 51h | 4,500 |  | 3,825 |

Notes:
- 217: EJ
- 218: EJ
- 219: EJ
- 220: EJ
- 221: PW
- 222: PW
- 223: PW
- 224: PW
- 226: PW
- 227: PW
- 228: DG
- 229: JB
- 230: DG
- 231: CL
- 232: CL
- 233: RK
- 234: RK
- 235: VV

| ID | WBS | Task | Duration | Start | Finish | Predecessors | Complete | Remaining | Baseline start | Baseline finish | Baseline duration | Total slack | Free slack | Constraint | Resources | Work | Actual work | Cost | Baseline cost | Actual cost |
| --- | --- | --- | --- | --- | --- | --- | --- | --- | --- | --- | --- | --- | --- | --- | --- | --- | --- | --- | --- | --- |
| 241 | 1.3.4.2.5.6 | **Mechanical Detail of the LGS WFS Ass'ly** | 91.67d | 2009-06-03 A | 2009-10-08 |  | 81% | 17.38d | 2009-06-22 | 2009-08-28 | 50d | 48.75d |  |  |  | 240h | 193h | 18,000.02 | 15,000 | 14,475.01 |
| 242 | 1.3.4.2.5.6.1 | Design PnS LGS WFS sensor assl'y (including OSM) | 41.67d | 2009-06-03 A | 2009-07-30 | 236 | 90% | 4.17d | 2009-06-22 | 2009-07-08 | 12.5d | 85.54d | 0d |  | Delacroix [30%] | 100h | 90h | 7,500 | 3,750 | 6,750 |
| 243 | 1.3.4.2.5.6.2 | Design the science LGS WFS sensor (including tetrahedron pickoff) | 21.43d | 2009-07-30 A | 2009-08-31 | 242 | 85% | 3.21d | 2009-07-22 | 2009-07-29 | 5d | 67.32d | 0d |  | Delacroix [35%] | 60h | 51h | 4,500.02 | 1,500 | 3,825 |
| 244 | 1.3.4.2.5.6.3 | Overall LGS WFS structure mechanical design | 28.57d | 2009-08-31 A | 2009-10-08 | 243 | 65% | 10d | 2009-07-29 | 2009-08-07 | 7.5d | 48.75d |  | finish no earlier than 2009-07-30 | Delacroix [35%] | 80h | 52h | 6,000 | 2,250 | 3,900.01 |
| 245 | 1.3.4.2.5.7 | Identify stray light issues (incl. Rayleigh scatter) | 50d | 2009-06-24 A | 2009-09-01 | 237 | 20% | 40d | 2009-06-15 | 2009-06-26 | 10d | 69.42d | 0d |  | Velur [15%] | 60h | 12h | 4,500 | 4,500 | 900 |
| 246 | 1.3.4.2.5.8 | Simulate/ conceptualize and design solutions to stray light | 7.5d | 2009-09-02 A | 2009-09-11 | 245 | 20% | 6d |  |  |  | 67.92d |  | finish no earlier than 2009-07-09 | Velur [50%] | 30h | 6h | 2,250 |  | 450 |
| 247 | 1.3.4.2.5.9 | Identify LGS WFS motion control needs and specify solutions. | 18.75d | 2009-06-24 A | 2009-07-20 A | 237 | 100% |  | 2009-06-15 | 2009-06-26 | 10d |  |  |  | Wetherell [40%]; Delacroix [20%]; Velur [20%] | 60h | 60h | 4,500 | 9,000 | 4,500 |
| 248 | 1.3.4.2.5.10 | Identify LGS WFS design risks and mitigation | 15d | 2009-07-20 A | 2009-08-10 A | 247 | 100% |  | 2009-06-29 | 2009-07-16 | 13.25d |  |  |  | Delacroix [20%]; Velur [20%] | 36h | 36h | 2,700 | 6,000 | 2,700 |
| 249 | 1.3.4.2.5.11 | Develop preliminary LGS WFS ass'ly integration plan | 30d | 2009-08-10 | 2009-09-21 | 248 |  |  | 2009-07-16 | 2009-08-03 | 12.5d | 56.67d | 0d |  | Delacroix [15%]; Velur [25%] | 80h |  | 6,000 | 6,000 |  |
| 250 | 1.3.4.2.5.12 | Write LGS WFS Ass'ly Documentation as a KAON | 10d | 2009-09-21 A | 2009-10-05 | 249 | 50% | 5d | 2009-08-03 | 2009-08-28 | 19d | 51.67d |  |  | Delacroix [50%]; Velur [50%] | 80h | 40h | 6,000 | 11,400 | 3,000 |
| 251 | 1.3.4.2.6 | **NGS Wavefront Sensor Assembly** | 86.57d? | 2009-11-05 A | 2010-03-08 |  | 28% | 62.54d? | 2008-04-01 | 2009-11-02 | 415d | 54.76d |  |  |  | 344h | 30h | 25,800 | 36,600 | 2,250 |
| 252 | 1.3.4.2.6.1 | Review concept design for NGS WFS assembly | 53.57d | 2009-11-05 A | 2010-01-20 A | 235FS-12w, 261FS-12w | 100% |  | 2009-08-28 | 2009-09-25 | 21d |  |  |  | Delacroix [7%] | 30h | 30h | 2,250 | 3,000 | 2,250 |
| 253 | 1.3.4.2.6.2 | Develop optical design for the NGS WFS | 10.71d? | 2010-01-28 | 2010-02-12 | 235, 261 |  |  |  |  |  | 70.62d |  |  | Velur [35%] | 30h |  | 2,250 |  |  |
| 254 | 1.3.4.2.6.3 | Interface NGS WFS design to overall NGAO optical design | 66.67d? | 2009-11-05 | 2010-02-08 | 235FS-12w, 261FS-12w |  |  |  |  |  | 74.67d |  |  | Delacroix [3%]; Velur [3%] | 32h |  | 2,400 |  |  |
| 255 | 1.3.4.2.6.4 | Develop mechanical detail for the NGS WFS ass'ly | 25d | 2010-01-20 | 2010-02-24 | 252 |  |  | 2009-01-19 | 2009-03-13 | 40d | 62.76d | 0d | finish no earlier than 2009-10-30 | Delacroix [40%]; Velur [10%] | 100h |  | 7,500 | 12,000 |  |
| 256 | 1.3.4.2.6.5 | Check compliance of design with the design of the field steering mirror assembly | 4d | 2010-02-18 | 2010-02-24 | 255FF |  |  | 2009-03-16 | 2009-03-27 | 10d | 62.76d |  |  | Velur [44.6%]; Delacroix [25%] | 12h |  | 900 | 3,000 |  |
| 257 | 1.3.4.2.6.6 | Identify NGS WFS motion control needs and specify solutions | 5d | 2010-01-20 | 2010-01-27 | 255SS |  |  | 2008-04-01 | 2008-04-08 | 6d | 54.76d | 0d | start no earlier than 2009-06-15 | Delacroix [40%]; Velur [10%] | 20h |  | 1,500 | 3,600 |  |
| 258 | 1.3.4.2.6.7 | Identify NGS WFS design risks and mitigation | 10d | 2010-01-27 | 2010-02-10 | 257 |  |  | 2009-05-22 | 2009-05-29 | 4.67d | 54.76d | 0d |  | Velur [35%]; Delacroix [10%] | 28h |  | 2,100 | 2,100 |  |
| 259 | 1.3.4.2.6.8 | Check compliance with alignment plan for the NGS OSM (written as part of opto-mechanical relay sub-system design effort). | 8d | 2010-02-10 | 2010-02-22 | 258 |  |  | 2009-05-29 | 2009-06-10 | 8d | 54.76d | 0d |  | Delacroix [25%]; Velur [41.4%] | 32h |  | 2,400 | 2,400 |  |
| 260 | 1.3.4.2.6.9 | Write NGS WFS Ass'ly Documentation as a KAON | 10d | 2010-02-22 | 2010-03-08 | 259 |  |  | 2009-10-20 | 2009-11-02 | 10d | 54.76d |  | finish no earlier than 2009-11-02 | Velur [50%]; Delacroix [50%] | 60h |  | 4,500 | 3,000 |  |
| 261 | 1.3.4.2.7 | **Low Order Wavefront Sensor Assembly** | 181.67d? | 2009-05-20 A | 2010-01-28 |  | 46% | 97.42d? | 2008-04-01 | 2009-11-02 | 415d | 70.62d | 0d |  |  | 810h | 321.4h | 60,750 | 84,000 | 24,105.02 |
| 262 | 1.3.4.2.7.1 | Review concept design for LOWFS assembly | 50d | 2009-05-20 A | 2009-07-28 A | 235SS | 100% |  | 2008-08-11 | 2008-09-05 | 20d |  |  |  | Delacroix [10%]; Velur [5%] | 60h | 60h | 4,500 | 4,500 | 4,500 |
| 263 | 1.3.4.2.7.2 | Developing optimal dithering strategy | 40d | 2009-07-15 A | 2009-09-08 | 262SS+8w | 25% | 30d | 2008-09-08 | 2008-09-19 | 10d | 70.42d | 21.67d |  | Velur [10%]; Bouchez [5%]; Johansson [2.5%] | 56h | 14h | 4,200 | 3,000 | 1,050 |
| 264 | 1.3.4.2.7.3 | Develop optical design of the TT and TTFA/TWFS sensors | 15d? | 2009-10-08 A | 2009-10-29 | 263, 235 | 65% | 5.25d? |  |  |  | 39d | 0d |  | Velur [50%] | 60h | 39h | 4,500 |  | 2,925 |
| 265 | 1.3.4.2.7.4 | Develop thermal model and work emissivity details of the LOWFS assembly and feed into the overall emissivity budget | 10d | 2009-10-29 | 2009-11-12 | 264 |  |  | 2009-02-10 | 2009-02-24 | 10d | 56.9d | 0d |  | Bouchez [50%] | 40h |  | 3,000 | 3,000 |  |

Notes:
- 251: VV
- 261: VV

| ID | WBS | Task | Duration | Start | Finish | Predecessors | Complete | Remaining | Baseline start | Baseline finish | Baseline duration | Total slack | Free slack | Constraint | Resources | Work | Actual work | Cost | Baseline cost | Actual cost |
| --- | --- | --- | --- | --- | --- | --- | --- | --- | --- | --- | --- | --- | --- | --- | --- | --- | --- | --- | --- | --- |
| 266 | 1.3.4.2.7.5 | **Mechanical detail of the LOWFS ass'ly** | 82.92d? | 2009-10-05 A | 2010-01-28 |  | 73% | 22.39d? |  |  |  | 70.62d |  |  |  | 250h | 194h | 18,750 |  | 14,550 |
| 267 | 1.3.4.2.7.5.1 | Develop TT and TTFA/TWFS OSM | 25d? | 2009-10-05 A | 2009-11-09 A | 250 | 100% |  |  |  |  |  |  |  | Delacroix [25%] | 50h | 50h | 3,750 |  | 3,750 |
| 268 | 1.3.4.2.7.5.2 | Design the TT and the TTFA/TWFS sensor mechanics | 45d | 2009-10-29 A | 2009-12-31 | 264 | 87% | 6d | 2008-09-22 | 2008-11-26 | 48d | 0d |  |  | Velur [20%]; Delacroix [25%] | 120h | 108h | 9,000 | 16,800 | 8,100 |
| 269 | 1.3.4.2.7.5.3 | Design the LOWFS cryostat | 30d | 2009-12-17 A | 2010-01-28 | 268FS-2w | 30% | 21d | 2009-01-13 | 2009-02-10 | 20d | 70.62d |  |  | Delacroix [25%]; Velur [25%] | 80h | 36h | 6,000 | 12,000 | 2,700 |
| 270 | 1.3.4.2.7.6 | Develop future PSF monitor sensor option | 35.71d | 2009-10-08 | 2009-11-27 | 264SS |  |  | 2009-01-08 | 2009-01-13 | 3.33d | 97.86d |  |  | Velur [7%] | 20h |  | 1,500 | 1,500 |  |
| 271 | 1.3.4.2.7.7 | Identify LOWFS WFS motion control needs and specify solutions | 20d | 2009-10-05 A | 2009-11-02 | 267SS | 60% | 8d | 2008-04-01 | 2008-04-22 | 16d | 133.54d |  | start no earlier than 2009-06-15 | Velur [10%] | 16h | 9.6h | 1,200 | 7,200 | 720 |
| 272 | 1.3.4.2.7.8 | Identify LOWFS design risks and mitigation | 20d | 2009-11-12 A | 2009-12-10 | 265 | 9% | 18.29d | 2009-02-24 | 2009-03-10 | 10d | 56.9d | 0d |  | Delacroix [10%]; Velur [25%] | 48h | 4.8h | 3,600 | 6,000 | 360.02 |
| 273 | 1.3.4.2.7.9 | Develop preliminary LOWFS ass'ly integration plan | 10d | 2009-12-10 | 2009-12-24 | 272 |  |  | 2009-03-10 | 2009-03-27 | 13.33d | 56.9d | 0d |  | Velur [75%]; Delacroix [25%] | 80h |  | 6,000 | 6,000 |  |
| 274 | 1.3.4.2.7.10 | Develop an initial performance verification test plan | 20d | 2009-12-03 | 2009-12-31 | 273FS-3w |  |  | 2009-03-27 | 2009-04-10 | 10d | 56.9d | 0d |  | Hale [25%]; Velur [25%] | 60h |  | 4,500 | 9,000 |  |
| 275 | 1.3.4.2.7.11 | Write LOWFS Ass'ly Documentation as a KAON | 16.67d | 2009-12-31 | 2010-01-25 | 274 |  |  | 2009-10-23 | 2009-11-02 | 6.67d | 56.9d |  | finish no earlier than 2009-11-02 | Hale [30%]; Velur [30%]; Delacroix [30%] | 120h |  | 9,000 | 6,000 |  |
| 276 | 1.3.4.2.8 | **Tip/Tilt Vibration Mitigation** | 31d? | 2009-05-01 A | 2009-06-12 |  | 95% | 1.55d? | 2008-07-07 | 2008-08-29 | 40d? | 245d |  |  |  | 30h | 28.5h | 2,250 | 6,000 | 2,137.5 |
| 277 | 1.3.4.2.8.1 | TT Vibration Mitigation Analysis | 31d? | 2009-05-01 A | 2009-06-12 |  | 95% | 1.55d? | 2008-07-07 | 2008-08-29 | 40d? | 245d |  | finish no earlier than 2009-06-12 | Neyman [12.1%] | 30h | 28.5h | 2,250 | 6,000 | 2,137.5 |
| 278 | 1.3.4.2.9 | **Acquisition Cameras** | 65d? | 2009-08-03 A | 2009-10-30 |  | 50% | 32.5d? | 2008-09-01 | 2009-10-30 | 305d? | 145d |  |  |  | 128h | 40h | 9,600 | 9,600 | 3,000 |
| 279 | 1.3.4.2.9.1 | Acquisition Camera Implementation Issues | 20d? | 2009-08-03 A | 2009-08-28 A |  | 100% |  | 2008-09-01 | 2008-09-26 | 20d? |  |  | start no earlier than 2009-08-03 | Neyman [12.5%]; Kwok [12.5%] | 40h | 40h | 3,000 | 3,000 | 3,000 |
| 280 | 1.3.4.2.9.2 | Acquisition Camera Opto-Mechanical Design | 20d? | 2009-10-01 | 2009-10-30 |  |  |  | 2009-10-01 | 2009-10-30 | 20d? | 145d |  | start no earlier than 2009-10-01 | Neyman [7.5%]; Panteleev [12.5%]; Lockwood [10%]; Stalcup [25%] | 88h |  | 6,600 | 6,600 |  |
| 281 | 1.3.4.2.10 | **Atmospheric Dispersion Correctors** | 43d? | 2009-07-01 A | 2009-08-28 |  | 59% | 17.64d? | 2008-10-17 | 2009-02-27 | 96d? | 190d |  |  |  | 113h | 38h | 8,475 | 18,000 | 2,849.98 |
| 282 | 1.3.4.2.10.1 | LOWFS ADCs Mechanical Location | 20d? | 2009-08-03 A | 2009-08-28 A |  | 100% |  | 2008-10-17 | 2008-10-30 | 10d? |  |  | finish no earlier than 2009-08-28 | Kupke [5%]; Lockwood [3.1%] | 13h | 13h | 975 | 10,500 | 975 |
| 283 | 1.3.4.2.10.2 | Science ADC | 22d? | 2009-07-01 A | 2009-07-30 |  | 22% | 17.23d? | 2008-12-24 | 2008-12-30 | 5d? | 211d |  | finish no earlier than 2009-07-30 | Kupke; Lockwood [25%] | 100h | 25h | 7,500 | 3,750 | 1,874.98 |
| 284 | 1.3.4.3 | **Alignment, Calibration & Diagnostics** | 100d? | 2009-08-03 A | 2009-12-18 |  | 9% | 91.3d? | 2009-02-02 | 2009-06-05 | 90d? | 110d |  |  |  | 495h | 47h | 37,125 | 37,875 | 3,525 |
| 285 | 1.3.4.3.1 | **Simulator** | 50d? | 2009-08-03 A | 2009-10-09 |  | 15% | 42.31d? | 2009-02-02 | 2009-04-03 | 45d? | 160d |  |  |  | 246h | 47h | 18,450 | 18,750 | 3,525 |
| 286 | 1.3.4.3.1.1 | Simulator Requirements & Interfaces | 10d? | 2009-08-03 A | 2009-08-14 |  | 75% | 2.5d? | 2009-02-02 | 2009-02-13 | 10d? | 200d |  | start no earlier than 2009-08-03 | Neyman [25%]; Wizinowich [5%]; Stalcup [27.5%] | 46h | 34.5h | 3,450 | 3,750 | 2,587.5 |
| 287 | 1.3.4.3.1.2 | Simulator Optical Design | 10d? | 2009-08-17 A | 2009-08-28 |  | 25% | 7.5d? | 2009-02-16 | 2009-02-27 | 10d? | 190d |  | start no earlier than 2009-08-17 | Neyman [12.5%]; Stalcup [50%] | 50h | 12.5h | 3,750 | 3,750 | 937.5 |
| 288 | 1.3.4.3.1.3 | Simulator Mechanical Design | 10d? | 2009-08-31 | 2009-09-11 |  |  |  | 2009-03-02 | 2009-03-13 | 10d? | 180d |  | start no earlier than 2009-08-31 | Stalcup [12.5%]; Bell [62.5%] | 60h |  | 4,500 | 4,500 |  |
| 289 | 1.3.4.3.1.4 | Simulator Electrical Design | 25d? | 2009-08-17 | 2009-09-18 |  |  |  | 2009-03-09 | 2009-03-20 | 10d? | 175d |  | finish no earlier than 2009-09-18 | Stalcup [10%]; Wetherell [15%] | 50h |  | 3,750 | 3,750 |  |
| 290 | 1.3.4.3.1.5 | Simulator Assembly, Alignment & Test Plans | 10d? | 2009-09-28 | 2009-10-09 |  |  |  | 2009-03-23 | 2009-04-03 | 10d? | 160d |  | start no earlier than 2009-09-28 | Stalcup [50%] | 40h |  | 3,000 | 3,000 |  |

Notes:
- 276: CN
- 278: CN
- 281: RK
- 284: TS
- 285: TS
- 286: CN
- 287: TS
- 288: TS
- 289: TS
- 290: TS

| ID | WBS | Task | Duration | Start | Finish | Complete | Remaining | Baseline start | Baseline finish | Baseline duration | Total slack | Constraint | Resources | Work | Actual work | Cost | Baseline cost | Actual cost |
| --- | --- | --- | --- | --- | --- | --- | --- | --- | --- | --- | --- | --- | --- | --- | --- | --- | --- | --- |
| 291 | 1.3.4.3.2 | **System Alignment Tools** | 50d? | 2009-10-12 | 2009-12-18 |  |  | 2009-04-06 | 2009-06-05 | 45d? | 110d |  |  | 249h |  | 18,675 | 19,125 |  |
| 292 | 1.3.4.3.2.1 | Alignment Requirements & Interfaces | 10d? | 2009-10-12 | 2009-10-23 |  |  | 2009-04-06 | 2009-04-17 | 10d? | 150d | start no earlier than 2009-10-12 | Neyman [25%]; Kupke [15%]; Wizinowich [2.5%]; Stalcup [25%] | 54h |  | 4,050 | 4,500 |  |
| 293 | 1.3.4.3.2.2 | Alignment Optical Design | 10d? | 2009-10-26 | 2009-11-06 |  |  | 2009-04-20 | 2009-05-01 | 10d? | 140d | start no earlier than 2009-10-26 | Stalcup [12.5%]; Kupke [50%] | 50h |  | 3,750 | 3,750 |  |
| 294 | 1.3.4.3.2.3 | Alignment Mechanical Design | 10d? | 2009-11-09 | 2009-11-20 |  |  | 2009-05-04 | 2009-05-15 | 10d? | 130d | start no earlier than 2009-11-09 | Stalcup [12.5%]; Lockwood [50%] | 50h |  | 3,750 | 3,750 |  |
| 295 | 1.3.4.3.2.4 | Alignment Electrical Design | 10d? | 2009-11-23 | 2009-12-04 |  |  | 2009-05-11 | 2009-05-22 | 10d? | 120d | start no earlier than 2009-11-23 | Stalcup [25%]; Wetherell [18.8%] | 35h |  | 2,625 | 2,625 |  |
| 296 | 1.3.4.3.2.5 | Alignment Assembly, Alignment & Test Plans | 10d? | 2009-12-07 | 2009-12-18 |  |  | 2009-05-25 | 2009-06-05 | 10d? | 110d | start no earlier than 2009-12-07 | Stalcup [50%]; Kupke [25%] | 60h |  | 4,500 | 4,500 |  |
| 297 | 1.3.4.4 | **Real-time Control** | 221d? | 2009-05-01 A | 2010-03-05 | 60% | 87.9d? | 2008-07-18 | 2010-03-05 | 426d? | 55d |  |  | 2372h | 1522.55h | 177,900.03 | 264,988.75 | 114,191.31 |
| 298 | 1.3.4.4.1 | **RTC Processor** | 221d? | 2009-05-01 A | 2010-03-05 | 62% | 83.83d? | 2008-07-18 | 2010-03-05 | 426d? | 55d |  |  | 2124h | 1299.05h | 159,300.03 | 240,988.75 | 97,428.8 |
| 299 | 1.3.4.4.1.1 | RTC Technical Management | 1743.42h? | 2009-05-01 A | 2010-03-02 | 75% | 438.62h? | 2008-07-18 | 2010-03-04 | 3400h? | 58.07d | start no earlier than 2009-05-01 | Reinig [9%]; Gavel [4.4%] | 233h | 174.75h | 17,475.04 | 34,725 | 13,106.27 |
| 300 | 1.3.4.4.1.2 | **Develop Internal Budgets** | 35.59d? | 2009-05-01 A | 2009-06-19 A | 100% |  | 2009-04-22 | 2009-05-12 | 15d? |  |  |  | 40h | 40h | 3,000 | 5,850 | 3,000 |
| 301 | 1.3.4.4.1.2.1 | Wavefront Error Budget | 28.59d? | 2009-05-01 A | 2009-06-19 A | 100% |  | 2009-04-22 | 2009-05-05 | 10d? |  | start no earlier than 2009-05-01 | Gavel [2.6%]; Reinig [6.3%] | 17h | 17h | 1,275 | 1,875 | 1,275 |
| 302 | 1.3.4.4.1.2.2 | Power Budget | 34d? | 2009-05-04 A | 2009-06-18 A | 100% |  | 2009-04-22 | 2009-04-30 | 6.25d? |  | start no earlier than 2009-05-03 | Gavel [0.7%]; Reinig [10%] | 12h | 12h | 900 | 1,013.2 | 900 |
| 303 | 1.3.4.4.1.2.3 | Volume Budget | 33d | 2009-05-04 A | 2009-06-17 A | 100% |  | 2009-04-22 | 2009-05-05 | 10d |  | start no earlier than 2009-05-03 | Gavel [0.4%]; Peck [10%] | 11h | 11h | 825 | 941.6 | 825 |
| 304 | 1.3.4.4.1.3 | **Algorithm Development Support** | 60d? | 2009-05-01 A | 2009-07-23 | 70% | 18d? | 2009-05-01 | 2009-07-23 | 60d? | 216d |  |  | 32h | 22.4h | 2,400 | 2,400 | 1,680 |
| 305 | 1.3.4.4.1.3.1 | MPP off-line simulator | 60d? | 2009-05-01 A | 2009-07-23 | 70% | 18d? | 2009-04-22 | 2009-07-17 | 62.5d? | 216d | start no earlier than 2009-05-01 | Gavel [4.6%] | 22h | 15.4h | 1,650 | 1,875 | 1,155 |
| 306 | 1.3.4.4.1.3.2 | Split tomography algorithm development | 14d? | 2009-05-01 A | 2009-05-20 | 70% | 4.2d? | 2009-04-22 | 2009-05-08 | 12.5d? | 262d | start no earlier than 2009-05-01 | Gavel [4.5%] | 5h | 3.5h | 375 | 375 | 262.5 |
| 307 | 1.3.4.4.1.3.3 | Woofer-tweeter algorithm development | 19d? | 2009-05-01 A | 2009-05-27 | 70% | 5.7d? | 2009-04-22 | 2009-05-08 | 12.5d? | 257d | finish no earlier than 2009-05-27 | Gavel [3.3%] | 5h | 3.5h | 375 | 375 | 262.5 |
| 308 | 1.3.4.4.1.4 | **RTC Hardware** | 175d? | 2009-05-01 A | 2009-12-31 | 15% | 149.04d? | 2009-04-22 | 2009-06-30 | 50d? | 101d |  | Peck [46.8%] | 804h | 201h | 60,300.03 | 57,410 | 15,075.06 |
| 309 | 1.3.4.4.1.4.1 | Number and Function of RTC Processor Boards | 87d? | 2009-05-01 A | 2009-08-31 | 5% | 82.7d? | 2009-04-22 | 2009-05-12 | 14.29d? | 189d | finish no earlier than 2009-08-31 | Reinig [35%]; Peck [50%] | 117h | 29.25h | 8,775.03 | 6,000 | 2,193.79 |
| 310 | 1.3.4.4.1.4.2 | Layout of Processors on Boards | 66d? | 2009-05-01 A | 2009-07-31 | 16% | 55.71d? | 2009-04-22 | 2009-05-28 | 26.71d? | 210d | start no earlier than 2009-05-01 | Reinig [20%]; Peck [13.7%] | 111h | 27.75h | 8,325 | 8,610 | 2,081.24 |
| 311 | 1.3.4.4.1.4.3 | Interconnect of processors on-board | 34d? | 2009-06-29 A | 2009-08-13 | 15% | 28.75d? | 2009-04-22 | 2009-05-14 | 16.67d? | 201d | finish no earlier than 2009-08-13 | Peck [30%] | 40h | 10h | 3,000 | 3,000 | 750 |
| 312 | 1.3.4.4.1.4.4 | Interconnection of boards to each other | 142d? | 2009-05-01 A | 2009-11-16 | 9% | 129.41d? | 2009-04-22 | 2009-06-30 | 50d? | 134d | start no earlier than 2009-05-01 | Peck [13.1%]; Reinig [40%] | 214h | 53.5h | 16,050 | 8,640 | 4,012.53 |
| 313 | 1.3.4.4.1.4.5 | Clock Distribution and Synchronization | 59d? | 2009-05-25 A | 2009-08-13 | 25% | 44.25d? | 2009-04-22 | 2009-04-24 | 2.5d? | 201d | start no earlier than 2009-05-25 | Reinig [4.2%]; Peck [30%] | 20h | 5h | 1,500 | 750 | 375 |
| 314 | 1.3.4.4.1.4.6 | Trade chip processing capacity with power dissipation capacity and manage generated heat | 15d? | 2009-06-08 A | 2009-06-26 | 8% | 13.86d? | 2009-04-22 | 2009-04-28 | 4.17d? | 235d | finish no earlier than 2009-06-26 | Reinig [8.3%]; Peck [30%] | 14h | 3.5h | 1,050 | 1,080 | 262.49 |
| 315 | 1.3.4.4.1.4.7 | Hardware Interfaces to HOWFS and LOWFS cameras | 124d? | 2009-07-13 A | 2009-12-31 | 25% | 93d? | 2009-04-22 | 2009-06-08 | 33.33d? | 101d | finish no earlier than 2009-12-31 | Peck [10.4%] | 103h | 25.75h | 7,725 | 6,000 | 1,931.25 |
| 316 | 1.3.4.4.1.4.8 | Hardware Interfaces to DM drivers | 135d? | 2009-05-01 A | 2009-11-05 | 4% | 130.07d? | 2009-04-22 | 2009-04-30 | 6.25d? | 141d | start no earlier than 2009-05-01 | Peck [3%]; Reinig [30%] | 52h | 13h | 3,900 | 1,830 | 975.01 |
| 317 | 1.3.4.4.1.4.9 | Hardware Interface to Telemetry Data Capture System | 137d? | 2009-06-08 A | 2009-12-15 | 25% | 102.75d? | 2009-04-22 | 2009-06-18 | 41.67d? | 113d | finish no earlier than 2009-12-15 | Peck [12.1%] | 133h | 33.25h | 9,975 | 7,500 | 2,493.75 |

Notes:
- 291: TS
- 292: CN
- 293: TS
- 294: TS
- 295: TS
- 296: TS
- 297: DG
- 298: DG
- 299: MR
- 300: Allocate budgets (wavefront error, space, power, etc.) across elements within the RTC.
- 304: DG
- 305: Program and maintain and IDL program that simulates the RTC's operations. Use to validate algorithm functionality and performance. Use to create dummy input data and comparision output data for testing.
- 308: Design of the hardware system that will implement the massively parallel proceesing (MPP) real-time code

| ID | WBS | Task | Duration | Start | Finish | Complete | Remaining | Baseline start | Baseline finish | Baseline duration | Total slack | Constraint | Resources | Work | Actual work | Cost | Baseline cost | Actual cost |
| --- | --- | --- | --- | --- | --- | --- | --- | --- | --- | --- | --- | --- | --- | --- | --- | --- | --- | --- |
| 318 | 1.3.4.4.1.5 | **RTC Software - Time-critical tasks on Processing Engine (PE)** | 109d? | 2009-05-01 A | 2009-09-30 A | 100% |  | 2009-04-22 | 2009-06-12 | 37.5d? |  |  | Peck [37.7%] | 237h | 237h | 17,775 | 33,562.5 | 17,775 |
| 319 | 1.3.4.4.1.5.1 | Wavefront reconstructor software | 43d? | 2009-05-01 A | 2009-06-30 A | 100% |  | 2009-04-22 | 2009-05-26 | 25d? |  | finish no earlier than 2009-06-30 | Reinig [13.4%] | 46h | 46h | 3,450 | 4,500 | 3,450 |
| 320 | 1.3.4.4.1.5.2 | Tomography Algorithm Software | 46d? | 2009-05-01 A | 2009-07-03 A | 100% |  | 2009-04-22 | 2009-06-08 | 33.33d? |  | finish no earlier than 2009-07-03 | Reinig [8.7%] | 32h | 32h | 2,400 | 6,000 | 2,400 |
| 321 | 1.3.4.4.1.5.3 | DM Control Software (inverse DM response function and open-loop control) | 17d? | 2009-07-27 A | 2009-08-18 A | 100% |  | 2009-04-22 | 2009-05-14 | 16.67d? |  | finish no earlier than 2009-08-18 | Reinig [29.4%] | 40h | 40h | 3,000 | 3,000 | 3,000 |
| 322 | 1.3.4.4.1.5.4 | Pseudo-Open Loop Control Software | 33d? | 2009-08-17 A | 2009-09-30 A | 100% |  | 2009-04-22 | 2009-05-04 | 8.33d? |  | finish no earlier than 2009-09-30 | Reinig [11.4%] | 30h | 30h | 2,250 | 1,500 | 2,250 |
| 323 | 1.3.4.4.1.5.5 | **Telemetry and Diagnostic Streams Software - RTC side** | 61.67d? | 2009-07-06 A | 2009-09-29 A | 100% |  | 2009-04-22 | 2009-06-12 | 37.5d? |  |  |  | 89h | 89h | 6,675 | 10,125 | 6,675 |
| 324 | 1.3.4.4.1.5.5.1 | Telemetry Data Streams Software | 10.42d? | 2009-07-06 A | 2009-07-20 A | 100% |  | 2009-04-22 | 2009-05-06 | 10.42d? |  | start no earlier than 2009-07-06 | Reinig [30%] | 25h | 25h | 1,875 | 1,875 | 1,875 |
| 325 | 1.3.4.4.1.5.5.2 | **Monitoring and Diagnostics Streams Software** | 51.67d? | 2009-07-20 A | 2009-09-29 A | 100% |  | 2009-04-22 | 2009-06-12 | 37.5d? |  |  |  | 64h | 64h | 4,800 | 8,250 | 4,800 |
| 326 | 1.3.4.4.1.5.5.2.1 | Periodic and On-Demand Status Updates Stream to supervisory control | 31d? | 2009-07-20 A | 2009-08-31 A | 100% |  | 2009-04-22 | 2009-06-12 | 37.5d? |  | finish no earlier than 2009-08-31 | Reinig [17.7%] | 44h | 44h | 3,300 | 6,750 | 3,300 |
| 327 | 1.3.4.4.1.5.5.2.2 | Self-monitoring and Alarms | 16.67d? | 2009-09-07 A | 2009-09-29 A | 100% |  | 2009-04-22 | 2009-05-14 | 16.67d? |  | start no earlier than 2009-09-07 | Reinig [15%] | 20h | 20h | 1,500 | 1,500 | 1,500 |
| 328 | 1.3.4.4.1.6 | **RTC Software - non-time-critical tasks on Control Processor** | 45d? | 2009-06-01 A | 2009-07-31 A | 100% |  | 2009-06-01 | 2009-07-31 | 45d? |  |  |  | 90h | 90h | 6,750 | 6,750 | 6,750 |
| 329 | 1.3.4.4.1.6.1 | Parameter Loader | 45d? | 2009-06-01 A | 2009-07-31 A | 100% |  | 2009-04-22 | 2009-05-18 | 18.75d? |  | finish no earlier than 2009-07-31 | Reinig [16.7%] | 60h | 60h | 4,500 | 2,250 | 4,500 |
| 330 | 1.3.4.4.1.6.2 | Real-time Control Sequencer | 25d? | 2009-06-01 A | 2009-07-03 A | 100% |  | 2009-04-22 | 2009-05-26 | 25d? |  | start no earlier than 2009-06-01 | Reinig [15%] | 30h | 30h | 2,250 | 2,250 | 2,250 |
| 331 | 1.3.4.4.1.7 | **Software Internal Interfaces** | 175d? | 2009-05-01 A | 2009-12-31 | 90% | 17.5d? | 2009-05-01 | 2009-12-31 | 175d? | 101d |  |  | 222h | 199.8h | 16,650 | 16,650 | 14,985 |
| 332 | 1.3.4.4.1.7.1 | Control Processor (CP) to Processing Engine (PE) | 65d? | 2009-06-29 A | 2009-09-25 | 90% | 6.5d? | 2009-04-22 | 2009-05-26 | 25d? | 170d | finish no earlier than 2009-09-25 | Reinig [7.7%] | 40h | 36h | 3,000 | 3,000 | 2,700 |
| 333 | 1.3.4.4.1.7.2 | **WFS Camera Interfaces** | 146d? | 2009-05-01 A | 2009-11-20 | 90% | 14.6d? | 2009-04-22 | 2009-05-26 | 25d? | 130d |  |  | 162h | 145.8h | 12,150 | 12,000 | 10,935 |
| 334 | 1.3.4.4.1.7.2.1 | HOWFS Camera Interface | 146d? | 2009-05-01 A | 2009-11-20 | 90% | 14.6d? | 2009-04-22 | 2009-05-26 | 25d? | 130d | finish no earlier than 2009-11-20 | Peck [3.5%]; Reinig [3.5%] | 82h | 73.8h | 6,150 | 6,000 | 5,535 |
| 335 | 1.3.4.4.1.7.2.2 | LOWFS Camera Interface | 25d? | 2009-05-25 A | 2009-06-26 | 90% | 2.5d? | 2009-04-22 | 2009-05-26 | 25d? | 235d | start no earlier than 2009-05-25 | Reinig [20%]; Peck [20%] | 80h | 72h | 6,000 | 6,000 | 5,400 |
| 336 | 1.3.4.4.1.7.3 | DM Driver Interfaces | 89d? | 2009-08-31 A | 2009-12-31 | 90% | 8.9d? | 2009-04-22 | 2009-05-08 | 12.5d? | 101d | finish no earlier than 2009-12-31 | Reinig [2.8%] | 20h | 18h | 1,500 | 1,500 | 1,350 |
| 337 | 1.3.4.4.1.8 | **Software External Interfaces** | 25d? | 2009-09-14 A | 2009-10-16 A | 100% |  | 2009-04-22 | 2009-05-26 | 25d? |  |  |  | 40h | 40h | 3,000 | 3,000 | 3,000 |
| 338 | 1.3.4.4.1.8.1 | RTC Server on Control Processor (CP) | 25d? | 2009-09-14 A | 2009-10-16 A | 100% |  | 2009-04-22 | 2009-05-26 | 25d? |  | start no earlier than 2009-09-14 | Reinig [10%] | 20h | 20h | 1,500 | 1,500 | 1,500 |
| 339 | 1.3.4.4.1.8.2 | Interface to Data Telemetry Capture System | 25d? | 2009-09-14 A | 2009-10-16 A | 100% |  | 2009-04-22 | 2009-05-26 | 25d? |  | start no earlier than 2009-09-14 | Reinig [10%] | 20h | 20h | 1,500 | 1,500 | 1,500 |
| 340 | 1.3.4.4.1.9 | **RTC Integration and Testing Plan** | 175d? | 2009-05-01 A | 2009-12-31 | 48% | 90.77d? | 2009-05-01 | 2009-12-31 | 175d? | 101d |  |  | 246h | 123h | 18,450 | 18,450 | 9,225 |
| 341 | 1.3.4.4.1.9.1 | Hardware Test Plan | 89d? | 2009-08-31 A | 2009-12-31 | 35% | 57.85d? | 2009-04-22 | 2009-05-08 | 12.5d? | 101d | finish no earlier than 2009-12-31 | Peck [4.5%]; Reinig [20%]; Gavel [5%] | 42h | 21h | 3,150 | 1,950 | 1,575 |

Notes:
- 318: Real time control code that runs on each massively parallel processing (MPP) element, which on the whole comprises the real time processing engine (PE).
- 322: Program the feedback control loop for closed-loop woofer / open-loop tweeter
- 327: "heartbeat", health status, operating within normal bounds, alarms

| ID | WBS | Task | Type | Duration | Start | Finish | Complete | Remaining | Baseline start | Baseline finish | Baseline duration | Total slack | Constraint | Resources | Work | Actual work | Cost | Baseline cost | Actual cost |
| --- | --- | --- | --- | --- | --- | --- | --- | --- | --- | --- | --- | --- | --- | --- | --- | --- | --- | --- | --- |
| 342 | 1.3.4.4.1.9.2 | **Software Test Plan** |  | 162d? | 2009-05-01 A | 2009-12-14 | 50% | 81d? | 2009-04-22 | 2009-06-30 | 50d? | 114d |  |  | 204h | 102h | 15,300 | 18,000 | 7,650 |
| 343 | 1.3.4.4.1.9.2.1 | Centroider / Wavefront Reconstructor test |  | 156d? | 2009-05-01 A | 2009-12-04 | 50% | 78d? | 2009-04-22 | 2009-06-30 | 50d? | 120d | finish no earlier than 2009-12-04 | Reinig [2.9%] | 36h | 18h | 2,700 | 3,000 | 1,350 |
| 344 | 1.3.4.4.1.9.2.2 | Tomography Test |  | 50d? | 2009-09-28 A | 2009-12-04 | 50% | 25d? | 2009-04-22 | 2009-06-30 | 50d? | 120d | finish no earlier than 2009-12-04 | Reinig [5%] | 20h | 10h | 1,500 | 3,000 | 750 |
| 345 | 1.3.4.4.1.9.2.3 | LOWFS processing test |  | 151d? | 2009-05-01 A | 2009-11-27 | 50% | 75.5d? | 2009-04-22 | 2009-06-30 | 50d? | 125d | finish no earlier than 2009-11-27 | Reinig [3%] | 36h | 18h | 2,700 | 3,000 | 1,350 |
| 346 | 1.3.4.4.1.9.2.4 | DM processing test |  | 61d? | 2009-09-14 A | 2009-12-07 | 50% | 30.5d? | 2009-04-22 | 2009-06-30 | 50d? | 119d | finish no earlier than 2009-12-07 | Reinig [8.2%] | 40h | 20h | 3,000 | 3,000 | 1,500 |
| 347 | 1.3.4.4.1.9.2.5 | Hybrid control loop test |  | 66d? | 2009-09-14 A | 2009-12-14 | 50% | 33d? | 2009-04-22 | 2009-06-30 | 50d? | 114d | finish no earlier than 2009-12-14 | Reinig [7.6%] | 40h | 20h | 3,000 | 3,000 | 1,500 |
| 348 | 1.3.4.4.1.9.2.6 | External interfaces test |  | 141d? | 2009-05-01 A | 2009-11-13 | 50% | 70.5d? | 2009-04-22 | 2009-06-30 | 50d? | 135d | finish no earlier than 2009-11-13 | Reinig [2.8%] | 32h | 16h | 2,400 | 3,000 | 1,200 |
| 349 | 1.3.4.4.1.10 | **Documentation** |  | 186d? | 2009-05-01 A | 2010-01-15 | 92% | 15.32d? | 2009-05-01 | 2010-01-15 | 186d? | 90d |  |  | 180h | 171.1h | 13,499.96 | 13,499.96 | 12,832.46 |
| 350 | 1.3.4.4.1.10.1 | Summary of Documents |  | 2d? | 2009-05-01 A | 2009-05-04 A | 100% |  | 2009-04-22 | 2009-05-01 | 7.5d? |  | finish no earlier than 2009-05-04 | Gavel [12.5%] | 2h | 2h | 150 | 225 | 150 |
| 351 | 1.3.4.4.1.10.2 | Control Loops and Offloading Paths Diagram |  | 43d? | 2009-05-01 A | 2009-06-30 | 95% | 2.15d? | 2009-04-22 | 2009-06-30 | 50d? | 233d | finish no earlier than 2009-06-30 | Gavel [4.9%] | 17h | 16.15h | 1,275 | 1,500 | 1,211.25 |
| 352 | 1.3.4.4.1.10.3 | Processor Engine (PE) design |  | 131d? | 2009-05-01 A | 2009-10-30 | 91% | 12.38d? | 2009-04-22 | 2009-05-14 | 16.67d? | 0d | finish no earlier than 2009-10-30 | Reinig [2.9%]; Peck [30%] | 57h | 54.15h | 4,274.96 | 5,580 | 4,061.21 |
| 353 | 1.3.4.4.1.10.4 | RTC Algorithms Description |  | 124d? | 2009-05-01 A | 2009-10-21 | 95% | 6.2d? | 2009-04-22 | 2009-05-14 | 16.67d? | 152d | finish no earlier than 2009-10-21 | Reinig [1.4%] | 14h | 13.3h | 1,050 | 3,000 | 997.5 |
| 354 | 1.3.4.4.1.10.5 | Control Processor (CP) design |  | 128d? | 2009-05-01 A | 2009-10-27 | 95% | 6.4d? | 2009-04-22 | 2009-04-30 | 6.25d? | 148d | finish no earlier than 2009-10-27 | Reinig [0.5%] | 5h | 4.75h | 375 | 750 | 356.25 |
| 355 | 1.3.4.4.1.10.6 | Hardware Interface Documentation |  | 175d? | 2009-05-01 A | 2009-12-31 | 91% | 15.72d? | 2009-04-22 | 2009-05-08 | 12.5d? | 0d | finish no earlier than 2009-12-31 | Reinig [2.4%]; Peck [30%] | 60h | 57h | 4,500 | 4,080 | 4,275 |
| 356 | 1.3.4.4.1.10.7 | Integration and Test Plan |  | 55d? | 2009-11-02 A | 2010-01-15 | 84% | 8.59d? | 2009-04-22 | 2009-05-19 | 20d? | 0d | finish no earlier than 2010-01-15 | Gavel [1.8%]; Peck [10%]; Reinig [10%] | 25h | 23.75h | 1,875 | 1,860 | 1,781.25 |
| 357 | 1.3.4.4.1.10.8 | **Document milestones** |  | 121d? | 2009-05-15 | 2009-10-30 |  |  | 2009-05-15 | 2009-10-30 | 121d? | 145d |  |  |  |  |  |  |  |
| 358 | 1.3.4.4.1.10.8.1 | Version 0.1 | milestone | 1d? | 2009-05-15 | 2009-05-15 |  |  | 2009-05-15 | 2009-05-15 | 1d? | 265d | start no earlier than 2009-05-15 |  |  |  |  |  |  |
| 359 | 1.3.4.4.1.10.8.2 | Version 0.2 | milestone | 1d? | 2009-08-31 | 2009-08-31 |  |  | 2009-08-31 | 2009-08-31 | 1d? | 189d | start no earlier than 2009-08-31 |  |  |  |  |  |  |
| 360 | 1.3.4.4.1.10.8.3 | Version 1.0 | milestone | 1d? | 2009-10-30 | 2009-10-30 |  |  | 2009-10-30 | 2009-10-30 | 1d? | 145d | start no earlier than 2009-10-30 |  |  |  |  |  |  |
| 361 | 1.3.4.4.1.11 | **Costing and Design Iteration Milestones** |  | 70d? | 2009-11-30 | 2010-03-05 |  |  | 2009-11-30 | 2010-03-05 | 70d? | 55d |  |  |  |  |  |  |  |
| 362 | 1.3.4.4.1.11.1 | Update 1 to cost estimate | milestone | 1d? | 2009-11-30 | 2009-11-30 |  |  | 2009-11-30 | 2009-11-30 | 1d? | 124d | start no earlier than 2009-11-30 |  |  |  |  |  |  |
| 363 | 1.3.4.4.1.11.2 | Design Iteration 1 | milestone | 1d? | 2010-01-29 | 2010-01-29 |  |  | 2010-01-29 | 2010-01-29 | 1d? | 80d | start no earlier than 2010-01-29 |  |  |  |  |  |  |
| 364 | 1.3.4.4.1.11.3 | Update 2 to cost estimate | milestone | 1d? | 2010-03-05 | 2010-03-05 |  |  | 2010-03-05 | 2010-03-05 | 1d? | 55d | start no earlier than 2010-03-05 |  |  |  |  |  |  |
| 365 | 1.3.4.4.2 | **DMs & Tip/Tilt Stages** |  | 96d? | 2009-05-01 A | 2009-09-11 | 48% | 49.82d? | 2008-10-06 | 2009-02-27 | 105d? | 180d |  |  | 248h | 223.5h | 18,600 | 24,000 | 16,762.5 |
| 366 | 1.3.4.4.2.1 | **Woofer DM/TT** |  | 96d? | 2009-05-01 A | 2009-09-11 | 53% | 44.95d? | 2008-10-06 | 2009-02-27 | 105d? | 180d |  |  | 113h | 94.5h | 8,475 | 9,900 | 7,087.5 |
| 367 | 1.3.4.4.2.1.1 | Evaluate Tip/Tilt Mount Options |  | 71d? | 2009-05-01 A | 2009-08-07 | 89% | 7.87d? | 2008-12-01 | 2009-01-09 | 30d? | 0d | finish no earlier than 2009-08-07 | Lockwood [6.5%]; Gavel [50%] | 41h | 36.9h | 3,075 | 3,300 | 2,767.5 |
| 368 | 1.3.4.4.2.1.2 | Evaluate Combined DM & Tip/Tilt Performance |  | 11d? | 2009-08-07 A | 2009-08-21 | 90% | 1.1d? | 2009-01-12 | 2009-01-23 | 10d? | 195d | finish no earlier than 2009-08-21 | Gavel [18.2%] | 16h | 14.4h | 1,200 | 1,200 | 1,080 |
| 369 | 1.3.4.4.2.1.3 | Select Tip/Tilt Mount |  | 6d? | 2009-08-21 A | 2009-08-28 | 80% | 1.2d? | 2009-01-26 | 2009-01-30 | 5d? | 0d | finish no earlier than 2009-08-28 | Gavel [8.3%]; Lockwood | 8h | 7.2h | 600 | 600 | 540 |
| 370 | 1.3.4.4.2.1.4 | Design Mechanical Package |  | 11d? | 2009-08-28 A | 2009-09-11 | 90% | 1.1d? | 2009-02-16 | 2009-02-27 | 10d? | 180d | finish no earlier than 2009-09-11 | Lockwood [45.5%] | 40h | 36h | 3,000 | 3,000 | 2,700 |
| 371 | 1.3.4.4.2.1.5 | Obtain Quotes |  | 66d? | 2009-05-01 | 2009-07-31 |  |  | 2009-01-05 | 2009-01-30 | 20d? | 210d | start no earlier than 2009-05-01 | Lockwood [1.5%] | 8h |  | 600 | 600 |  |

Notes:
- 342: Write the test plans that will be used to validate the code running on the real-time processing engine (PE)
- 355: Describe the electronic hardware interface and the software protocols needed to connect the WFS cameras and the DM drivers to the RTC Processing Engine
- 365: DG
- 366: DG

| ID | WBS | Task | Type | Duration | Start | Finish | Complete | Remaining | Baseline start | Baseline finish | Baseline duration | Total slack | Constraint | Resources | Work | Actual work | Cost | Baseline cost | Actual cost |
| --- | --- | --- | --- | --- | --- | --- | --- | --- | --- | --- | --- | --- | --- | --- | --- | --- | --- | --- | --- |
| 372 | 1.3.4.4.2.2 | **Tweeter DM/TT** |  | 87d? | 2009-05-01 A | 2009-08-31 | 47% | 46.44d? | 2008-10-06 | 2009-02-13 | 95d? | 189d |  |  | 23h | 21h | 1,725 | 3,600 | 1,575 |
| 373 | 1.3.4.4.2.2.1 | Evaluate Options & Select Tip/Tilt Mount |  | 66d? | 2009-05-01 A | 2009-07-31 A | 100% |  | 2008-11-03 | 2008-11-28 | 20d? |  | finish no earlier than 2009-07-31 | Lockwood [0.9%]; Gavel [50%] | 13h | 13h | 975 | 2,100 | 975 |
| 374 | 1.3.4.4.2.2.2 | Design Mechanical Package |  | 10d? | 2009-08-03 A | 2009-08-14 A | 100% |  | 2009-02-02 | 2009-02-13 | 10d? |  | start no earlier than 2009-08-03 | Lockwood [10%] | 8h | 8h | 600 | 600 | 600 |
| 375 | 1.3.4.4.2.2.3 | Obtain Quotes |  | 87d? | 2009-05-01 | 2009-08-31 |  |  | 2008-11-03 | 2008-11-28 | 20d? | 189d | finish no earlier than 2009-08-31 | Gavel [0.3%] | 2h |  | 150 | 300 |  |
| 376 | 1.3.4.4.2.3 | **LOWFS DM/TT** |  | 90d? | 2009-05-01 A | 2009-09-03 | 44% | 50d? | 2008-10-06 | 2009-02-13 | 95d? | 186d |  |  | 112h | 108h | 8,400 | 10,500 | 8,100 |
| 377 | 1.3.4.4.2.3.1 | Evaluate Options & Select Tip/Tilt Mount |  | 46d? | 2009-05-01 A | 2009-07-03 A | 100% |  | 2008-11-03 | 2008-11-28 | 20d? |  | finish no earlier than 2009-07-03 | Lockwood [5.4%]; Gavel [50%] | 28h | 28h | 2,100 | 2,100 | 2,100 |
| 378 | 1.3.4.4.2.3.2 | Design Mechanical Package |  | 26d? | 2009-07-03 A | 2009-08-07 A | 100% |  | 2009-01-12 | 2009-02-13 | 25d? |  | finish no earlier than 2009-08-07 | Lockwood [38.5%] | 80h | 80h | 6,000 | 6,000 | 6,000 |
| 379 | 1.3.4.4.2.3.3 | Obtain Quotes |  | 90d? | 2009-05-01 | 2009-09-03 |  |  | 2008-11-03 | 2008-11-28 | 20d? | 186d | finish no earlier than 2009-09-03 | Gavel [0.6%] | 4h |  | 300 | 300 |  |
| 380 | 1.3.4.5 | **AO System Lab I&T** |  | 80d? | 2009-11-02 | 2010-02-19 |  |  | 2009-07-06 | 2009-08-28 | 40d? | 65d |  |  | 194h |  | 14,550 | 15,000 |  |
| 381 | 1.3.4.5.1 | AO System Lab I&T Scope Definition |  | 6.25d? | 2009-11-02 | 2009-11-10 |  |  | 2009-07-06 | 2009-07-17 | 10d? | 138.75d | start no earlier than 2009-11-02 | Wizinowich [20%] | 10h |  | 750 | 1,200 |  |
| 382 | 1.3.4.5.2 | AO System Lab Facility Plan |  | 70d? | 2009-11-16 | 2010-02-19 |  |  | 2009-07-20 | 2009-08-28 | 30d? | 65d | finish no earlier than 2010-02-19 | Neyman [4.3%] | 24h |  | 1,800 | 1,800 |  |
| 383 | 1.3.4.5.3 | AO System Lab Integration Plan |  | 70d? | 2009-11-16 | 2010-02-19 |  |  | 2009-07-20 | 2009-08-28 | 30d? | 65d | finish no earlier than 2010-02-19 | Neyman [14.3%] | 80h |  | 6,000 | 6,000 |  |
| 384 | 1.3.4.5.4 | AO System Lab Test Plan |  | 70d? | 2009-11-16 | 2010-02-19 |  |  | 2009-07-27 | 2009-08-28 | 25d? | 65d | finish no earlier than 2010-02-19 | Neyman [14.3%] | 80h |  | 6,000 | 6,000 |  |
| 385 | 1.3.5 | **Laser Guide Star Facility (LGSF) Design** |  | 241d? | 2009-04-28 A | 2010-03-30 | 62% | 92.25d? | 2008-05-05 | 2009-12-04 | 415d? | 38d |  |  | 1426h | 873h | 106,950 | 83,400 | 65,475 |
| 386 | 1.3.5.1 | **Laser Enclosure (LE)** |  | 45d? | 2009-10-05 A | 2009-12-04 | 2% | 44.3d? | 2009-10-05 | 2009-12-04 | 45d? | 120d |  |  | 120h | 6h | 9,000 | 9,000 | 450 |
| 387 | 1.3.5.1.1 | LE Mechanical Design |  | 10d? | 2009-10-05 A | 2009-10-16 | 5% | 9.5d? | 2009-10-05 | 2009-10-16 | 10d? | 155d | start no earlier than 2009-10-05 | Chin; Bell [50%] | 50h | 6h | 3,750 | 3,750 | 450 |
| 388 | 1.3.5.1.2 | LE Environmental Control Design |  | 12d? | 2009-10-19 | 2009-11-03 |  |  | 2009-10-19 | 2009-11-18 | 23d? | 143d | start no earlier than 2009-10-19 | Chin [10.4%]; Nance [21.7%]; Bell [20.8%] | 50h |  | 3,750 | 3,750 |  |
| 389 | 1.3.5.1.3 | LE Assembly & Test Plans |  | 10d? | 2009-11-23 | 2009-12-04 |  |  | 2009-11-23 | 2009-12-04 | 10d? | 120d | start no earlier than 2009-11-23 | Chin [5%]; Medeiros [10%]; Bell [10%] | 20h |  | 1,500 | 1,500 |  |
| 390 | 1.3.5.2 | **Laser Units** |  | 241d? | 2009-04-28 A | 2010-03-30 | 77% | 54.78d? | 2008-05-05 | 2009-05-29 | 280d? | 38d |  |  | 400h | 302h | 30,000 | 28,500 | 22,650 |
| 391 | 1.3.5.2.1 | Laser PD Contract Management |  | 174d? | 2009-05-01 A | 2009-12-30 | 95% | 8.7d? | 2008-05-05 | 2009-05-29 | 280d? | 102d | start no earlier than 2009-05-01 | Adkins [4.3%]; Wizinowich [4.3%]; Chin [2.9%] | 160h | 152h | 12,000 | 22,500 | 11,400 |
| 392 | 1.3.5.2.2 | Laser Preliminary Design Evaluations |  | 39d? | 2009-10-15 A | 2009-12-08 A | 100% |  | 2009-10-15 | 2009-12-08 | 39d? |  | start no earlier than 2009-10-15 | Adkins [12.8%]; Chin [12.8%]; Wizinowich [12.8%] | 120h | 120h | 9,000 | 9,000 | 9,000 |
| 393 | 1.3.5.2.3 | Laser Detailed Design Definition/Collaborations |  | 76d? | 2009-12-15 A | 2010-03-30 | 25% | 57d? | 2009-12-15 | 2010-03-30 | 76d? | 38d | start no earlier than 2009-12-15 | Adkins [6.6%]; Chin [3.3%]; Wizinowich [9.9%] | 120h | 30h | 9,000 | 9,000 | 2,250 |
| 394 | 1.3.5.2.4 | **FASORtronics PD Milestones** |  | 144d | 2009-04-28 | 2009-11-16 |  |  | 2009-04-28 | 2009-11-16 | 144d | 135d |  |  |  |  |  |  |  |
| 395 | 1.3.5.2.4.1 | Progress Report 1 | milestone | 0d | 2009-04-28 | 2009-04-28 |  |  | 2009-04-28 | 2009-04-28 | 0d? | 279d | start no earlier than 2009-04-28 |  |  |  |  |  |  |
| 396 | 1.3.5.2.4.2 | Progress Report 2 | milestone | 0d | 2009-06-24 | 2009-06-24 |  |  | 2009-06-24 | 2009-06-24 | 0d? | 238d | start no earlier than 2009-06-24 |  |  |  |  |  |  |
| 397 | 1.3.5.2.4.3 | Progress Report 3 | milestone | 0d | 2009-08-26 | 2009-08-26 |  |  | 2009-08-26 | 2009-08-26 | 0d? | 193d | start no earlier than 2009-08-26 |  |  |  |  |  |  |
| 398 | 1.3.5.2.4.4 | Progress Report 4 | milestone | 0d | 2009-10-28 | 2009-10-28 |  |  | 2009-10-28 | 2009-10-28 | 0d? | 148d | start no earlier than 2009-10-28 |  |  |  |  |  |  |
| 399 | 1.3.5.2.4.5 | Preliminary Design Review | milestone | 0d | 2009-11-16 | 2009-11-16 |  |  | 2009-11-16 | 2009-11-16 | 0d? | 135d | start no earlier than 2009-11-16 |  |  |  |  |  |  |

Notes:
- 372: DG
- 376: DG
- 380: CN
- 381: PW
- 382: CN
- 383: CN
- 384: CN
- 385: JC
- 386: JC
- 387: DM
- 388: JC
- 389: JC
- 390: PW
- 391: PW
- 392: PW
- 393: PW

| ID | WBS | Task | Type | Duration | Start | Finish | Complete | Remaining | Baseline start | Baseline finish | Baseline duration | Total slack | Constraint | Resources | Work | Actual work | Cost | Baseline cost | Actual cost |
| --- | --- | --- | --- | --- | --- | --- | --- | --- | --- | --- | --- | --- | --- | --- | --- | --- | --- | --- | --- |
| 400 | 1.3.5.2.5 | **TOPTICA PD Milestones** |  | 141d | 2009-05-15 | 2009-11-30 |  |  | 2009-05-15 | 2009-11-30 | 141d | 125d |  |  |  |  |  |  |  |
| 401 | 1.3.5.2.5.1 | Progress Report 1 | milestone | 0d | 2009-05-15 | 2009-05-15 |  |  | 2009-05-15 | 2009-05-15 | 0d? | 266d | start no earlier than 2009-05-15 |  |  |  |  |  |  |
| 402 | 1.3.5.2.5.2 | Progress Report 2 | milestone | 0d | 2009-06-19 | 2009-06-19 |  |  | 2009-06-19 | 2009-06-19 | 0d? | 241d | start no earlier than 2009-06-19 |  |  |  |  |  |  |
| 403 | 1.3.5.2.5.3 | Progress Report 3 | milestone | 0d | 2009-08-04 | 2009-08-04 |  |  | 2009-08-04 | 2009-08-04 | 0d? | 209d | start no earlier than 2009-08-04 |  |  |  |  |  |  |
| 404 | 1.3.5.2.5.4 | Progress Report 4 | milestone | 0d | 2009-10-15 | 2009-10-15 |  |  | 2009-10-15 | 2009-10-15 | 0d? | 157d | start no earlier than 2009-10-15 |  |  |  |  |  |  |
| 405 | 1.3.5.2.5.5 | Preliminary Design Review | milestone | 0d | 2009-11-30 | 2009-11-30 |  |  | 2009-11-30 | 2009-11-30 | 0d? | 125d | start no earlier than 2009-11-30 |  |  |  |  |  |  |
| 406 | 1.3.5.2.6 | **AURA Sub-Award Quarterly Reports** |  | 196d | 2009-04-30 | 2010-01-29 |  |  | 2009-04-30 | 2009-12-30 | 174d | 81d |  |  |  |  |  |  |  |
| 407 | 1.3.5.2.6.1 | Report 1 | milestone | 0d | 2009-04-30 | 2009-04-30 |  |  | 2009-04-30 | 2009-04-30 | 0d? | 277d | start no earlier than 2009-04-30 |  |  |  |  |  |  |
| 408 | 1.3.5.2.6.2 | Report 2 | milestone | 0d | 2009-07-31 | 2009-07-31 |  |  | 2009-06-30 | 2009-06-30 | 0d? | 211d | start no earlier than 2009-07-31 |  |  |  |  |  |  |
| 409 | 1.3.5.2.6.3 | Report 3 | milestone | 0d | 2009-10-30 | 2009-10-30 |  |  | 2009-09-30 | 2009-09-30 | 0d? | 146d | start no earlier than 2009-10-30 |  |  |  |  |  |  |
| 410 | 1.3.5.2.6.4 | Final Report | milestone | 0d | 2010-01-29 | 2010-01-29 |  |  | 2009-12-30 | 2009-12-30 | 0d? | 81d | start no earlier than 2010-01-29 |  |  |  |  |  |  |
| 411 | 1.3.5.3 | **Laser Launch Facility (LLF)** |  | 161d? | 2009-05-01 A | 2009-12-11 | 66% | 55.4d? | 2009-04-01 | 2009-09-11 | 118d? | 115d |  |  | 664h | 459.6h | 49,800 | 29,550 | 34,470 |
| 412 | 1.3.5.3.1 | LLF Requirements & Interfaces |  | 41d? | 2009-05-01 A | 2009-06-26 A | 100% |  | 2009-04-01 | 2009-05-08 | 6d? |  | finish no earlier than 2009-06-26 | Neyman [3%]; Chin [3%] | 20h | 20h | 1,500 | 1,500 | 1,500 |
| 413 | 1.3.5.3.2 | LLF Optical Design |  | 86d? | 2009-05-01 A | 2009-08-28 | 90% | 8.6d? | 2009-05-01 | 2009-06-19 | 36d? | 190d | finish no earlier than 2009-08-28 | Neyman [2.9%]; Stalcup [29.1%] | 220h | 198h | 16,500 | 3,000 | 14,850 |
| 414 | 1.3.5.3.3 | LLF Launch Telescope Preliminary Design Contract (Resue KI?? MRI/NSF) |  | 55d? | 2009-05-18 A | 2009-07-31 | 40% | 33d? | 2009-05-18 | 2009-07-31 | 55d? | 210d | start no earlier than 2009-05-18 | Chin [5.5%] | 24h | 9.6h | 1,800 | 1,800 | 720 |
| 415 | 1.3.5.3.4 | LLF Mechanical Design |  | 38d? | 2009-08-10 A | 2009-09-30 | 85% | 5.7d? | 2009-06-01 | 2009-07-31 | 45d? | 167d | start no earlier than 2009-08-10 | Stalcup [6.6%]; Bell [49.3%]; Mogensen [16.4%] | 220h | 187h | 16,500 | 15,000 | 14,025 |
| 416 | 1.3.5.3.5 | LLF Electrical Design |  | 40d? | 2009-09-07 A | 2009-10-30 | 25% | 30d? | 2009-07-20 | 2009-08-28 | 30d? | 145d | start no earlier than 2009-09-07 | Stalcup [6.2%]; Chin [6.2%]; Wetherell [25%] | 120h | 30h | 9,000 | 7,500 | 2,250 |
| 417 | 1.3.5.3.6 | LLF Assembly, Alignment & Test Plans |  | 30d? | 2009-11-02 A | 2009-12-11 | 25% | 22.5d? | 2009-08-31 | 2009-09-11 | 10d? | 115d | finish no earlier than 2009-12-11 | Stalcup [20.8%]; Chin [4.2%] | 60h | 15h | 4,500 | 750 | 1,125 |
| 418 | 1.3.5.4 | **Laser Safety Systems** |  | 88d? | 2009-06-01 A | 2009-09-30 | 54% | 40.7d? | 2009-06-01 | 2009-09-30 | 88d? | 167d |  |  | 194h | 105.4h | 14,550 | 12,750 | 7,905 |
| 419 | 1.3.5.4.1 | **Personnel & Equipment Safety System** |  | 43d? | 2009-08-03 A | 2009-09-30 | 50% | 21.5d? | 2009-08-03 | 2009-09-30 | 43d? | 167d |  |  | 130h | 65h | 9,750 | 9,750 | 4,875 |
| 420 | 1.3.5.4.1.1 | Safety Requirements & Interfaces |  | 10d? | 2009-08-03 A | 2009-08-14 | 50% | 5d? | 2009-08-03 | 2009-08-14 | 10d? | 200d | start no earlier than 2009-08-03 | Chin [50%] | 40h | 20h | 3,000 | 3,000 | 1,500 |
| 421 | 1.3.5.4.1.2 | Safety Algorithms, Diagrams & Dataflow |  | 33d? | 2009-08-17 A | 2009-09-30 | 50% | 16.5d? | 2009-08-17 | 2009-09-30 | 33d? | 167d | start no earlier than 2009-08-17 | Chin [7.6%] | 20h | 10h | 1,500 | 1,500 | 750 |
| 422 | 1.3.5.4.1.3 | Safety Communication Protocols & Methods |  | 33d? | 2009-08-17 A | 2009-09-30 | 50% | 16.5d? | 2009-08-17 | 2009-09-30 | 33d? | 167d | start no earlier than 2009-08-17 | Chin [7.6%] | 20h | 10h | 1,500 | 1,500 | 750 |
| 423 | 1.3.5.4.1.4 | Safety Performance Estimate |  | 33d? | 2009-08-17 A | 2009-09-30 | 50% | 16.5d? | 2009-08-17 | 2009-09-30 | 33d? | 167d | start no earlier than 2009-08-17 | Chin [7.6%] | 20h | 10h | 1,500 | 1,500 | 750 |
| 424 | 1.3.5.4.1.5 | Safety Electronics, Shutter & Interlocks |  | 33d? | 2009-08-17 A | 2009-09-30 | 50% | 16.5d? | 2009-08-17 | 2009-09-30 | 33d? | 167d | start no earlier than 2009-08-17 | Wetherell [3.8%] | 10h | 5h | 750 | 750 | 375 |
| 425 | 1.3.5.4.1.6 | Safety Test Plans |  | 33d? | 2009-08-17 A | 2009-09-30 | 50% | 16.5d? | 2009-08-17 | 2009-09-30 | 33d? | 167d | start no earlier than 2009-08-17 | Chin [3.8%]; Wetherell [3.8%] | 20h | 10h | 1,500 | 1,500 | 750 |

Notes:
- 411: TS
- 418: JC
- 419: JC

| ID | WBS | Task | Duration | Start | Finish | Predecessors | Complete | Remaining | Baseline start | Baseline finish | Baseline duration | Total slack | Free slack | Constraint | Resources | Work | Actual work | Cost | Baseline cost | Actual cost |
| --- | --- | --- | --- | --- | --- | --- | --- | --- | --- | --- | --- | --- | --- | --- | --- | --- | --- | --- | --- | --- |
| 426 | 1.3.5.4.2 | **Laser Traffic Control System (LTCS) Modifications (Doug can start earlier per JC)** | 20d? | 2009-06-01 A | 2009-06-26 |  | 50% | 10d? | 2009-06-01 | 2009-06-26 | 20d? | 235d |  |  |  | 40h | 20h | 3,000 | 3,000 | 1,500 |
| 427 | 1.3.5.4.2.1 | LTCS Requirements & Interfaces (LTCS mods. independent of other pieces laser facility design) | 20d? | 2009-06-01 A | 2009-06-26 |  | 50% | 10d? | 2009-06-01 | 2009-06-26 | 20d? | 235d |  | finish no earlier than 2009-06-26 | Summers [5%] | 8h | 4h | 600 | 600 | 300 |
| 428 | 1.3.5.4.2.2 | LTCS Algorithms, Diagrams & Dataflow | 20d? | 2009-06-01 A | 2009-06-26 |  | 50% | 10d? | 2009-06-01 | 2009-06-26 | 20d? | 235d |  | finish no earlier than 2009-06-26 | Summers [5%] | 8h | 4h | 600 | 600 | 300 |
| 429 | 1.3.5.4.2.3 | LTCS Communication Protocols & Methods | 20d? | 2009-06-01 A | 2009-06-26 |  | 50% | 10d? | 2009-06-01 | 2009-06-26 | 20d? | 235d |  | finish no earlier than 2009-06-26 | Summers [5%] | 8h | 4h | 600 | 600 | 300 |
| 430 | 1.3.5.4.2.4 | LTCS Performance Estimate | 20d? | 2009-06-01 A | 2009-06-26 |  | 50% | 10d? | 2009-06-01 | 2009-06-26 | 20d? | 235d |  | finish no earlier than 2009-06-26 | Summers [5%] | 8h | 4h | 600 | 600 | 300 |
| 431 | 1.3.5.4.2.5 | LTCS Test Plans | 20d? | 2009-06-01 A | 2009-06-26 |  | 50% | 10d? | 2009-06-01 | 2009-06-26 | 20d? | 235d |  | finish no earlier than 2009-06-26 | Summers [5%] | 8h | 4h | 600 | 600 | 300 |
| 432 | 1.3.5.4.3 | **Space Command Laser Clearing House (LCH)** | 33d? | 2009-08-17 A | 2009-09-30 |  | 85% | 4.95d? |  |  |  | 167d |  |  |  | 24h | 20.4h | 1,800 |  | 1,530 |
| 433 | 1.3.5.4.3.1 | LCH Requirements & Interfaces | 33d? | 2009-08-17 A | 2009-09-30 |  | 85% | 4.95d? |  |  |  | 167d |  | finish no earlier than 2009-09-30 | Chin [9.1%] | 24h | 20.4h | 1,800 |  | 1,530 |
| 434 | 1.3.5.5 | Laser System Lab I&T Plan | 20d? | 2009-10-05 | 2009-10-30 |  |  |  | 2009-10-05 | 2009-10-30 | 20d? | 145d |  | finish no earlier than 2009-10-30 | Stalcup [20%]; Chin; Bell | 48h |  | 3,600 | 3,600 |  |
| 435 | 1.3.6 | **Control System Design** | 200d? | 2009-06-15 A | 2010-03-19 |  | 16% | 167.54d? | 2009-05-29 | 2010-01-25 | 172d? | 45d |  |  |  | 1644h | 270h | 123,300 | 102,000 | 20,249.96 |
| 436 | 1.3.6.1 | **Controls electronics** | 200d? | 2009-06-15 A | 2010-03-19 |  | 33% | 134.25d? | 2009-05-29 | 2010-01-25 | 172d? | 45d |  |  |  | 600h | 190h | 45,000 | 45,000 | 14,250 |
| 437 | 1.3.6.1.1 | Controls Infrastructure | 10d? | 2009-06-15 A | 2009-06-26 | 196 | 75% | 2.5d? | 2009-05-29 | 2009-06-11 | 10d? | 95.75d | 0d | start no earlier than 2009-05-29 | Wetherell [50%] | 40h | 30h | 3,000 | 3,000 | 2,250 |
| 438 | 1.3.6.1.2 | Camera control | 10d? | 2009-06-29 A | 2009-07-10 | 437 | 25% | 7.5d? | 2009-06-12 | 2009-06-25 | 10d? | 93.25d | 0d | start no earlier than 2009-06-12 | Wetherell [50%] | 40h | 10h | 3,000 | 3,000 | 750 |
| 439 | 1.3.6.1.3 | DM & TT Control | 33d? | 2009-07-13 A | 2009-08-26 | 438 | 50% | 16.5d? | 2009-06-26 | 2009-07-09 | 10d? | 76.75d | 0d | finish no earlier than 2009-08-26 | Wetherell [15.2%] | 40h | 20h | 3,000 | 3,000 | 1,500 |
| 440 | 1.3.6.1.4 | Environmental and power control | 22d? | 2009-08-27 A | 2009-09-25 | 439 | 25% | 16.5d? | 2009-07-10 | 2009-08-10 | 22d? | 71.25d | 0d | finish no earlier than 2009-08-10 | Wetherell [22.7%] | 40h | 10h | 3,000 | 3,000 | 750 |
| 441 | 1.3.6.1.5 | RTC control | 10d? | 2009-09-28 A | 2009-10-09 | 440 | 50% | 5d? | 2009-08-11 | 2009-08-24 | 10d? | 71.25d | 0d |  | Wetherell [50%] | 40h | 20h | 3,000 | 3,000 | 1,500 |
| 442 | 1.3.6.1.6 | Laser control | 10d? | 2009-10-12 A | 2009-10-23 | 441 | 25% | 7.5d? | 2009-08-25 | 2009-09-07 | 10d? | 68.75d | 0d |  | Wetherell [50%] | 40h | 10h | 3,000 | 3,000 | 750 |
| 443 | 1.3.6.1.7 | Laser Safety System Control | 10d? | 2009-10-26 A | 2009-11-06 | 442 | 25% | 7.5d? | 2009-09-08 | 2009-09-21 | 10d? | 68.75d | 0d | start no earlier than 2009-08-03 | Wetherell [50%] | 40h | 10h | 3,000 | 3,000 | 750 |
| 444 | 1.3.6.1.8 | Motion control | 95d? | 2009-11-09 A | 2010-03-19 | 443 | 25% | 71.25d? | 2009-09-22 | 2010-01-25 | 90d? | 45d |  | finish no earlier than 2010-03-19 | Wetherell [42.1%] | 320h | 80h | 24,000 | 24,000 | 6,000 |
| 445 | 1.3.6.2 | **Controls Software** | 119.5d? | 2009-09-14 A | 2010-02-26 |  | 9% | 109.22d? | 2009-07-17 | 2009-12-30 | 118.06d? | 60.5d |  |  |  | 724h | 80h | 54,300 | 57,000 | 5,999.96 |
| 446 | 1.3.6.2.1 | Controls Infrastructure | 6d? | 2009-09-14 | 2009-09-21 | 195 |  |  | 2009-07-17 | 2009-07-24 | 5.56d? | 70.78d | 0d | start no earlier than 2009-07-17 | Johansson [41.7%]; Morrison [50%] | 40h |  | 3,000 | 3,000 |  |
| 447 | 1.3.6.2.2 | **Common services** | 31d? | 2009-09-22 | 2009-11-03 | 446 |  |  | 2009-07-24 | 2009-09-07 | 31.25d? | 70.78d | 0d |  |  | 164h |  | 12,300 | 15,000 |  |
| 448 | 1.3.6.2.2.1 | Telemetry | 3d? | 2009-09-22 | 2009-09-24 |  |  |  | 2009-07-24 | 2009-07-29 | 2.5d? | 70.78d | 0d | start no earlier than 2009-07-24 | Johansson [40%]; Morrison [50%] | 16h |  | 1,200 | 1,200 |  |
| 449 | 1.3.6.2.2.2 | Health monitoring | 3d? | 2009-09-25 | 2009-09-29 | 448 |  |  | 2009-07-29 | 2009-07-31 | 2.5d? | 70.78d | 0d | start no earlier than 2009-07-29 | Johansson [40%]; Morrison [50%] | 16h |  | 1,200 | 1,200 |  |
| 450 | 1.3.6.2.2.3 | Logging | 3d? | 2009-09-30 | 2009-10-02 | 449 |  |  | 2009-07-31 | 2009-08-05 | 2.5d? | 70.78d | 0d | start no earlier than 2009-07-31 | Johansson [40%]; Morrison [50%] | 16h |  | 1,200 | 1,200 |  |
| 451 | 1.3.6.2.2.4 | Archiving | 3d? | 2009-10-05 | 2009-10-07 | 450 |  |  | 2009-08-05 | 2009-08-07 | 2.5d? | 70.78d | 0d | start no earlier than 2009-08-05 | Johansson [40%]; Morrison [50%] | 16h |  | 1,200 | 1,200 |  |
| 452 | 1.3.6.2.2.5 | Alarming | 7.5d? | 2009-10-08 | 2009-10-19 | 451 |  |  | 2009-08-07 | 2009-08-17 | 6.25d? | 70.78d | 0d | start no earlier than 2009-08-07 | Johansson [40%]; Morrison [50%] | 40h |  | 3,000 | 3,000 |  |
| 453 | 1.3.6.2.2.6 | Configuration | 11.5d? | 2009-10-19 | 2009-11-03 | 452 |  |  | 2009-08-17 | 2009-09-07 | 15d? | 70.78d |  | start no earlier than 2009-08-17 | Johansson [16.3%]; Morrison [50%] | 60h |  | 4,500 | 7,200 |  |
| 454 | 1.3.6.2.3 | Camera control | 7.5d? | 2009-11-04 | 2009-11-13 | 447 |  |  | 2009-09-07 | 2009-09-16 | 6.25d? | 70.78d | 0d | start no earlier than 2009-09-07 | Johansson [40%]; Morrison [50%] | 40h |  | 3,000 | 3,000 |  |
| 455 | 1.3.6.2.4 | DM & TT Control | 7.5d? | 2009-11-13 | 2009-11-24 | 454 |  |  | 2009-09-16 | 2009-09-24 | 6.25d? | 70.78d | 0d | start no earlier than 2009-09-16 | Johansson [40%]; Morrison [50%] | 40h |  | 3,000 | 3,000 |  |
| 456 | 1.3.6.2.5 | Environmental and power control | 7.5d? | 2009-11-25 | 2009-12-04 | 455 |  |  | 2009-09-24 | 2009-10-02 | 6.25d? | 70.78d | 0d | start no earlier than 2009-09-24 | Johansson [40%]; Morrison [50%] | 40h |  | 3,000 | 3,000 |  |
| 457 | 1.3.6.2.6 | RTC control | 7.5d? | 2009-12-04 | 2009-12-15 | 456 |  |  | 2009-10-02 | 2009-10-12 | 6.25d? | 70.78d | 0d | start no earlier than 2009-10-02 | Johansson [40%]; Morrison [50%] | 40h |  | 3,000 | 3,000 |  |
| 458 | 1.3.6.2.7 | Laser control | 7.5d? | 2009-12-16 A | 2009-12-25 | 457 | 37% | 4.72d? | 2009-10-12 | 2009-10-21 | 6.25d? | 68d | 0d | start no earlier than 2009-10-12 | Johansson [40%]; Morrison [50%] | 40h | 20h | 3,000 | 3,000 | 1,499.96 |
| 459 | 1.3.6.2.8 | Laser Safety System Control | 7.5d? | 2009-12-25 | 2010-01-05 | 458 |  |  | 2009-10-21 | 2009-10-29 | 6.25d? | 68d | 0d | start no earlier than 2009-10-21 | Johansson [40%]; Morrison [50%] | 40h |  | 3,000 | 3,000 |  |
| 460 | 1.3.6.2.9 | Alignment & calibration source control | 7.5d? | 2010-01-06 | 2010-01-15 | 459 |  |  | 2009-10-29 | 2009-11-06 | 6.25d? | 68d | 0d | start no earlier than 2009-10-29 | Johansson [40%]; Morrison [50%] | 40h |  | 3,000 | 3,000 |  |
| 461 | 1.3.6.2.10 | Motion Control | 30d? | 2010-01-15 A | 2010-02-26 | 460 | 25% | 22.5d? | 2009-11-06 | 2009-12-30 | 37.5d? | 60.5d |  | start no earlier than 2009-11-06 | Johansson [33.3%]; Morrison [66.7%] | 240h | 60h | 18,000 | 18,000 | 4,500 |

Notes:
- 426: DS
- 434: TS
- 435: EJ
- 436: EW
- 445: EJ

| ID | WBS | Task | Duration | Start | Finish | Baseline start | Baseline finish | Baseline duration | Total slack | Constraint | Resources | Work | Cost | Baseline cost |
| --- | --- | --- | --- | --- | --- | --- | --- | --- | --- | --- | --- | --- | --- | --- |
| 462 | 1.3.6.3 | **Acquisition, Guiding & Offload (AGO) Control** | 43d? | 2009-10-01 | 2009-11-30 | 2009-07-01 | 2009-08-03 | 24d? | 124d |  |  | 320h | 24,000 | 24,000 |
| 463 | 1.3.6.3.1 | Acquisition | 22d? | 2009-10-01 | 2009-10-30 | 2009-07-01 | 2009-07-01 | 1d? | 145d | finish no earlier than 2009-10-30 | Johnson [22.7%] | 40h | 3,000 | 3,000 |
| 464 | 1.3.6.3.2 | Focus management | 22d? | 2009-10-01 | 2009-10-30 | 2009-07-01 | 2009-07-01 | 1d? | 145d | start no earlier than 2009-10-01 | Stalcup [22.7%]; Summers [20.5%]; Wizinowich [2.3%] | 80h | 6,000 | 6,000 |
| 465 | 1.3.6.3.3 | **Offloading** | 21d? | 2009-11-02 | 2009-11-30 | 2009-08-03 | 2009-08-03 | 1d? | 124d |  |  | 200h | 15,000 | 15,000 |
| 466 | 1.3.6.3.3.1 | Tip-Tilt offloading | 21d? | 2009-11-02 | 2009-11-30 | 2009-08-03 | 2009-08-03 | 1d? | 124d | start no earlier than 2009-11-02 | Stalcup [11.9%]; Johnson [11.9%] | 40h | 3,000 | 3,000 |
| 467 | 1.3.6.3.3.2 | Focus offloading | 21d? | 2009-11-02 | 2009-11-30 | 2009-08-03 | 2009-08-03 | 1d? | 124d | start no earlier than 2009-11-02 | Stalcup [11.9%]; Summers [11.9%] | 40h | 3,000 | 3,000 |
| 468 | 1.3.6.3.3.3 | Coma offloading | 21d? | 2009-11-02 | 2009-11-30 | 2009-08-03 | 2009-08-03 | 1d? | 124d | start no earlier than 2009-11-02 | Stalcup [11.9%]; Summers [11.9%] | 40h | 3,000 | 3,000 |
| 469 | 1.3.6.3.3.4 | Rotation offloading | 21d? | 2009-11-02 | 2009-11-30 | 2009-11-02 | 2009-11-30 | 21d? | 124d | start no earlier than 2009-11-02 | Stalcup [11.9%]; Johnson [11.9%] | 40h | 3,000 | 3,000 |
| 470 | 1.3.6.3.3.5 | ACS offloading | 21d? | 2009-11-02 | 2009-11-30 | 2009-11-02 | 2009-11-30 | 21d? | 124d | start no earlier than 2009-11-02 | Stalcup [11.9%]; Cohen [11.9%] | 40h | 3,000 | 3,000 |
| 471 | 1.3.7 | **Science Operations Tools Design** | 190d? | 2009-07-06 | 2010-03-26 | 2008-07-01 | 2009-10-30 | 349d? | 40d |  |  | 1500h | 112,500 | 112,500 |
| 472 | 1.3.7.1 | **Multi-Systems Command Sequencer (MCS)** | 154d? | 2009-07-06 | 2010-02-04 | 2008-07-01 | 2009-02-02 | 155d? | 76d |  |  | 440h | 33,000 | 33,000 |
| 473 | 1.3.7.1.1 | **Setup Sequences: Configuration & Calibration** | 89d? | 2009-07-06 | 2009-11-05 | 2008-07-01 | 2008-10-31 | 89d? | 141d |  |  | 100h | 7,500 | 7,500 |
| 474 | 1.3.7.1.1.1 | **Setup Sequences Common Structure** | 89d? | 2009-07-06 | 2009-11-05 | 2008-07-01 | 2008-10-31 | 89d? | 141d |  |  | 60h | 4,500 | 4,500 |
| 475 | 1.3.7.1.1.1.1 | Setup Sequences Operations Concept Document | 89d? | 2009-07-06 | 2009-11-05 | 2008-07-01 | 2008-10-31 | 89d? | 141d | start no earlier than 2009-07-06 | Johansson [2.8%] | 20h | 1,500 | 1,500 |
| 476 | 1.3.7.1.1.1.2 | Setup Sequences Software Requirements | 89d? | 2009-07-06 | 2009-11-05 | 2008-07-01 | 2008-10-31 | 89d? | 141d | start no earlier than 2009-07-06 | Johansson [2.8%] | 20h | 1,500 | 1,500 |
| 477 | 1.3.7.1.1.1.3 | Setup Sequences Module Definitions | 89d? | 2009-07-06 | 2009-11-05 | 2008-07-01 | 2008-10-31 | 89d? | 141d | start no earlier than 2009-07-06 | Johansson [2.8%] | 20h | 1,500 | 1,500 |
| 478 | 1.3.7.1.1.2 | **Configuration Sequences** | 89d? | 2009-07-06 | 2009-11-05 | 2008-07-01 | 2008-10-31 | 89d? | 141d |  |  | 20h | 1,500 | 1,500 |
| 479 | 1.3.7.1.1.2.1 | Config Sequences Functional Requirements | 89d? | 2009-07-06 | 2009-11-05 | 2008-07-01 | 2008-10-31 | 89d? | 141d | start no earlier than 2009-07-06 | Lyke [2.8%] | 20h | 1,500 | 1,500 |
| 480 | 1.3.7.1.1.2.2 | Interface Definitions | 1d? | 2009-07-06 | 2009-07-06 | 2008-07-01 | 2008-07-01 | 1d? | 229d | start no earlier than 2009-07-06 |  |  |  |  |
| 481 | 1.3.7.1.1.3 | **Calibration Sequences** | 89d? | 2009-07-06 | 2009-11-05 | 2008-07-01 | 2008-10-31 | 89d? | 141d |  |  | 20h | 1,500 | 1,500 |
| 482 | 1.3.7.1.1.3.1 | Calibration Sequences Functional Requirements | 89d? | 2009-07-06 | 2009-11-05 | 2008-07-01 | 2008-10-31 | 89d? | 141d | start no earlier than 2009-07-06 | Lyke [2.8%] | 20h | 1,500 | 1,500 |
| 483 | 1.3.7.1.1.3.2 | Interface Definitions | 1d? | 2009-07-06 | 2009-07-06 | 2008-07-01 | 2008-07-01 | 1d? | 229d | start no earlier than 2009-07-06 |  |  |  |  |
| 484 | 1.3.7.1.2 | **Observing Sequences** | 89d? | 2009-10-05 | 2010-02-04 | 2008-10-01 | 2009-02-02 | 89d? | 76d |  |  | 240h | 18,000 | 18,000 |
| 485 | 1.3.7.1.2.1 | **Observing Sequences Common Structure** | 89d? | 2009-10-05 | 2010-02-04 | 2008-10-01 | 2009-02-02 | 89d? | 76d |  |  | 120h | 9,000 | 9,000 |
| 486 | 1.3.7.1.2.1.1 | Observing Sequences Operations Concept Document | 87d? | 2009-10-05 | 2010-02-02 | 2008-10-01 | 2009-02-02 | 89d? | 78d | start no earlier than 2009-10-05 | Lyke [4.3%]; Johansson [1.4%] | 40h | 3,000 | 3,000 |
| 487 | 1.3.7.1.2.1.2 | Observing Sequences Software Requirements | 89d? | 2009-10-05 | 2010-02-04 | 2008-10-01 | 2009-02-02 | 89d? | 76d | start no earlier than 2009-10-05 | Johansson [5.6%] | 40h | 3,000 | 3,000 |
| 488 | 1.3.7.1.2.1.3 | Observing Sequences Module Definitions | 89d? | 2009-10-05 | 2010-02-04 | 2008-10-01 | 2009-02-02 | 89d? | 76d | start no earlier than 2009-10-05 | Johansson [2.8%]; Lyke [2.8%] | 40h | 3,000 | 3,000 |

Notes:
- 462: EJ
- 465: TS
- 471: JL
- 472: EJ
- 473: EJ
- 484: JL

| ID | WBS | Task | Duration | Start | Finish | Baseline start | Baseline finish | Baseline duration | Total slack | Constraint | Resources | Work | Cost | Baseline cost |
| --- | --- | --- | --- | --- | --- | --- | --- | --- | --- | --- | --- | --- | --- | --- |
| 489 | 1.3.7.1.2.2 | **Acquisition Sequences** | 89d? | 2009-10-05 | 2010-02-04 | 2008-10-01 | 2009-02-02 | 89d? | 76d |  |  | 60h | 4,500 | 4,500 |
| 490 | 1.3.7.1.2.2.1 | Acquisition Sequences Functional Requirements | 89d? | 2009-10-05 | 2010-02-04 | 2008-10-01 | 2009-02-02 | 89d? | 76d | start no earlier than 2009-10-05 | Conrad [4.2%]; Johansson [1.4%] | 40h | 3,000 | 3,000 |
| 491 | 1.3.7.1.2.2.2 | Acquisition Sequences Interface Definitions | 89d? | 2009-10-05 | 2010-02-04 | 2008-10-01 | 2009-02-02 | 89d? | 76d | start no earlier than 2009-10-05 | Johansson [2.8%] | 20h | 1,500 | 1,500 |
| 492 | 1.3.7.1.2.3 | **Observing Sequences** | 89d? | 2009-10-05 | 2010-02-04 | 2008-10-01 | 2009-02-02 | 89d? | 76d |  |  | 20h | 1,500 | 1,500 |
| 493 | 1.3.7.1.2.3.1 | Observing Sequences Functional Requirements | 89d? | 2009-10-05 | 2010-02-04 | 2008-10-01 | 2009-02-02 | 89d? | 76d | start no earlier than 2009-10-05 | Lyke [2.8%] | 20h | 1,500 | 1,500 |
| 494 | 1.3.7.1.2.3.2 | Interface Definitions | 1d? | 2009-10-05 | 2009-10-05 | 2008-10-01 | 2008-10-01 | 1d? | 164d | start no earlier than 2009-10-05 |  |  |  |  |
| 495 | 1.3.7.1.2.4 | **Quality Monitoring Sequences** | 89d? | 2009-10-05 | 2010-02-04 | 2008-10-01 | 2009-02-02 | 89d? | 76d |  |  | 20h | 1,500 | 1,500 |
| 496 | 1.3.7.1.2.4.1 | Quality Monitoring Functional Requirements | 89d? | 2009-10-05 | 2010-02-04 | 2008-10-01 | 2009-02-02 | 89d? | 76d | start no earlier than 2009-10-05 | Conrad [2.8%] | 20h | 1,500 | 1,500 |
| 497 | 1.3.7.1.2.4.2 | Interface Definitions | 1d? | 2009-10-05 | 2009-10-05 | 2008-10-01 | 2008-10-01 | 1d? | 164d | start no earlier than 2009-10-05 |  |  |  |  |
| 498 | 1.3.7.1.2.5 | **Optimization Sequences** | 89d? | 2009-10-05 | 2010-02-04 | 2008-10-01 | 2009-02-02 | 89d? | 76d |  |  | 20h | 1,500 | 1,500 |
| 499 | 1.3.7.1.2.5.1 | Optimization Sequences Functional Requirements | 89d? | 2009-10-05 | 2010-02-04 | 2008-10-01 | 2009-02-02 | 89d? | 76d | start no earlier than 2009-10-05 | Lyke [2.8%] | 20h | 1,500 | 1,500 |
| 500 | 1.3.7.1.2.5.2 | Interface Definitions | 1d? | 2009-10-05 | 2009-10-05 | 2008-10-01 | 2008-10-01 | 1d? | 164d | start no earlier than 2009-10-05 |  |  |  |  |
| 501 | 1.3.7.1.3 | **Alarm Handler & Troubleshooting Sequences** | 89d? | 2009-10-05 | 2010-02-04 | 2008-10-01 | 2009-02-02 | 89d? | 76d |  |  | 100h | 7,500 | 7,500 |
| 502 | 1.3.7.1.3.1 | **Alarm Handler & Troubleshooting Common Structure** | 89d? | 2009-10-05 | 2010-02-04 | 2008-10-01 | 2009-02-02 | 89d? | 76d |  |  | 100h | 7,500 | 7,500 |
| 503 | 1.3.7.1.3.1.1 | Alarm & Troubleshooting Operations Concept Document | 89d? | 2009-10-05 | 2010-02-04 | 2008-10-01 | 2009-02-02 | 89d? | 76d | start no earlier than 2009-10-05 | Lyke [4.2%]; Morrison [1.4%] | 40h | 3,000 | 3,000 |
| 504 | 1.3.7.1.3.1.2 | Alarm & Troubleshooting Software Requirements | 89d? | 2009-10-05 | 2010-02-04 | 2008-10-01 | 2009-02-02 | 89d? | 76d | start no earlier than 2009-10-05 | Morrison [2.8%] | 20h | 1,500 | 1,500 |
| 505 | 1.3.7.1.3.1.3 | Alarm & Troubleshooting Module Definitions | 89d? | 2009-10-05 | 2010-02-04 | 2008-10-01 | 2009-02-02 | 89d? | 76d | start no earlier than 2009-10-05 | Morrison [2.8%]; Lyke [2.8%] | 40h | 3,000 | 3,000 |
| 506 | 1.3.7.1.3.2 | **Alarm Handler Sequences** | 1d? | 2009-10-05 | 2009-10-05 | 2008-10-01 | 2008-10-01 | 1d? | 164d |  |  |  |  |  |
| 507 | 1.3.7.1.3.2.1 | Functional Requirements | 1d? | 2009-10-05 | 2009-10-05 | 2008-10-01 | 2008-10-01 | 1d? | 164d | start no earlier than 2009-10-05 |  |  |  |  |
| 508 | 1.3.7.1.3.2.2 | Interface Definitions | 1d? | 2009-10-05 | 2009-10-05 | 2008-10-01 | 2008-10-01 | 1d? | 164d | start no earlier than 2009-10-05 |  |  |  |  |
| 509 | 1.3.7.1.3.3 | **Troubleshooting Sequences** | 1d? | 2009-10-05 | 2009-10-05 | 2008-10-01 | 2008-10-01 | 1d? | 164d |  |  |  |  |  |
| 510 | 1.3.7.1.3.3.1 | Functional Requirements | 1d? | 2009-10-05 | 2009-10-05 | 2008-10-01 | 2008-10-01 | 1d? | 164d | start no earlier than 2009-10-05 |  |  |  |  |
| 511 | 1.3.7.1.3.3.2 | Interface Definitions | 1d? | 2009-10-05 | 2009-10-05 | 2008-10-01 | 2008-10-01 | 1d? | 164d | start no earlier than 2009-10-05 |  |  |  |  |
| 512 | 1.3.7.2 | **User Interfaces** | 190d? | 2009-07-06 | 2010-03-26 | 2008-07-01 | 2009-05-29 | 239d? | 40d |  |  | 380h | 28,500 | 28,500 |
| 513 | 1.3.7.2.1 | **User Interface (UI) Infrastructure** | 89d? | 2009-07-06 | 2009-11-05 | 2008-07-01 | 2008-10-31 | 89d? | 141d |  |  | 60h | 4,500 | 4,500 |
| 514 | 1.3.7.2.1.1 | **UI Command Interface (CI) to MCS** | 89d? | 2009-07-06 | 2009-11-05 | 2008-07-01 | 2008-10-31 | 89d? | 141d |  |  | 40h | 3,000 | 3,000 |
| 515 | 1.3.7.2.1.1.1 | UI to MCS Functional Requirements | 89d? | 2009-07-06 | 2009-11-05 | 2008-07-01 | 2008-10-31 | 89d? | 141d | start no earlier than 2009-07-06 | Morrison [2.8%] | 20h | 1,500 | 1,500 |
| 516 | 1.3.7.2.1.1.2 | UI to MCS Interface Definitions | 89d? | 2009-07-06 | 2009-11-05 | 2008-07-01 | 2008-10-31 | 89d? | 141d | start no earlier than 2009-07-06 | Morrison [2.8%] | 20h | 1,500 | 1,500 |

Notes:
- 512: JL

| ID | WBS | Task | Duration | Start | Finish | Baseline start | Baseline finish | Baseline duration | Total slack | Constraint | Resources | Work | Cost | Baseline cost |
| --- | --- | --- | --- | --- | --- | --- | --- | --- | --- | --- | --- | --- | --- | --- |
| 517 | 1.3.7.2.1.2 | **UI Command Interface to Pre- & Post-Observing Tools** | 89d? | 2009-07-06 | 2009-11-05 | 2008-07-01 | 2008-10-31 | 89d? | 141d |  |  | 20h | 1,500 | 1,500 |
| 518 | 1.3.7.2.1.2.1 | UI to Pre/Post Obs Tools Functional Requirements | 89d? | 2009-07-06 | 2009-11-05 | 2008-07-01 | 2008-10-31 | 89d? | 141d | start no earlier than 2009-07-06 | Morrison [2.8%] | 20h | 1,500 | 1,500 |
| 519 | 1.3.7.2.1.2.2 | UI to Pre/Post Obs Tools Interface Definitions | 89d? | 2009-07-06 | 2009-11-05 | 2008-07-01 | 2008-10-31 | 89d? | 141d | start no earlier than 2009-07-06 |  |  |  |  |
| 520 | 1.3.7.2.2 | **Setup User Interfaces** | 125d? | 2009-10-05 | 2010-03-26 | 2008-10-01 | 2009-03-31 | 130d? | 40d |  |  | 80h | 6,000 | 6,000 |
| 521 | 1.3.7.2.2.1 | **Setup UI Common Structure** | 125d? | 2009-10-05 | 2010-03-26 | 2008-10-01 | 2009-03-31 | 130d? | 40d |  |  | 50h | 3,750 | 3,750 |
| 522 | 1.3.7.2.2.1.1 | Setup UI Operations Concept Document | 125d? | 2009-10-05 | 2010-03-26 | 2008-10-01 | 2009-03-31 | 130d? | 40d | finish no earlier than 2010-03-26 | Lyke [2%] | 20h | 1,500 | 1,500 |
| 523 | 1.3.7.2.2.1.2 | Setup UI Software Requirements | 125d? | 2009-10-05 | 2010-03-26 | 2008-10-01 | 2009-03-31 | 130d? | 40d | finish no earlier than 2010-03-26 | Morrison [1%] | 10h | 750 | 750 |
| 524 | 1.3.7.2.2.1.3 | Setup UI Module Definitions | 125d? | 2009-10-05 | 2010-03-26 | 2008-10-01 | 2009-03-31 | 130d? | 40d | finish no earlier than 2010-03-26 | Morrison [2%] | 20h | 1,500 | 1,500 |
| 525 | 1.3.7.2.2.2 | **Setup UI Configurations** | 125d? | 2009-10-05 | 2010-03-26 | 2008-10-01 | 2009-03-31 | 130d? | 40d |  |  | 15h | 1,125 | 1,125 |
| 526 | 1.3.7.2.2.2.1 | Setup UI Config Functional Requirements | 125d? | 2009-10-05 | 2010-03-26 | 2008-10-01 | 2009-03-31 | 130d? | 40d | finish no earlier than 2010-03-26 | Lyke [1.5%] | 15h | 1,125 | 1,125 |
| 527 | 1.3.7.2.2.2.2 | Setup UI Config Interface Definitions | 125d? | 2009-10-05 | 2010-03-26 | 2008-10-01 | 2009-03-31 | 130d? | 40d | finish no earlier than 2010-03-26 |  |  |  |  |
| 528 | 1.3.7.2.2.3 | **Setup UI Calibrations** | 125d? | 2009-10-05 | 2010-03-26 | 2008-10-01 | 2009-03-31 | 130d? | 40d |  |  | 15h | 1,125 | 1,125 |
| 529 | 1.3.7.2.2.3.1 | Setup UI Calib Functional Requirements | 125d? | 2009-10-05 | 2010-03-26 | 2008-10-01 | 2009-03-31 | 130d? | 40d | finish no earlier than 2010-03-26 | Lyke [1.5%] | 15h | 1,125 | 1,125 |
| 530 | 1.3.7.2.2.3.2 | Setup UI Calib Interface Definitions | 125d? | 2009-10-05 | 2010-03-26 | 2008-10-01 | 2009-03-31 | 130d? | 40d | finish no earlier than 2010-03-26 |  |  |  |  |
| 531 | 1.3.7.2.3 | **Observations User Interfaces** | 125d? | 2009-10-05 | 2010-03-26 | 2008-10-01 | 2009-05-29 | 173d? | 40d |  |  | 240h | 18,000 | 18,000 |
| 532 | 1.3.7.2.3.1 | **Observations UI Common Structure** | 125d? | 2009-10-05 | 2010-03-26 | 2008-10-01 | 2009-05-29 | 173d? | 40d |  |  | 130h | 9,750 | 9,750 |
| 533 | 1.3.7.2.3.1.1 | Observations UI Operations Concept Document | 125d? | 2009-10-05 | 2010-03-26 | 2008-10-01 | 2009-05-29 | 173d? | 40d | finish no earlier than 2010-03-26 | Lyke [3%]; Morrison | 40h | 3,000 | 3,000 |
| 534 | 1.3.7.2.3.1.2 | Observations UI Software Requirements | 125d? | 2009-10-05 | 2010-03-26 | 2008-10-01 | 2009-05-29 | 173d? | 40d | finish no earlier than 2010-03-26 | Morrison [1%] | 10h | 750 | 750 |
| 535 | 1.3.7.2.3.1.3 | Observations UI Module Definitions | 125d? | 2009-10-05 | 2010-03-26 | 2008-10-01 | 2009-05-29 | 173d? | 40d | finish no earlier than 2010-03-26 | Morrison [4%]; Lyke [4%] | 80h | 6,000 | 6,000 |
| 536 | 1.3.7.2.3.2 | **Acquisition & AO Control UI** | 125d? | 2009-10-05 | 2010-03-26 | 2008-10-01 | 2009-05-29 | 173d? | 40d |  |  | 30h | 2,250 | 2,250 |
| 537 | 1.3.7.2.3.2.1 | Acq/AO Control UI Functional Requirements | 125d? | 2009-10-05 | 2010-03-26 | 2008-10-01 | 2009-05-29 | 173d? | 40d | finish no earlier than 2010-03-26 | Kwok [2%] | 20h | 1,500 | 1,500 |
| 538 | 1.3.7.2.3.2.2 | Acq/AO Control UI Interface Definitions | 125d? | 2009-10-05 | 2010-03-26 | 2008-10-01 | 2009-05-29 | 173d? | 40d | finish no earlier than 2010-03-26 | Morrison [1%] | 10h | 750 | 750 |
| 539 | 1.3.7.2.3.3 | **Observing Sequences UI** | 125d? | 2009-10-05 | 2010-03-26 | 2008-10-01 | 2009-05-29 | 173d? | 40d |  |  | 20h | 1,500 | 1,500 |
| 540 | 1.3.7.2.3.3.1 | Obs Seq UI Functional Requirements | 125d? | 2009-10-05 | 2010-03-26 | 2008-10-01 | 2009-05-29 | 173d? | 40d | finish no earlier than 2010-03-26 | Lyke [2%] | 20h | 1,500 | 1,500 |
| 541 | 1.3.7.2.3.3.2 | Obs Seq UI Interface Definitions | 125d? | 2009-10-05 | 2010-03-26 | 2008-10-01 | 2009-05-29 | 173d? | 40d | finish no earlier than 2010-03-26 |  |  |  |  |

Notes:
- 520: JL
- 531: JL
- 539: JL

| ID | WBS | Task | Duration | Start | Finish | Baseline start | Baseline finish | Baseline duration | Total slack | Constraint | Resources | Work | Cost | Baseline cost |
| --- | --- | --- | --- | --- | --- | --- | --- | --- | --- | --- | --- | --- | --- | --- |
| 542 | 1.3.7.2.3.4 | **Status & Graph UI** | 125d? | 2009-10-05 | 2010-03-26 | 2008-10-01 | 2009-05-29 | 173d? | 40d |  |  | 20h | 1,500 | 1,500 |
| 543 | 1.3.7.2.3.4.1 | Status & Graph UI Functional Requirements | 125d? | 2009-10-05 | 2010-03-26 | 2008-10-01 | 2009-05-29 | 173d? | 40d | finish no earlier than 2010-03-26 | Conrad [2%] | 20h | 1,500 | 1,500 |
| 544 | 1.3.7.2.3.4.2 | Status & Graph UI Interface Definitions | 125d? | 2009-10-05 | 2010-03-26 | 2008-10-01 | 2009-05-29 | 173d? | 40d | finish no earlier than 2010-03-26 |  |  |  |  |
| 545 | 1.3.7.2.3.5 | **Advanced Monitoring UI** | 125d? | 2009-10-05 | 2010-03-26 | 2008-10-01 | 2009-05-29 | 173d? | 40d |  |  | 20h | 1,500 | 1,500 |
| 546 | 1.3.7.2.3.5.1 | Adv Monitoring UI Functional Requirements | 125d? | 2009-10-05 | 2010-03-26 | 2008-10-01 | 2009-05-29 | 173d? | 40d | finish no earlier than 2010-03-26 | Lyke [2%] | 20h | 1,500 | 1,500 |
| 547 | 1.3.7.2.3.5.2 | Adv Monitoring UI Interface Definitions | 125d? | 2009-10-05 | 2010-03-26 | 2008-10-01 | 2009-05-29 | 173d? | 40d | finish no earlier than 2010-03-26 |  |  |  |  |
| 548 | 1.3.7.2.3.6 | **Optimization & Troubleshooting UI** | 125d? | 2009-10-05 | 2010-03-26 | 2008-10-01 | 2009-05-29 | 173d? | 40d |  |  | 20h | 1,500 | 1,500 |
| 549 | 1.3.7.2.3.6.1 | Opt & Trouble UI Functional Requirements | 125d? | 2009-10-05 | 2010-03-26 | 2008-10-01 | 2009-05-29 | 173d? | 40d | finish no earlier than 2010-03-26 | Lyke [2%] | 20h | 1,500 | 1,500 |
| 550 | 1.3.7.2.3.6.2 | Opt & Trouble UI Interface Definitions | 125d? | 2009-10-05 | 2010-03-26 | 2008-10-01 | 2009-05-29 | 173d? | 40d | finish no earlier than 2010-03-26 |  |  |  |  |
| 551 | 1.3.7.3 | **Pre- & Post-Observing Science Support Tools** | 148d? | 2009-09-01 | 2010-03-25 | 2009-01-01 | 2009-10-30 | 217d? | 41d |  |  | 610h | 45,750 | 45,750 |
| 552 | 1.3.7.3.1 | **User Documentation** | 148d? | 2009-09-01 | 2010-03-25 | 2009-01-01 | 2009-09-01 | 174d? | 41d |  |  | 20h | 1,500 | 1,500 |
| 553 | 1.3.7.3.1.1 | User Documentation Operations Concept | 148d? | 2009-09-01 | 2010-03-25 | 2009-01-01 | 2009-09-01 | 174d? | 41d | finish no earlier than 2010-03-25 | Lyke [0.8%] | 10h | 750 | 750 |
| 554 | 1.3.7.3.1.2 | User Documentation Functional Requirements | 148d? | 2009-09-01 | 2010-03-25 | 2009-01-01 | 2009-09-01 | 174d? | 41d | finish no earlier than 2010-03-25 | Lyke [0.8%] | 10h | 750 | 750 |
| 555 | 1.3.7.3.2 | **Science Observations Planning Tools** | 148d? | 2009-09-01 | 2010-03-25 | 2009-01-07 | 2009-07-31 | 148d? | 41d |  |  | 340h | 25,500 | 25,500 |
| 556 | 1.3.7.3.2.1 | **NGS Star Finder** | 148d? | 2009-09-01 | 2010-03-25 | 2009-01-07 | 2009-07-31 | 148d? | 41d |  |  | 60h | 4,500 | 4,500 |
| 557 | 1.3.7.3.2.1.1 | NGS Star Finder Operations Concept | 148d? | 2009-09-01 | 2010-03-25 | 2009-01-07 | 2009-07-31 | 148d? | 41d | start no earlier than 2009-09-01 | Conrad [1.7%] | 20h | 1,500 | 1,500 |
| 558 | 1.3.7.3.2.1.2 | NGS Star Finder Functional Requirements & Use Case Definitions | 148d? | 2009-09-01 | 2010-03-25 | 2009-01-07 | 2009-07-31 | 148d? | 41d | start no earlier than 2009-09-01 | Conrad [3.4%] | 40h | 3,000 | 3,000 |
| 559 | 1.3.7.3.2.1.3 | Interface Definitions | 148d? | 2009-09-01 | 2010-03-25 | 2009-01-07 | 2009-07-31 | 148d? | 41d | start no earlier than 2009-09-01 |  |  |  |  |
| 560 | 1.3.7.3.2.1.4 | Module Definitions | 148d? | 2009-09-01 | 2010-03-25 | 2009-01-07 | 2009-07-31 | 148d? | 41d | start no earlier than 2009-09-01 |  |  |  |  |
| 561 | 1.3.7.3.2.2 | **Performance Prediction Tool** | 148d? | 2009-09-01 | 2010-03-25 | 2009-01-07 | 2009-07-31 | 148d? | 41d |  |  | 140h | 10,500 | 10,500 |
| 562 | 1.3.7.3.2.2.1 | Performance Prediction Operations Concept | 148d? | 2009-09-01 | 2010-03-25 | 2009-01-07 | 2009-07-31 | 148d? | 41d | start no earlier than 2009-09-01 | Stalcup [3.4%] | 40h | 3,000 | 3,000 |
| 563 | 1.3.7.3.2.2.2 | Performance Prediction Functional Requirements & Use Case Definitions | 148d? | 2009-09-01 | 2010-03-25 | 2009-01-07 | 2009-07-31 | 148d? | 41d | start no earlier than 2009-09-01 | Stalcup [3.4%] | 40h | 3,000 | 3,000 |
| 564 | 1.3.7.3.2.2.3 | Performance Prediction Interface Definitions | 148d? | 2009-09-01 | 2010-03-25 | 2009-01-07 | 2009-07-31 | 148d? | 41d | start no earlier than 2009-09-01 | Morrison [1.7%] | 20h | 1,500 | 1,500 |
| 565 | 1.3.7.3.2.2.4 | Performance Predictions Module Definitions | 148d? | 2009-09-01 | 2010-03-25 | 2009-01-07 | 2009-07-31 | 148d? | 41d | start no earlier than 2009-09-01 | Morrison [1.7%]; Stalcup [1.7%] | 40h | 3,000 | 3,000 |

Notes:
- 542: AC
- 545: JL
- 548: JL
- 551: JL
- 552: JL
- 555: AC
- 556: AC
- 561: TS

| ID | WBS | Task | Duration | Start | Finish | Baseline start | Baseline finish | Baseline duration | Total slack | Constraint | Resources | Work | Cost | Baseline cost |
| --- | --- | --- | --- | --- | --- | --- | --- | --- | --- | --- | --- | --- | --- | --- |
| 566 | 1.3.7.3.2.3 | **Observation Planning & Efficiency Tool** | 148d? | 2009-09-01 | 2010-03-25 | 2009-01-07 | 2009-07-31 | 148d? | 41d |  |  | 140h | 10,500 | 10,500 |
| 567 | 1.3.7.3.2.3.1 | Observing Planning & Efficiency Tool Operations Concept | 148d? | 2009-09-01 | 2010-03-25 | 2009-01-07 | 2009-07-31 | 148d? | 41d | start no earlier than 2009-09-01 | Conrad [3.4%] | 40h | 3,000 | 3,000 |
| 568 | 1.3.7.3.2.3.2 | Observing Planning & Efficiency Tool Functional Requirements & Use Case Definitions | 148d? | 2009-09-01 | 2010-03-25 | 2009-01-07 | 2009-07-31 | 148d? | 41d | start no earlier than 2009-09-01 | Conrad [3.4%] | 40h | 3,000 | 3,000 |
| 569 | 1.3.7.3.2.3.3 | Observing Planning & Efficiency Tool Interface Definitions | 148d? | 2009-09-01 | 2010-03-25 | 2009-01-07 | 2009-07-31 | 148d? | 41d | start no earlier than 2009-09-01 | Morrison [1.7%] | 20h | 1,500 | 1,500 |
| 570 | 1.3.7.3.2.3.4 | Observing Planning & Efficiency Tool Module Definitions | 148d? | 2009-09-01 | 2010-03-25 | 2009-01-07 | 2009-07-31 | 148d? | 41d | start no earlier than 2009-09-01 | Morrison [1.7%]; Conrad [1.7%] | 40h | 3,000 | 3,000 |
| 571 | 1.3.7.3.2.4 | **Laser Clearinghouse Coordination Tool** | 148d? | 2009-09-01 | 2010-03-25 | 2009-01-07 | 2009-07-31 | 148d? | 41d |  |  |  |  |  |
| 572 | 1.3.7.3.2.4.1 | Operations Concept | 148d? | 2009-09-01 | 2010-03-25 | 2009-01-07 | 2009-07-31 | 148d? | 41d | start no earlier than 2009-09-01 |  |  |  |  |
| 573 | 1.3.7.3.2.4.2 | Functional Requirements & Use Case Definitions | 148d? | 2009-09-01 | 2010-03-25 | 2009-01-07 | 2009-07-31 | 148d? | 41d | start no earlier than 2009-09-01 |  |  |  |  |
| 574 | 1.3.7.3.2.4.3 | Interface Definitions | 148d? | 2009-09-01 | 2010-03-25 | 2009-01-07 | 2009-07-31 | 148d? | 41d | start no earlier than 2009-09-01 |  |  |  |  |
| 575 | 1.3.7.3.2.4.4 | Module Definitions | 148d? | 2009-09-01 | 2010-03-25 | 2009-01-07 | 2009-07-31 | 148d? | 41d | start no earlier than 2009-09-01 |  |  |  |  |
| 576 | 1.3.7.3.3 | **Data Products** | 126d? | 2009-10-01 | 2010-03-25 | 2009-02-02 | 2009-10-30 | 195d? | 41d |  |  | 250h | 18,750 | 18,750 |
| 577 | 1.3.7.3.3.1 | **Generic Data Products** | 126d? | 2009-10-01 | 2010-03-25 | 2009-02-02 | 2009-09-01 | 152d? | 41d |  |  | 80h | 6,000 | 6,000 |
| 578 | 1.3.7.3.3.1.1 | Generic Data Operations Concept | 126d? | 2009-10-01 | 2010-03-25 | 2009-02-02 | 2009-09-01 | 152d? | 41d | finish no earlier than 2010-03-25 | Conrad [2%] | 20h | 1,500 | 1,500 |
| 579 | 1.3.7.3.3.1.2 | Generic Data Functional Requirements & Use Case Definitions | 126d? | 2009-10-01 | 2010-03-25 | 2009-02-02 | 2009-09-01 | 152d? | 41d | finish no earlier than 2010-03-25 | Conrad [4%] | 40h | 3,000 | 3,000 |
| 580 | 1.3.7.3.3.1.3 | Generic Data Interface Definitions | 126d? | 2009-10-01 | 2010-03-25 | 2009-02-02 | 2009-09-01 | 152d? | 41d | finish no earlier than 2010-03-25 | Morrison [2%] | 20h | 1,500 | 1,500 |
| 581 | 1.3.7.3.3.2 | **Science Data Quality Assessment** | 126d? | 2009-10-01 | 2010-03-25 | 2009-02-02 | 2009-10-30 | 195d? | 41d |  |  | 160h | 12,000 | 12,000 |
| 582 | 1.3.7.3.3.2.1 | **Quality Metrics & Logged Information** | 126d? | 2009-10-01 | 2010-03-25 | 2009-02-02 | 2009-09-01 | 152d? | 41d |  |  | 80h | 6,000 | 6,000 |
| 583 | 1.3.7.3.3.2.1.1 | Quality Metrics Operations Concept | 126d? | 2009-10-01 | 2010-03-25 | 2009-02-02 | 2009-09-01 | 152d? | 41d | finish no earlier than 2010-03-25 | Conrad [4%] | 40h | 3,000 | 3,000 |
| 584 | 1.3.7.3.3.2.1.2 | Quality Metrics Functional Requirements & Use Case Definitions | 126d? | 2009-10-01 | 2010-03-25 | 2009-02-02 | 2009-09-01 | 152d? | 41d | finish no earlier than 2010-03-25 | Kwok [4%] | 40h | 3,000 | 3,000 |
| 585 | 1.3.7.3.3.2.1.3 | Interface Definitions | 126d? | 2009-10-01 | 2010-03-25 | 2009-02-02 | 2009-09-01 | 152d? | 41d | finish no earlier than 2010-03-25 |  |  |  |  |
| 586 | 1.3.7.3.3.2.2 | **PSF Calibration** | 126d? | 2009-10-01 | 2010-03-25 | 2009-02-02 | 2009-10-30 | 195d? | 41d |  |  | 80h | 6,000 | 6,000 |
| 587 | 1.3.7.3.3.2.2.1 | PSF Calibration Operations Concept | 126d? | 2009-10-01 | 2010-03-25 | 2009-02-02 | 2009-10-30 | 195d? | 41d | finish no earlier than 2010-03-25 | Kwok [4%] | 40h | 3,000 | 3,000 |
| 588 | 1.3.7.3.3.2.2.2 | PSF Calibration Functional Requirements & Use Case Definitions | 126d? | 2009-10-01 | 2010-03-25 | 2009-02-02 | 2009-10-30 | 195d? | 41d | finish no earlier than 2010-03-25 | Kwok [4%] | 40h | 3,000 | 3,000 |
| 589 | 1.3.7.3.3.2.2.3 | Interface Definitions | 126d? | 2009-10-01 | 2010-03-25 | 2009-02-02 | 2009-10-30 | 195d? | 41d | finish no earlier than 2010-03-25 |  |  |  |  |
| 590 | 1.3.7.3.3.2.2.4 | Module Definitions | 126d? | 2009-10-01 | 2010-03-25 | 2009-02-02 | 2009-10-30 | 195d? | 41d | finish no earlier than 2010-03-25 |  |  |  |  |

Notes:
- 566: AC
- 576: AC
- 577: AC
- 581: AC
- 582: AC
- 586: SK

| ID | WBS | Task | Type | Duration | Start | Finish | Complete | Remaining | Baseline start | Baseline finish | Baseline duration | Total slack | Constraint | Resources | Work | Actual work | Cost | Baseline cost | Actual cost |
| --- | --- | --- | --- | --- | --- | --- | --- | --- | --- | --- | --- | --- | --- | --- | --- | --- | --- | --- | --- |
| 591 | 1.3.7.3.3.3 | **Science Data Archiving** |  | 126d? | 2009-10-01 | 2010-03-25 |  |  | 2009-02-02 | 2009-10-30 | 195d? | 41d |  |  | 10h |  | 750 | 750 |  |
| 592 | 1.3.7.3.3.3.1 | Science Data Operations Concept |  | 126d? | 2009-10-01 | 2010-03-25 |  |  | 2009-02-02 | 2009-10-30 | 195d? | 41d | finish no earlier than 2010-03-25 | Lyke [1%] | 10h |  | 750 | 750 |  |
| 593 | 1.3.7.3.3.3.2 | Functional Requirements & Use Case Definitions |  | 126d? | 2009-10-01 | 2010-03-25 |  |  | 2009-02-02 | 2009-10-30 | 195d? | 41d | finish no earlier than 2010-03-25 |  |  |  |  |  |  |
| 594 | 1.3.7.3.3.3.3 | Interface Definitions |  | 126d? | 2009-10-01 | 2010-03-25 |  |  | 2009-02-02 | 2009-10-30 | 195d? | 41d | finish no earlier than 2010-03-25 |  |  |  |  |  |  |
| 595 | 1.3.7.4 | **Data Server** |  | 107d? | 2009-10-01 | 2010-02-26 |  |  | 2009-02-02 | 2009-10-30 | 195d? | 60d |  |  | 70h |  | 5,250 | 5,250 |  |
| 596 | 1.3.7.4.1 | Data Server: Architecture |  | 107d? | 2009-10-01 | 2010-02-26 |  |  | 2009-02-02 | 2009-10-30 | 195d? | 60d | finish no earlier than 2010-02-26 | Johnson [2.8%]; Morrison [1.9%] | 40h |  | 3,000 | 3,000 |  |
| 597 | 1.3.7.4.2 | Data Server: HW & SW Specification & Selection |  | 107d? | 2009-10-01 | 2010-02-26 |  |  | 2009-02-02 | 2009-10-30 | 195d? | 60d | finish no earlier than 2010-02-26 | Johnson [1.4%]; Morrison [0.9%] | 20h |  | 1,500 | 1,500 |  |
| 598 | 1.3.7.4.3 | Data Server: Software Design | milestone | 0d? | 2009-10-01 | 2009-10-01 |  |  | 2009-02-02 | 2009-02-02 | 0d? | 167d | start no earlier than 2009-10-01 |  |  |  |  |  |  |
| 599 | 1.3.7.4.4 | Data Server: Compliance Matrix | milestone | 0d? | 2009-10-01 | 2009-10-01 |  |  | 2009-02-02 | 2009-02-02 | 0d? | 167d | start no earlier than 2009-10-01 |  |  |  |  |  |  |
| 600 | 1.3.7.4.5 | Data Server: Test Plan | milestone | 0d? | 2009-10-01 | 2009-10-01 |  |  | 2009-02-02 | 2009-02-02 | 0d? | 167d | start no earlier than 2009-10-01 |  |  |  |  |  |  |
| 601 | 1.3.7.4.6 | Data Server: Summary Report |  | 107d? | 2009-10-01 | 2010-02-26 |  |  | 2009-02-02 | 2009-10-30 | 195d? | 60d | finish no earlier than 2010-02-26 | Johnson [0.7%]; Morrison [0.5%] | 10h |  | 750 | 750 |  |
| 602 | 1.3.8 | **Telescope & Summit Engineering Design** |  | 200d? | 2009-05-04 A | 2010-02-05 | 3% | 194.06d? | 2008-12-08 | 2009-10-02 | 215d? | 75d |  |  | 976h | 29.25h | 72,600 | 82,575 | 2,193.75 |
| 603 | 1.3.8.1 | Telescope Performance |  | 1d? | 2009-05-04 | 2009-05-04 |  |  | 2009-05-04 | 2009-05-04 | 1d? | 274d | start no earlier than 2009-05-04 |  |  |  |  |  |  |
| 604 | 1.3.8.2 | **Infrastructure Modifications for AO** |  | 165d? | 2009-06-08 A | 2010-01-22 | 2% | 161.95d? | 2009-05-04 | 2009-10-02 | 110d? | 85d |  |  | 650h | 18h | 48,750 | 49,500 | 1,350 |
| 605 | 1.3.8.2.1 | AO Infrastructure Requirements & Interfaces |  | 20d? | 2009-06-08 A | 2009-07-03 | 20% | 16d? | 2009-05-04 | 2009-05-29 | 20d? | 230d | start no earlier than 2009-06-08 | Bell [37.5%]; Wetherell [18.8%] | 90h | 18h | 6,750 | 6,750 | 1,350 |
| 606 | 1.3.8.2.2 | AO Infrastructure Mechanical Modifications |  | 40d? | 2009-07-06 | 2009-08-28 |  |  | 2009-06-01 | 2009-07-31 | 45d? | 190d | finish no earlier than 2009-08-28 | Bell; Medeiros [37.5%]; Mogensen | 160h |  | 12,000 | 12,000 |  |
| 607 | 1.3.8.2.3 | AO Infrastructure Electrical Modifications |  | 41.25d? | 2009-10-05 | 2009-12-01 |  |  | 2009-07-06 | 2009-09-04 | 45d? | 123.75d | start no earlier than 2009-10-05 | Devenot [33.3%] | 110h |  | 8,250 | 9,000 |  |
| 608 | 1.3.8.2.4 | AO Infrastructure Glycol Cooling Modifications |  | 45d? | 2009-10-19 | 2009-12-18 |  |  | 2009-07-13 | 2009-09-11 | 45d? | 110d | start no earlier than 2009-10-19 | Nance [5.6%]; Bell [22.2%]; Medeiros [11.1%] | 140h |  | 10,500 | 10,500 |  |
| 609 | 1.3.8.2.5 | AO Infrastructure CCR Modifications |  | 45d? | 2009-10-19 | 2009-12-18 |  |  | 2009-07-13 | 2009-09-11 | 45d? | 110d | start no earlier than 2009-10-19 | Bell [11.1%] | 40h |  | 3,000 | 3,000 |  |
| 610 | 1.3.8.2.6 | AO Infrastructure Implementation & Test Plans |  | 25d? | 2009-12-21 | 2010-01-22 |  |  | 2009-08-31 | 2009-10-02 | 25d? | 85d | start no earlier than 2009-12-21 | Bell [25%]; Medeiros [15%]; Nance [10%]; Wetherell [5%] | 110h |  | 8,250 | 8,250 |  |
| 611 | 1.3.8.3 | **Infrastructure modifications for LGSF** |  | 200d? | 2009-05-04 | 2010-02-05 |  |  | 2009-05-04 | 2009-10-02 | 110d? | 75d |  |  | 265h |  | 19,875 | 21,000 |  |
| 612 | 1.3.8.3.1 | LGSF Infrastructure Requirements & Interfaces |  | 20d? | 2009-05-04 | 2009-05-29 |  |  | 2009-05-04 | 2009-05-29 | 20d? | 255d | finish no earlier than 2009-05-29 | Bell [25%]; Chin [12.5%]; Nance [1.9%] | 63h |  | 4,725 | 5,250 |  |
| 613 | 1.3.8.3.2 | LGSF Infrastructure Mechanical Modifications |  | 41d? | 2009-07-03 | 2009-08-28 |  |  | 2009-06-29 | 2009-08-28 | 45d? | 190d | start no earlier than 2009-07-03 | Medeiros [7.6%]; Mogensen [6.1%] | 45h |  | 3,375 | 3,750 |  |
| 614 | 1.3.8.3.3 | LGSF Infrastructure Electrical Modifications |  | 45d? | 2009-12-07 | 2010-02-05 |  |  | 2009-07-06 | 2009-09-04 | 45d? | 75d | start no earlier than 2009-12-07 | Devenot [11.1%] | 40h |  | 3,000 | 3,000 |  |
| 615 | 1.3.8.3.4 | LGSF Infrastructure Glycol Cooling Modifications |  | 45d? | 2009-07-13 | 2009-09-11 |  |  | 2009-07-13 | 2009-09-11 | 45d? | 180d | finish no earlier than 2009-09-11 | Bell [13.9%] | 50h |  | 3,750 | 3,750 |  |
| 616 | 1.3.8.3.5 | LGSF Infrastructure Implementation & Test Plans |  | 23.12d? | 2009-09-01 | 2009-10-02 |  |  | 2009-08-31 | 2009-10-02 | 25d? | 165d | finish no earlier than 2009-10-02 | Bell [20%]; Chin; Medeiros [10.8%] | 67h |  | 5,025 | 5,250 |  |

Notes:
- 591: JL
- 595: JJ
- 602: CN
- 604: JB
- 605: JB
- 606: DM
- 607: MD
- 608: JB
- 609: JB
- 610: JB
- 611: JB
- 612: JB
- 613: DM
- 614: MD
- 615: JB
- 616: JB

| ID | WBS | Task | Duration | Start | Finish | Complete | Remaining | Baseline start | Baseline finish | Baseline duration | Total slack | Constraint | Resources | Work | Actual work | Cost | Baseline cost | Actual cost |
| --- | --- | --- | --- | --- | --- | --- | --- | --- | --- | --- | --- | --- | --- | --- | --- | --- | --- | --- |
| 617 | 1.3.8.4 | **Interferometer Modifications** | 40d? | 2009-07-01 A | 2009-08-25 | 13% | 35d? | 2008-12-08 | 2009-01-30 | 40d? | 193d |  |  | 61h | 11.25h | 3,975 | 4,575 | 843.75 |
| 618 | 1.3.8.4.1 | Optical Design of Post Field Selector Optics | 40d? | 2009-07-01 A | 2009-08-25 | 25% | 30d? | 2008-12-08 | 2009-01-30 | 40d? | 193d | start no earlier than 2009-07-01 | Neyman [4.7%]; Kupke [9.4%] | 45h | 11.25h | 3,375 | 3,375 | 843.75 |
| 619 | 1.3.8.4.2 | Evaluation of Optical Design Impact on Interferometer | 40d? | 2009-07-01 | 2009-08-25 |  |  | 2008-12-08 | 2009-01-30 | 40d? | 193d | start no earlier than 2009-07-01 | Neyman [2.5%]; Ragland [2.5%] | 16h |  | 600 | 1,200 |  |
| 620 | 1.3.9 | **Telescope Integration & Test** | 85d? | 2009-10-05 A | 2010-01-29 | 8% | 78.1d? | 2009-10-05 | 2009-12-18 | 55d? | 80d |  |  | 571h | 21.6h | 42,825 | 46,650 | 1,620 |
| 621 | 1.3.9.1 | **Old AO/Laser Removal** | 30d? | 2009-10-05 A | 2009-11-13 | 48% | 15.71d? | 2009-10-05 | 2009-10-30 | 20d? | 135d |  |  | 84h | 21.6h | 6,300 | 9,000 | 1,620 |
| 622 | 1.3.9.1.1 | AO Removal Plan | 26.67d? | 2009-10-05 | 2009-11-10 |  |  | 2009-10-05 | 2009-10-30 | 20d? | 138.33d | start no earlier than 2009-10-05 | Bell [15%]; Wetherell [7.5%]; Chin [1.9%]; Doyle [3.8%] | 60h |  | 4,500 | 4,500 |  |
| 623 | 1.3.9.1.2 | Laser Removal Plan | 30d? | 2009-10-05 A | 2009-11-13 | 90% | 3d? | 2009-10-05 | 2009-10-30 | 20d? | 135d | start no earlier than 2009-10-05 | Chin [5%]; Bell [3.3%]; Grace [1.7%] | 24h | 21.6h | 1,800 | 4,500 | 1,620 |
| 624 | 1.3.9.2 | Laser Enclosure Integration | 1d? | 2009-10-05 | 2009-10-05 |  |  | 2009-10-05 | 2009-10-05 | 1d? | 164d | start no earlier than 2009-10-05 |  |  |  |  |  |  |
| 625 | 1.3.9.3 | AO Enclosure Integration | 1d? | 2009-10-05 | 2009-10-05 |  |  | 2009-10-05 | 2009-10-05 | 1d? | 164d | start no earlier than 2009-10-05 |  |  |  |  |  |  |
| 626 | 1.3.9.4 | **AO System Install + I&T** | 35d? | 2009-11-02 | 2009-12-18 |  |  | 2009-11-02 | 2009-12-18 | 35d? | 110d |  |  | 170h |  | 12,750 | 12,750 |  |
| 627 | 1.3.9.4.1 | Opto-Mechanical Integration Plan | 27d? | 2009-11-02 | 2009-12-08 |  |  | 2009-11-02 | 2009-12-08 | 27d? | 118d | start no earlier than 2009-11-02 | Chin [1.9%]; Bell [16.7%]; Neyman [9.3%] | 60h |  | 4,500 | 4,500 |  |
| 628 | 1.3.9.4.2 | Electronics Integration Plan | 35d? | 2009-11-02 | 2009-12-18 |  |  | 2009-11-02 | 2009-12-18 | 35d? | 110d | start no earlier than 2009-11-02 | Wetherell [14.3%] | 40h |  | 3,000 | 3,000 |  |
| 629 | 1.3.9.4.3 | Computer Integration Plan | 35d? | 2009-11-02 | 2009-12-18 |  |  | 2009-11-02 | 2009-12-18 | 35d? | 110d | start no earlier than 2009-11-02 | Chock [7.1%] | 20h |  | 1,500 | 1,500 |  |
| 630 | 1.3.9.4.4 | AO System Integration Plan | 35d? | 2009-11-02 | 2009-12-18 |  |  | 2009-11-02 | 2009-12-18 | 35d? | 110d | start no earlier than 2009-11-02 | Neyman [14.3%] | 40h |  | 3,000 | 3,000 |  |
| 631 | 1.3.9.4.5 | AO System Test Plan | 35d? | 2009-11-02 | 2009-12-18 |  |  | 2009-11-02 | 2009-12-18 | 35d? | 110d | start no earlier than 2009-11-02 | Neyman [3.6%] | 10h |  | 750 | 750 |  |
| 632 | 1.3.9.5 | **Laser System Install + I&T** | 40.83d? | 2009-10-23 | 2009-12-18 |  |  | 2009-11-02 | 2009-12-18 | 35d? | 110d |  |  | 197h |  | 14,775 | 15,900 |  |
| 633 | 1.3.9.5.1 | LGSF Installation & Integration Plan | 40.83d? | 2009-10-23 | 2009-12-18 |  |  | 2009-11-02 | 2009-12-18 | 35d? | 110d | finish no earlier than 2009-12-18 | Chin [20.8%]; Nance [6.1%]; Medeiros [6.1%]; Wetherell [6.1%]; Stalcup [1.5%] | 133h |  | 9,975 | 11,100 |  |
| 634 | 1.3.9.5.2 | LGSF System Test Plan | 35d? | 2009-11-02 | 2009-12-18 |  |  | 2009-11-02 | 2009-12-18 | 35d? | 110d | start no earlier than 2009-11-02 | Stalcup [14.3%]; Wetherell [1.4%]; Johansson [2.9%]; Chin [4.3%] | 64h |  | 4,800 | 4,800 |  |
| 635 | 1.3.9.6 | LGS AO System On-sky I&T Plan | 10d? | 2010-01-04 | 2010-01-15 |  |  | 2009-11-02 | 2009-11-13 | 10d? | 90d | start no earlier than 2010-01-04 | Lyke [25%]; Bouchez [25%] | 40h |  | 3,000 | 3,000 |  |
| 636 | 1.3.9.7 | Performance Characterization | 1d? | 2010-01-04 | 2010-01-04 |  |  | 2009-11-02 | 2009-11-02 | 1d? | 99d | start no earlier than 2010-01-04 |  |  |  |  |  |  |
| 637 | 1.3.9.8 | Science Verification Plan | 20d? | 2010-01-04 | 2010-01-29 |  |  | 2009-11-02 | 2009-11-27 | 20d? | 80d | start no earlier than 2010-01-04 | Lyke [25%]; Bouchez [25%] | 80h |  | 6,000 | 6,000 |  |
| 638 | 1.3.10 | **Operations Transition** | 227d? | 2009-05-01 A | 2010-03-15 | 13% | 196.82d? | 2009-01-09 | 2009-11-30 | 232d? | 49d |  |  | 166h | 36.5h | 12,450 | 12,450 | 2,737.5 |
| 639 | 1.3.10.1 | **Operations Plans** | 140d? | 2009-09-01 A | 2010-03-15 | 11% | 124.61d? | 2009-09-01 | 2009-11-30 | 65d? | 49d |  |  | 88h | 14h | 6,600 | 7,200 | 1,050 |
| 640 | 1.3.10.1.1 | Operations Support Plan | 65d? | 2009-09-01 | 2009-11-30 |  |  | 2009-09-01 | 2009-11-30 | 65d? | 124d | start no earlier than 2009-09-01 | Chin [3.1%]; Lyke [3.1%] | 32h |  | 2,400 | 3,000 |  |
| 641 | 1.3.10.1.2 | Operations Maintenance & Spares Plan Template | 51d? | 2010-01-04 A | 2010-03-15 | 25% | 38.25d? | 2009-09-01 | 2009-11-30 | 65d? | 49d | finish no earlier than 2010-03-15 | Wetherell [6.9%]; Bell [3.9%]; Lockwood [1.5%]; Velur [1.5%] | 56h | 14h | 4,200 | 4,200 | 1,050 |

Notes:
- 617: CN
- 618: CN
- 619: CN
- 620: CN
- 621: JB
- 622: JB
- 623: JC
- 626: CN
- 627: JB
- 628: EW
- 629: JC
- 630: CN
- 631: CN
- 632: JC
- 633: JC
- 634: CN
- 635: JL
- 637: JL
- 638: JC
- 639: JC
- 640: JC
- 641: EW

| ID | WBS | Task | Duration | Start | Finish | Complete | Remaining | Baseline start | Baseline finish | Baseline duration | Total slack | Constraint | Resources | Work | Actual work | Cost | Baseline cost | Actual cost |
| --- | --- | --- | --- | --- | --- | --- | --- | --- | --- | --- | --- | --- | --- | --- | --- | --- | --- | --- |
| 642 | 1.3.10.2 | **Operations Handover** | 152d? | 2009-05-01 A | 2009-11-30 | 15% | 128.81d? | 2009-01-09 | 2009-11-30 | 232d? | 124d |  |  | 78h | 22.5h | 5,850 | 5,250 | 1,687.5 |
| 643 | 1.3.10.2.1 | Operations Handover Success Criteria | 6d? | 2009-05-01 A | 2009-05-08 | 75% | 1.5d? | 2009-05-01 | 2009-05-08 | 6d? | 270d | finish no earlier than 2009-05-08 | Chin [33.3%] | 16h | 12h | 1,200 | 1,200 | 900 |
| 644 | 1.3.10.2.2 | Operations Personnel Training Plan | 65d? | 2009-09-01 A | 2009-11-30 | 25% | 48.75d? | 2009-09-01 | 2009-11-30 | 65d? | 124d | start no earlier than 2009-09-01 | Lyke [3.1%]; Chin [5%] | 42h | 10.5h | 3,150 | 3,750 | 787.5 |
| 645 | 1.3.10.2.3 | Documentation Transition Plan | 65d? | 2009-09-01 | 2009-11-30 |  |  | 2009-01-09 | 2009-11-30 | 232d? | 124d | start no earlier than 2009-09-01 | Chin [3.1%]; Lyke [0.8%] | 20h |  | 1,500 | 1,500 |  |

Notes:
- 642: JC
- 643: JC
- 644: JC
- 645: JC
