# NGAO Design v7

Schedule from MS Project, 2005-10-03 to 2010-03-22, costs in $, A marks actual dates.
CARA

## Calendars

- Standard: Mon-Fri 08:00-12:00, 13:00-17:00; Sat-Sun off.

## Resources

| Resource | Group | Rate |
| --- | --- | --- |
| Dekany | COO |  |
| Gavel | UCO | 75 |
| Max | UCO |  |
| Wizinowich | WMKO | 75 |
| Adkins | KO | 75 |
| McGrath | UCO | 75 |
| Tyau | WMKO | 75 |
| Le Mignant | WMKO | 75 |
| Bell | KO | 75 |
| Chin | WMKO | 75 |
| Kupke | UCO | 75 |
| Lockwood | UCO | 75 |
| Neyman | WMKO | 75 |
| Reinig | UCO | 75 |
| Velur | COO | 75 |
| Free | WMKO |  |
| Student |  | 75 |
| Johansson | WMKO | 75 |
| Wetherell | WMKO | 75 |
| Medeiros | WMKO | 75 |
| Nance | WMKO | 75 |
| Summers | WMKO | 75 |
| Mogensen | WMKO | 75 |
| Bouchez | KO | 75 |
| Kissner | WMKO | 75 |
| Chock | WMKO | 75 |
| Panteleev | WMKO | 75 |
| Morrison | WMKO | 75 |
| Macintosh | UCO | 75 |
| Electrical Engineer / Programmer | UCO | 75 |
| Zolkower | COO | 75 |
| Britton | COO | 75 |
| Hale | COO | 75 |
| Grace |  | 75 |
| Doyle | WMKO | 75 |
| Contract Administrator | WMKO | 75 |
| Brown | COO | 75 |

## Schedule

| ID | WBS | Task | Duration | Start | Finish | Complete | Remaining | Total slack | Constraint | Resources | Work | Actual work | Cost | Actual cost |
| --- | --- | --- | --- | --- | --- | --- | --- | --- | --- | --- | --- | --- | --- | --- |
| 1 | 1 | **NGAO Design** | 1166d? | 2005-10-03 A | 2010-03-22 | 13% | 1008.67d? | 0d |  |  | 36131h | 6374.3h | 2,592,599.97 | 449,923.18 |
| 2 | 1.1 | Proposal | 195d? | 2005-10-03 | 2006-06-30 |  |  | 971d | finish no earlier than 2006-06-30 |  |  |  |  |  |
| 3 | 1.2 | System Design | 413d? | 2006-10-02 | 2008-04-30 |  |  | 493d | finish no earlier than 2008-04-30 |  |  |  |  |  |
| 4 | 1.3 | **Preliminary Design** | 494d? | 2008-04-30 A | 2010-03-22 | 14% | 426.07d? | 0d |  |  | 36131h | 6374.3h | 2,592,599.97 | 449,923.18 |
| 5 | 1.3.1 | Reserved | 1d? | 2008-05-01 | 2008-05-01 |  |  | 492d | start no earlier than 2008-05-01 |  |  |  |  |  |
| 6 | 1.3.2 | **PD Phase Management** | 494d? | 2008-04-30 A | 2010-03-22 | 34% | 324.65d? | 0d |  |  | 9306h | 2744.8h | 648,300 | 189,673.34 |
| 7 | 1.3.2.1 | **Planning** | 456d? | 2008-05-02 A | 2010-01-29 | 12% | 400.9d? | 36d |  |  | 1640h | 69h | 120,450 | 5,175 |
| 8 | 1.3.2.1.1 | **Replans (PD phase)** | 286d? | 2008-05-02 A | 2009-06-05 | 35% | 185.9d? | 206d |  |  | 190h | 57.5h | 14,250 | 4,312.5 |
| 9 | 1.3.2.1.1.1 | Replan based on SDR | 6d? | 2008-05-02 A | 2008-05-09 | 85% | 0.9d? | 486d | start no earlier than 2008-05-02 | Dekany [12.5%]; Gavel [12.5%]; Wizinowich [37.5%] | 30h | 25.5h | 2,250 | 1,912.5 |
| 10 | 1.3.2.1.1.2 | Replan 1 | 10d? | 2008-10-27 A | 2008-11-07 | 40% | 6d? | 356d | finish no earlier than 2008-11-07 | Dekany [20%]; Gavel [20%]; Wizinowich [45%]; Lockwood [1.2%]; Velur [3.8%]; Neyman [1.2%]; Le Mignant [1.2%]; Johansson [2.5%]; Reinig [2.5%]; Bell [1.2%]; Wetherell [1.2%] | 80h | 32h | 6,000 | 2,400 |
| 11 | 1.3.2.1.1.3 | Replan 2 | 10d? | 2009-05-25 | 2009-06-05 |  |  | 206d | finish no earlier than 2009-06-05 | Dekany [20%]; Gavel [20%]; Wizinowich [40%]; Wetherell [2.5%]; Bell [1.2%]; Reinig [3.8%]; Johansson [2.5%]; Le Mignant [2.5%]; Neyman [1.2%]; Velur [5%]; Lockwood [1.2%] | 80h |  | 6,000 |  |
| 12 | 1.3.2.1.2 | **WMKO FY Plans** | 280d? | 2008-05-05 A | 2009-05-29 | 23% | 215.33d? | 211d |  |  | 40h | 11.5h | 3,000 | 862.5 |
| 13 | 1.3.2.1.2.1 | Support WMKO FY09 Planning | 20d? | 2008-05-05 A | 2008-05-30 A | 100% |  |  | start no earlier than 2008-05-05 | Wizinowich [6.2%] | 10h | 10h | 750 | 750 |
| 14 | 1.3.2.1.2.2 | Support WMKO FY10 Planning | 85d? | 2009-02-02 A | 2009-05-29 | 5% | 80.75d? | 211d | start no earlier than 2009-02-02 | Wizinowich [4.4%] | 30h | 1.5h | 2,250 | 112.5 |
| 15 | 1.3.2.1.3 | **Systems Engineering Management Plan** | 218d? | 2009-04-01 | 2010-01-29 |  |  | 36d |  |  | 1410h |  | 103,200 |  |
| 16 | 1.3.2.1.3.1 | **Project Plan** | 50d? | 2009-11-02 | 2010-01-08 |  |  | 51d |  |  | 1010h |  | 74,250 |  |
| 17 | 1.3.2.1.3.1.1 | PBS, WBS & Task Definition | 15d? | 2009-11-02 | 2009-11-20 |  |  | 86d | start no earlier than 2009-11-02 | Dekany [33.3%]; Gavel [33.3%]; Wizinowich [33.3%]; Max [8.3%]; Reinig [12.5%]; Wetherell [8.3%]; Johansson [12.5%]; Le Mignant [12.5%]; Neyman [8.3%]; Bell [8.3%]; Velur [33.3%]; Lockwood [12.5%] | 260h |  | 18,750 |  |
| 18 | 1.3.2.1.3.1.2 | Cost Estimation | 20d? | 2009-11-23 | 2009-12-18 |  |  | 66d | start no earlier than 2009-11-23 | Dekany [37.5%]; Gavel [25%]; Max [6.2%]; Wizinowich [37.5%]; Nance [12.5%]; Neyman [18.8%]; Le Mignant [18.8%]; Bell [12.5%]; Johansson [25%]; Wetherell [9.4%]; Reinig [12.5%]; Kupke [9.4%]; Lockwood [12.5%]; Velur [9.4%]; Brown [25%]; Britton [9.4%]; Hale [9.4%]; Zolkower [9.4%] | 480h |  | 35,250 |  |
| 19 | 1.3.2.1.3.1.3 | Full Schedule (MS Project Plan) | 25d? | 2009-12-07 | 2010-01-08 |  |  | 51d | start no earlier than 2009-12-07 | Wizinowich [30%]; Dekany [15%]; Gavel [15%]; Velur [20%]; Bell [5%]; Neyman [7.5%]; Le Mignant [10%]; Johansson [10%]; Wetherell [5%]; Lockwood [7.5%]; Reinig [10%] | 270h |  | 20,250 |  |
| 20 | 1.3.2.1.3.2 | **Detailed Design Phase Plan** | 177d? | 2009-04-01 | 2009-12-03 |  |  | 77d |  |  | 320h |  | 23,250 |  |
| 21 | 1.3.2.1.3.2.1 | Detailed Design Plan v1 (FY10 planning) | 33d? | 2009-04-01 | 2009-05-15 |  |  | 221d | finish no earlier than 2009-05-15 | Wizinowich [15.2%] | 40h |  | 3,000 |  |
| 22 | 1.3.2.1.3.2.2 | Detailed Design Plan v2 (TSIP proposal) | 18d? | 2009-07-15 | 2009-08-07 |  |  | 161d | start no earlier than 2009-07-15 | Wizinowich [22.2%]; Dekany [27.8%]; Gavel [27.8%] | 40h |  | 3,000 |  |
| 23 | 1.3.2.1.3.2.3 | Detailed Design Plan Final Version | 19d? | 2009-11-09 | 2009-12-03 |  |  | 77d | start no earlier than 2009-11-09 | Wizinowich [46.1%]; Dekany [19.7%]; Gavel [19.7%]; Max [6.6%]; Lockwood [65.8%]; Nance; Bell; Neyman; Le Mignant; Johansson; Reinig; Velur | 240h |  | 17,250 |  |
| 24 | 1.3.2.1.3.3 | SEMP Document | 15d? | 2010-01-11 | 2010-01-29 |  |  | 36d | start no earlier than 2010-01-11 | Wizinowich [30%]; Dekany [20%]; Gavel [13.3%]; Max [3.3%] | 80h |  | 5,700 |  |

Notes:
- 6: PW
- 7: PW
- 15: PW
- 17: PW
- 18: RD
- 19: PW
- 20: PW
- 21: PW
- 22: PW
- 23: PW
- 24: PW

| ID | WBS | Task | Type | Duration | Start | Finish | Complete | Remaining | Total slack | Constraint | Resources | Work | Actual work | Cost | Actual cost |
| --- | --- | --- | --- | --- | --- | --- | --- | --- | --- | --- | --- | --- | --- | --- | --- |
| 25 | 1.3.2.2 | **Project Management & Meetings** |  | 477d? | 2008-05-01 A | 2010-02-26 | 40% | 287.95d? | 16d |  |  | 2270h | 824.5h | 162,750 | 58,837.51 |
| 26 | 1.3.2.2.1 | **Executive Committee** |  | 477d? | 2008-05-01 A | 2010-02-26 | 40% | 286.2d? | 16d |  |  | 600h | 240h | 37,500 | 15,000 |
| 27 | 1.3.2.2.1.1 | Executive Committee Management Activities |  | 477d? | 2008-05-01 A | 2010-02-26 | 40% | 286.2d? | 16d | finish no earlier than 2010-02-26 | Dekany [2%]; Gavel [2%]; Max [0.7%]; Wizinowich [3.3%] | 300h | 120h | 20,625 | 8,250 |
| 28 | 1.3.2.2.1.2 | Executive Committee Telecons |  | 477d? | 2008-05-01 A | 2010-02-26 | 40% | 286.2d? | 16d | finish no earlier than 2010-02-26 | Dekany [2%]; Gavel [2%]; Max [2%]; Wizinowich [2%] | 300h | 120h | 16,875 | 6,750 |
| 29 | 1.3.2.2.2 | **Team Meetings** |  | 477d? | 2008-05-01 A | 2010-02-26 | 39% | 291.44d? | 16d |  |  | 1670h | 584.5h | 125,250 | 43,837.51 |
| 30 | 1.3.2.2.2.1 | Meeting Participation |  | 477d? | 2008-05-01 A | 2010-02-26 | 39% | 291.44d? | 16d | start no earlier than 2008-05-01 | Dekany [4.2%]; Gavel [4.2%]; Wizinowich [4.2%]; Le Mignant [3.9%]; Johansson [4.3%]; Neyman [3.9%]; Bell [2.1%]; Adkins [2.4%]; Kupke [2.4%]; Lockwood [2.4%]; Velur [3.9%]; Wetherell [3.3%]; Reinig [2.6%]; Zolkower [2.6%] | 1670h | 584.5h | 125,250 | 43,837.51 |
| 31 | 1.3.2.2.2.2 | Team Meeting #1 (CIT - 1 day) | milestone | 0d | 2008-05-01 | 2008-05-01 |  |  | 493d | start no earlier than 2008-05-01 |  |  |  |  |  |
| 32 | 1.3.2.2.2.3 | Team Meeting #2 (telecon) | milestone | 0d | 2008-06-13 | 2008-06-13 |  |  | 462d | start no earlier than 2008-06-13 |  |  |  |  |  |
| 33 | 1.3.2.2.2.4 | Team Meeting #3 (telecon) | milestone | 0d? | 2008-07-11 | 2008-07-11 |  |  | 442d | start no earlier than 2008-07-11 |  |  |  |  |  |
| 34 | 1.3.2.2.2.5 | Team Meeting #4 (telecon) | milestone | 0d | 2008-08-15 A | 2008-08-15 A | 100% |  |  | start no earlier than 2008-08-15 |  |  |  |  |  |
| 35 | 1.3.2.2.2.6 | Team Meeting #5 (UC - 3 days) | milestone | 0d? | 2008-09-18 A | 2008-09-18 A | 100% |  |  | finish no earlier than 2008-09-18 |  |  |  |  |  |
| 36 | 1.3.2.2.2.7 | Team Meeting #6 (telecon) | milestone | 0d | 2008-10-17 | 2008-10-17 |  |  | 372d | start no earlier than 2008-10-17 |  |  |  |  |  |
| 37 | 1.3.2.2.2.8 | Team Meeting #7 (telecon) | milestone | 0d | 2008-11-14 | 2008-11-14 |  |  | 352d | start no earlier than 2008-11-14 |  |  |  |  |  |
| 38 | 1.3.2.2.2.9 | Team Meeting #8 (telecon) | milestone | 0d | 2008-12-12 | 2008-12-12 |  |  | 332d | start no earlier than 2008-12-12 |  |  |  |  |  |
| 39 | 1.3.2.2.2.10 | Team Meeting #9 (telecon) | milestone | 0d | 2009-01-16 | 2009-01-16 |  |  | 306d | finish no earlier than 2009-01-16 |  |  |  |  |  |
| 40 | 1.3.2.2.2.11 | Team Meeting #10 (WMKO - 4 days) | milestone | 0d | 2009-02-10 | 2009-02-10 |  |  | 290d | start no earlier than 2009-02-10 |  |  |  |  |  |
| 41 | 1.3.2.2.2.12 | Team Meeting #11 (telecon) | milestone | 0d | 2009-03-13 | 2009-03-13 |  |  | 267d | start no earlier than 2009-03-13 |  |  |  |  |  |
| 42 | 1.3.2.2.2.13 | Team Meeting #12 (telecon) | milestone | 0d | 2009-04-17 | 2009-04-17 |  |  | 242d | start no earlier than 2009-04-17 |  |  |  |  |  |
| 43 | 1.3.2.2.2.14 | Team Meeting #13 (telecon) | milestone | 0d | 2009-05-15 | 2009-05-15 |  |  | 221d | finish no earlier than 2009-05-15 |  |  |  |  |  |
| 44 | 1.3.2.2.2.15 | Team Meeting #14 (telecon) | milestone | 0d | 2009-06-12 | 2009-06-12 |  |  | 201d | finish no earlier than 2009-06-12 |  |  |  |  |  |
| 45 | 1.3.2.2.2.16 | Team Meeting #15 (telecon) | milestone | 0d | 2009-07-17 | 2009-07-17 |  |  | 177d | start no earlier than 2009-07-17 |  |  |  |  |  |
| 46 | 1.3.2.2.2.17 | Team Meeting #16 (CIT - 3 days)) | milestone | 0d | 2009-08-20 | 2009-08-20 |  |  | 152d | finish no earlier than 2009-08-20 |  |  |  |  |  |
| 47 | 1.3.2.2.2.18 | Team Meeting #17 (telecon) | milestone | 0d | 2009-09-18 | 2009-09-18 |  |  | 132d | start no earlier than 2009-09-18 |  |  |  |  |  |
| 48 | 1.3.2.2.2.19 | Team Meeting #18 (telecon) | milestone | 0d | 2009-10-16 | 2009-10-16 |  |  | 112d | start no earlier than 2009-10-16 |  |  |  |  |  |
| 49 | 1.3.2.2.2.20 | Team Meeting #19 (telecon) | milestone | 0d | 2009-11-13 | 2009-11-13 |  |  | 92d | start no earlier than 2009-11-13 |  |  |  |  |  |
| 50 | 1.3.2.2.2.21 | Team Meeting #20 (telecon) | milestone | 0d | 2009-12-11 | 2009-12-11 |  |  | 72d | start no earlier than 2009-12-11 |  |  |  |  |  |
| 51 | 1.3.2.2.2.22 | Team Meeting #21 (telecon) | milestone | 0d | 2010-01-15 | 2010-01-15 |  |  | 47d | start no earlier than 2010-01-15 |  |  |  |  |  |

Notes:
- 25: PW
- 26: PW
- 29: PW

| ID | WBS | Task | Type | Duration | Start | Finish | Complete | Remaining | Total slack | Constraint | Resources | Work | Actual work | Cost | Actual cost |
| --- | --- | --- | --- | --- | --- | --- | --- | --- | --- | --- | --- | --- | --- | --- | --- |
| 52 | 1.3.2.2.3 | **Director Telecons** |  | 390d | 2008-05-09 | 2009-11-06 |  |  | 97d |  |  |  |  |  |  |
| 53 | 1.3.2.2.3.1 | Director Telecon #1 | milestone | 0d | 2008-05-09 | 2008-05-09 |  |  | 487d | start no earlier than 2008-05-09 |  |  |  |  |  |
| 54 | 1.3.2.2.3.2 | Director Telecon #2 | milestone | 0d | 2008-11-07 | 2008-11-07 |  |  | 357d | start no earlier than 2008-11-07 |  |  |  |  |  |
| 55 | 1.3.2.2.3.3 | Director Telecon #3 | milestone | 0d | 2009-05-08 | 2009-05-08 |  |  | 227d | start no earlier than 2009-05-08 |  |  |  |  |  |
| 56 | 1.3.2.2.3.4 | Director Telecon #4 | milestone | 0d | 2009-11-06 | 2009-11-06 |  |  | 97d | start no earlier than 2009-11-06 |  |  |  |  |  |
| 57 | 1.3.2.3 | **Tracking & Reporting** |  | 478d? | 2008-04-30 A | 2010-02-26 | 35% | 308.94d? | 16d |  |  | 869h | 403.4h | 62,175 | 29,068.33 |
| 58 | 1.3.2.3.1 | **Monthly Status Reports** |  | 477d? | 2008-05-01 A | 2010-02-26 | 40% | 287.63d? | 16d |  |  | 546h | 201.4h | 37,950 | 13,918.33 |
| 59 | 1.3.2.3.1.1 | Monthly Team Status Reports |  | 477d? | 2008-05-01 A | 2010-02-26 | 39% | 290.44d? | 16d | start no earlier than 2008-05-01 | Wizinowich [1%]; Max [0.5%]; Gavel [1%]; Dekany [1%]; Reinig [0.6%]; Johansson [0.8%]; Le Mignant [0.7%]; Velur [1%]; Kupke [0.5%]; Neyman [0.5%]; Lockwood [0.5%]; Bell [0.3%]; Adkins [0.5%]; Wetherell [0.4%] | 340h | 119h | 24,000 | 8,338.33 |
| 60 | 1.3.2.3.1.2 | Monthly Project Reports (TSIP, Directors) |  | 467d? | 2008-05-15 A | 2010-02-26 | 40% | 280.2d? | 16d | start no earlier than 2008-05-15 | Wizinowich [2.4%]; Dekany [0.5%]; Gavel [0.5%]; Adkins [0.5%]; Max [0.5%] | 170h | 68h | 11,250 | 4,500 |
| 61 | 1.3.2.3.1.3 | TSIP Project Report Telecons |  | 464d? | 2008-05-20 A | 2010-02-26 | 40% | 278.4d? | 16d | start no earlier than 2008-05-20 | Adkins [0.5%]; Wizinowich [0.5%] | 36h | 14.4h | 2,700 | 1,080 |
| 62 | 1.3.2.3.2 | **SSC Meetings** |  | 459.88d? | 2008-04-30 A | 2010-02-02 | 26% | 339.91d? | 34.12d |  |  | 91h | 26h | 6,825 | 1,950 |
| 63 | 1.3.2.3.2.1 | SSC Meeting (CIT) - SDR report | milestone | 0d | 2008-04-30 | 2008-04-30 |  |  | 494d | start no earlier than 2008-04-30 |  |  |  |  |  |
| 64 | 1.3.2.3.2.2 | SSC Meeting (Keck) |  | 1.12d | 2008-06-18 A | 2008-06-19 A | 100% |  |  | start no earlier than 2008-06-18 | Dekany; Gavel; Wizinowich | 13h | 13h | 975 | 975 |
| 65 | 1.3.2.3.2.3 | SSC Meeting (UCSC) |  | 1.12d | 2008-11-03 A | 2008-11-04 A | 100% |  |  | start no earlier than 2008-11-03 | Dekany; Gavel; Wizinowich | 13h | 13h | 975 | 975 |
| 66 | 1.3.2.3.2.4 | SSC Meeting (Keck) |  | 1.12d | 2009-02-19 | 2009-02-20 |  |  | 281.88d | start no earlier than 2009-02-19 | Dekany; Gavel; Wizinowich | 13h |  | 975 |  |
| 67 | 1.3.2.3.2.5 | SSC Meeting (CIT) |  | 1.12d | 2009-04-29 | 2009-04-30 |  |  | 232.88d | start no earlier than 2009-04-29 | Dekany; Gavel; Wizinowich | 13h |  | 975 |  |
| 68 | 1.3.2.3.2.6 | SSC Meeting (Keck) |  | 1.12d | 2009-06-17 | 2009-06-18 |  |  | 197.88d | start no earlier than 2009-06-17 | Dekany; Gavel; Wizinowich | 13h |  | 975 |  |
| 69 | 1.3.2.3.2.7 | SSC Meeting (UCSC) |  | 1.12d | 2009-11-03 | 2009-11-04 |  |  | 98.88d | start no earlier than 2009-11-03 | Dekany; Gavel; Wizinowich | 13h |  | 975 |  |
| 70 | 1.3.2.3.2.8 | SSC Meeting (Keck) |  | 1.88d? | 2010-02-01 | 2010-02-02 |  |  | 34.12d | start no earlier than 2010-02-01 | Dekany [50%]; Gavel [50%]; Wizinowich [60%] | 13h |  | 975 |  |
| 71 | 1.3.2.3.3 | **Other Presentations** |  | 350d? | 2008-06-02 A | 2009-10-02 | 8% | 321.49d? | 121d |  |  | 232h | 176h | 17,400 | 13,200 |
| 72 | 1.3.2.3.3.1 | SPIE AO Conference Presentations/Papers |  | 15d? | 2008-06-02 A | 2008-06-20 A | 100% |  |  | start no earlier than 2008-06-02 | Dekany [33.3%]; Gavel [33.3%]; Wizinowich [33.3%] | 120h | 120h | 9,000 | 9,000 |
| 73 | 1.3.2.3.3.2 | SPIE AO Conference (Marseille) |  | 5d? | 2008-06-23 | 2008-06-28 |  |  | 451d | finish no earlier than 2008-06-28 |  |  |  |  |  |
| 74 | 1.3.2.3.3.3 | Keck Science Meeting 08 |  | 3d | 2008-09-18 A | 2008-09-22 A | 100% |  |  | start no earlier than 2008-09-18 | Dekany; Gavel; Wizinowich | 56h | 56h | 4,200 | 4,200 |
| 75 | 1.3.2.3.3.4 | Keck Science Meeting 09 |  | 3d | 2009-09-17 | 2009-09-21 |  |  | 130d | start no earlier than 2009-09-17 | Dekany; Gavel; Wizinowich | 56h |  | 4,200 |  |
| 76 | 1.3.2.3.3.5 | Other |  | 195d? | 2009-01-05 | 2009-10-02 |  |  | 121d | finish no earlier than 2009-10-02 |  |  |  |  |  |

Notes:
- 52: PW
- 57: PW
- 58: PW
- 62: PW
- 71: PW

| ID | WBS | Task | Type | Duration | Start | Finish | Complete | Remaining | Total slack | Constraint | Resources | Work | Actual work | Cost | Actual cost |
| --- | --- | --- | --- | --- | --- | --- | --- | --- | --- | --- | --- | --- | --- | --- | --- |
| 77 | 1.3.2.4 | **Proposals** |  | 348d? | 2008-06-02 A | 2009-09-30 | 5% | 330.29d? | 123d |  |  | 480h | 160h | 3,000 |  |
| 78 | 1.3.2.4.1 | Advancement Support |  | 348d? | 2008-06-02 | 2009-09-30 |  |  | 123d | start no earlier than 2008-06-02 | Free [2.9%] | 80h |  |  |  |
| 79 | 1.3.2.4.2 | TSIP Proposal for DDR |  | 25d? | 2009-07-28 | 2009-08-31 |  |  | 145d | finish no earlier than 2009-08-31 | Dekany [10%]; Gavel [10%]; Max [10%]; Free [90%] | 240h |  | 3,000 |  |
| 80 | 1.3.2.4.3 | Other Proposal |  | 20d? | 2009-09-03 A | 2009-09-30 A | 100% |  |  | finish no earlier than 2009-09-30 | Free | 160h | 160h |  |  |
| 81 | 1.3.2.5 | **Programmatic Risk Assessment & Mitigation** |  | 355d? | 2008-05-19 A | 2009-09-25 | 45% | 196.31d? | 126d |  |  | 180h | 30h | 13,500 | 2,250 |
| 82 | 1.3.2.5.1 | **Risk Assessment** |  | 213.25d? | 2008-09-04 | 2009-06-30 |  |  | 189d |  |  | 60h |  | 4,500 |  |
| 83 | 1.3.2.5.1.1 | Programmatic Risk Assessment v1 |  | 6.25d? | 2008-09-04 | 2008-09-12 |  |  | 396d | finish no earlier than 2008-09-12 | Wizinowich [40%]; Dekany [8%]; Gavel [8%]; Adkins [8.9%] | 32h |  | 2,400 |  |
| 84 | 1.3.2.5.1.2 | Programmatic Risk Assessment v2 |  | 2d? | 2009-06-29 | 2009-06-30 |  |  | 189d | finish no earlier than 2009-06-30 | Wizinowich; Dekany; Gavel; Adkins | 28h |  | 2,100 |  |
| 85 | 1.3.2.5.2 | **Risk Mitigation** |  | 355d? | 2008-05-19 A | 2009-09-25 | 45% | 193.59d? | 126d |  |  | 120h | 30h | 9,000 | 2,250 |
| 86 | 1.3.2.5.2.1 | Laser Procurement |  | 350d? | 2008-05-26 A | 2009-09-25 | 60% | 140d? | 126d | finish no earlier than 2009-09-25 | Wizinowich [1.4%] | 40h | 24h | 3,000 | 1,800 |
| 87 | 1.3.2.5.2.2 | Science Instruments |  | 35d? | 2008-10-06 A | 2008-11-21 | 10% | 31.5d? | 346d | finish no earlier than 2008-11-21 | Wizinowich [14.3%] | 40h | 4h | 3,000 | 300 |
| 88 | 1.3.2.5.2.3 | Funding |  | 95d? | 2008-05-19 A | 2008-09-26 | 5% | 90.25d? | 386d | finish no earlier than 2008-09-26 | Wizinowich [5.3%] | 40h | 2h | 3,000 | 150 |
| 89 | 1.3.2.6 | **Preliminary Design Review** |  | 404.33d? | 2008-09-02 | 2010-03-22 |  |  | 0d |  |  | 506h |  | 34,350 |  |
| 90 | 1.3.2.6.1 | Define Success Criteria for all Reviews |  | 8.33d? | 2008-09-02 | 2008-09-12 |  |  | 396d | finish no earlier than 2008-09-12 | Wizinowich [60%]; Dekany [12%]; Gavel [12%]; Max [6%] | 60h |  | 4,200 |  |
| 91 | 1.3.2.6.2 | Review Setup (Date, Participants, Charter) |  | 5d? | 2009-09-07 | 2009-09-11 |  |  | 136d | start no earlier than 2009-09-07 | Wizinowich [30%]; Max [10%] | 16h |  | 900 |  |
| 92 | 1.3.2.6.3 | Preliminary Design Report |  | 12d? | 2010-01-11 | 2010-01-26 |  |  | 39d | start no earlier than 2010-01-11 | Wizinowich [52.1%]; Dekany [15.6%]; Gavel [15.6%]; Max [4.2%]; Neyman [2.1%]; Le Mignant [2.1%]; Johansson [2.1%]; Reinig [3.1%]; Velur [5.2%]; Kupke [2.1%] | 100h |  | 7,200 |  |
| 93 | 1.3.2.6.4 | Review Package Distributed |  | 1d? | 2010-01-27 | 2010-01-27 |  |  | 38d | start no earlier than 2010-01-27 | Wizinowich [75%] | 6h |  | 450 |  |
| 94 | 1.3.2.6.5 | Reviewer Comments Received | milestone | 0d | 2010-02-10 | 2010-02-10 |  |  | 29d | start no earlier than 2010-02-10 |  |  |  |  |  |
| 95 | 1.3.2.6.6 | Reviewer Comments Addressed |  | 5d? | 2010-02-11 | 2010-02-17 |  |  | 23d | start no earlier than 2010-02-11 | Wizinowich [50%]; Dekany [30%]; Gavel [30%]; Max [40%]; Reinig [5%]; Velur [15%]; Bell [2.5%]; Wetherell [2.5%]; Neyman [5%]; Le Mignant [5%]; Johansson [5%]; Kupke [5%]; Lockwood [5%] | 80h |  | 4,800 |  |
| 96 | 1.3.2.6.7 | PDR Presentation Preparation |  | 15d? | 2010-02-01 | 2010-02-19 |  |  | 21d | start no earlier than 2010-02-01 | Wizinowich [16.7%]; Dekany [10%]; Gavel [10%]; Reinig [3.3%]; Kupke [1.7%]; Lockwood [1.7%]; Velur [5%]; Wetherell [0.8%]; Bell [0.8%]; Neyman [1.7%]; Le Mignant [2.5%]; Johansson [2.5%] | 68h |  | 5,100 |  |
| 97 | 1.3.2.6.8 | Preliminary Design Review |  | 1d? | 2010-02-22 | 2010-02-22 |  |  | 20d | start no earlier than 2010-02-22 | Wizinowich [1250%]; Dekany [1250%]; Max [1250%]; Gavel [1250%]; Zolkower; Velur; Reinig; Lockwood; Kupke; Wetherell; Le Mignant; Neyman; Johansson; Britton | 128h |  | 8,700 |  |
| 98 | 1.3.2.6.9 | Reviewer Report Received | milestone | 0d | 2010-03-15 | 2010-03-15 |  |  | 6d | start no earlier than 2010-03-15 |  |  |  |  |  |
| 99 | 1.3.2.6.10 | Response to Reviewer Report |  | 5d? | 2010-03-16 | 2010-03-22 |  |  | 0d | start no earlier than 2010-03-16 | Wizinowich [40%]; Dekany [20%]; Gavel [20%]; Max [20%]; Reinig [5%]; Kupke [2.5%]; Velur [5%]; Neyman [2.5%]; Le Mignant [2.5%]; Johansson [2.5%] | 48h |  | 3,000 |  |
| 100 | 1.3.2.7 | **Project Support** |  | 477d? | 2008-05-01 A | 2010-02-26 | 38% | 296.71d? | 16d |  |  | 3361h | 1257.9h | 252,075 | 94,342.5 |
| 101 | 1.3.2.7.1 | Administrative/Contract Support |  | 477d? | 2008-05-01 A | 2010-02-26 | 38% | 295.19d? | 0d | start no earlier than 2008-05-01 | Tyau [20.6%]; Contract Administrator [2.1%]; Wizinowich [10.4%] | 765h | 229.5h | 57,375 | 17,212.5 |
| 102 | 1.3.2.7.2 | Shared Infrastructure |  | 430d? | 2008-07-07 A | 2010-02-26 | 35% | 279.5d? | 16d | finish no earlier than 2010-02-26 | Chock [5.8%] | 200h | 70h | 15,000 | 5,250 |
| 103 | 1.3.2.7.3 | Research Time |  | 477d? | 2008-05-01 A | 2010-02-26 | 40% | 286.2d? | 16d | start no earlier than 2008-05-01 | McGrath [47.3%]; Le Mignant [15.5%] | 2396h | 958.4h | 179,700 | 71,880 |

Notes:
- 77: PW
- 81: PW
- 82: PW
- 85: PW
- 89: PW
- 100: PW

| ID | WBS | Task | Duration | Start | Finish | Complete | Remaining | Total slack | Constraint | Resources | Work | Actual work | Cost | Actual cost |
| --- | --- | --- | --- | --- | --- | --- | --- | --- | --- | --- | --- | --- | --- | --- |
| 104 | 1.3.3 | **Systems Engineering** | 457d? | 2008-05-01 A | 2010-01-29 | 18% | 375.61d? | 36d |  |  | 9415h | 1711.2h | 638,550 | 116,377.34 |
| 105 | 1.3.3.1 | **Science Case Requirements** | 457d? | 2008-05-01 A | 2010-01-29 | 19% | 369.08d? | 36d |  |  | 4005h | 622.7h | 232,800 | 34,740 |
| 106 | 1.3.3.1.1 | **Science Case Requirements** | 447d? | 2008-05-01 A | 2010-01-15 | 16% | 373.36d? | 46d |  |  | 2701h | 448h | 166,500 | 26,550 |
| 107 | 1.3.3.1.1.1 | **Requirements for new Science Drivers** | 183d? | 2008-05-01 A | 2009-01-12 | 33% | 121.82d? | 310d |  |  | 440h | 173.8h | 24,000 | 10,140 |
| 108 | 1.3.3.1.1.1.1 | Astrometry Science in Sparse Fields | 71d? | 2008-10-06 A | 2009-01-12 | 50% | 35.5d? | 310d | finish no earlier than 2009-01-12 | McGrath [7%]; Student [14.1%]; Max [3.5%] | 140h | 70h | 9,000 | 4,500 |
| 109 | 1.3.3.1.1.1.2 | Resolved Stellar Populations in Crowded Fields | 61d? | 2008-07-14 A | 2008-10-06 | 55% | 27.45d? | 380d | finish no earlier than 2008-10-06 | Student [24.6%]; Max [8.2%] | 160h | 88h | 9,000 | 4,950 |
| 110 | 1.3.3.1.1.1.3 | Debris Disks & Young Stellar Objects | 61d? | 2008-07-14 A | 2008-10-06 | 10% | 54.9d? | 380d | finish no earlier than 2008-10-06 | McGrath [8.2%]; Max [8.2%] | 80h | 8h | 3,000 | 300 |
| 111 | 1.3.3.1.1.1.4 | QSO Host Galaxies | 52d? | 2008-05-01 A | 2008-07-11 | 13% | 45.24d? | 441d | finish no earlier than 2008-07-11 | McGrath [9.6%]; Max [4.8%] | 60h | 7.8h | 3,000 | 390 |
| 112 | 1.3.3.1.1.2 | **Extend SCRD Discussion of Science Drivers** | 168d? | 2008-05-01 A | 2008-12-22 | 11% | 150.23d? | 325d |  |  | 601h | 58.2h | 37,500 | 3,600 |
| 113 | 1.3.3.1.1.2.1 | Nearby AGNs | 52d? | 2008-05-01 A | 2008-07-11 | 50% | 26d? | 441d | finish no earlier than 2008-07-11 | McGrath [4.8%]; Max [2.4%] | 30h | 15h | 1,500 | 750 |
| 114 | 1.3.3.1.1.2.2 | Gravitational Lensing | 52d? | 2008-05-01 A | 2008-07-11 | 45% | 28.6d? | 441d | finish no earlier than 2008-07-11 | McGrath [9.6%]; Max [1%] | 44h | 19.8h | 3,000 | 1,350 |
| 115 | 1.3.3.1.1.2.3 | Backup Science | 52d? | 2008-05-01 | 2008-07-11 |  |  | 441d | finish no earlier than 2008-07-11 | McGrath [4.8%]; Max [1%]; Le Mignant [4.8%] | 44h |  | 3,000 |  |
| 116 | 1.3.3.1.1.2.4 | Ice Giant Planets | 61d? | 2008-07-14 | 2008-10-06 |  |  | 380d | finish no earlier than 2008-10-06 | McGrath [2%] | 10h |  | 750 |  |
| 117 | 1.3.3.1.1.2.5 | GR at Galactic Center | 61d? | 2008-07-14 A | 2008-10-06 | 4% | 58.56d? | 380d | finish no earlier than 2008-10-06 | Student [16.4%]; Max [3.1%] | 95h | 3.8h | 6,000 | 240 |
| 118 | 1.3.3.1.1.2.6 | Extrasolar Planets | 52d? | 2008-10-06 A | 2008-12-16 | 14% | 44.72d? | 329d | start no earlier than 2008-10-06 | McGrath [9.6%]; Macintosh [19.2%]; Max [4.8%] | 140h | 19.6h | 9,000 | 1,260 |
| 119 | 1.3.3.1.1.2.7 | Asteroids | 52d? | 2008-05-01 | 2008-07-11 |  |  | 441d | finish no earlier than 2008-07-11 | Student [9.6%]; Le Mignant [4.8%]; Max [1.9%] | 68h |  | 4,500 |  |
| 120 | 1.3.3.1.1.2.8 | QSO Host Galaxies | 116d? | 2008-07-14 | 2008-12-22 |  |  | 325d | finish no earlier than 2008-12-22 | McGrath [6.5%]; Max [2.2%] | 80h |  | 4,500 |  |
| 121 | 1.3.3.1.1.2.9 | Backup Science - NGS & Acquisition Camera | 61d? | 2008-07-14 | 2008-10-06 |  |  | 380d | finish no earlier than 2008-10-06 | McGrath [4.1%]; Le Mignant [6.1%]; Neyman [4.1%]; Max [4.1%] | 90h |  | 5,250 |  |
| 122 | 1.3.3.1.1.3 | **Characterize PSF Stability, Knowledge & Subtraction Requirements** | 226d? | 2008-10-06 A | 2009-08-17 | 4% | 216.6d? | 155d |  |  | 1340h | 56h | 87,000 | 3,750 |
| 123 | 1.3.3.1.1.3.1 | Nearby AGNs | 226d? | 2008-10-06 A | 2009-08-17 | 9% | 205.66d? | 155d | finish no earlier than 2009-08-17 | McGrath [8.8%]; Student [19.9%]; Max [3.3%] | 580h | 52.2h | 39,000 | 3,510 |
| 124 | 1.3.3.1.1.3.2 | Galactic Center Astrometry | 97d? | 2008-10-06 A | 2009-02-17 | 2% | 95.06d? | 284d | start no earlier than 2008-10-06 | Student [20.6%]; Max [3.9%] | 190h | 3.8h | 12,000 | 240 |
| 125 | 1.3.3.1.1.3.3 | Extrasolar Planets | 96d? | 2009-01-12 | 2009-05-25 |  |  | 215d | start no earlier than 2009-01-12 | McGrath [5.2%]; Student [15.6%]; Macintosh [10.4%]; Max [2.6%] | 260h |  | 18,000 |  |
| 126 | 1.3.3.1.1.3.4 | Minor Planet Multiplicity | 36d? | 2008-10-20 | 2008-12-08 |  |  | 335d | start no earlier than 2008-10-20 | Student [27.8%]; Max [3.5%] | 90h |  | 6,000 |  |
| 127 | 1.3.3.1.1.3.5 | QSO Host Galaxies | 81d? | 2008-10-06 | 2009-01-26 |  |  | 300d | finish no earlier than 2009-01-26 | McGrath [6.2%]; Student [18.5%]; Max [9.3%] | 220h |  | 12,000 |  |
| 128 | 1.3.3.1.1.4 | Characterize Sensitivity & Background Requirements | 96d? | 2009-01-12 A | 2009-05-25 | 90% | 9.6d? | 215d | finish no earlier than 2009-05-25 | McGrath [15.6%]; Max [5.2%] | 160h | 144h | 9,000 | 8,100 |
| 129 | 1.3.3.1.1.5 | Science Requirements Summary Matrix | 165d? | 2009-05-25 A | 2010-01-08 | 16% | 138.6d? | 51d | finish no earlier than 2010-01-08 | McGrath [6.1%]; Max [1.5%] | 100h | 16h | 6,000 | 960 |
| 130 | 1.3.3.1.1.6 | SEMP Input | 75d? | 2009-10-05 | 2010-01-15 |  |  | 46d | start no earlier than 2009-10-05 | McGrath [6.7%]; Max [3.3%] | 60h |  | 3,000 |  |

Notes:
- 104: RD
- 105: CM
- 106: CM

| ID | WBS | Task | Duration | Start | Finish | Complete | Remaining | Total slack | Constraint | Resources | Work | Actual work | Cost | Actual cost |
| --- | --- | --- | --- | --- | --- | --- | --- | --- | --- | --- | --- | --- | --- | --- |
| 131 | 1.3.3.1.2 | **Science Observing Planning & Execution** | 379d? | 2008-08-04 A | 2010-01-14 | 5% | 359.97d? | 47d |  |  | 480h | 24h | 31,500 | 1,575 |
| 132 | 1.3.3.1.2.1 | Key Science Driver Observing Scenarios | 120d? | 2008-08-04 A | 2009-01-16 | 10% | 108d? | 306d | start no earlier than 2008-08-04 | McGrath [13.5%]; Le Mignant [8.3%]; Max [3.1%] | 240h | 24h | 15,750 | 1,575 |
| 133 | 1.3.3.1.2.2 | Design Reference Missions | 119d? | 2009-08-03 | 2010-01-14 |  |  | 47d | start no earlier than 2009-08-03 | McGrath [13.7%]; Le Mignant [8.5%]; Max [3.2%] | 240h |  | 15,750 |  |
| 134 | 1.3.3.1.3 | **Science Performance Input** | 315d? | 2008-10-06 A | 2009-12-18 | 15% | 266.84d? | 66d |  |  | 180h | 34h | 9,750 | 1,425 |
| 135 | 1.3.3.1.3.1 | Define Science Driver Parameters for Performance Budgets | 12d? | 2008-10-13 A | 2008-10-28 | 50% | 6d? | 364d | start no earlier than 2008-10-13 | McGrath [10.4%]; Max [10.4%] | 20h | 10h | 750 | 375 |
| 136 | 1.3.3.1.3.2 | Input to User Interfaces, Planning & Observing Tools | 300d? | 2008-10-06 A | 2009-11-27 | 5% | 285d? | 81d | finish no earlier than 2009-11-27 | McGrath [3.3%] | 80h | 4h | 6,000 | 300 |
| 137 | 1.3.3.1.3.3 | Input to Preliminary Operations Concept Document | 275d? | 2008-12-01 A | 2009-12-18 | 25% | 206.25d? | 66d | finish no earlier than 2009-12-18 | McGrath [1.8%]; Max [1.8%] | 80h | 20h | 3,000 | 750 |
| 138 | 1.3.3.1.4 | **Science Competitiveness** | 380d? | 2008-07-07 A | 2009-12-18 | 34% | 252.07d? | 66d |  |  | 144h | 53.5h | 7,800 | 2,955 |
| 139 | 1.3.3.1.4.1 | Update List of Science Goals for Other Facilities | 380d? | 2008-07-07 A | 2009-12-18 | 40% | 228d? | 66d | finish no earlier than 2009-12-18 | McGrath [1.4%]; Max [0.7%] | 64h | 25.6h | 3,300 | 1,320 |
| 140 | 1.3.3.1.4.2 | Evaluate NGAO Potential to Compliment Other Facilities | 380d? | 2008-07-07 A | 2009-12-18 | 48% | 197.6d? | 66d | finish no earlier than 2009-12-18 | McGrath [1.3%]; Max [0.3%] | 50h | 24h | 3,000 | 1,440 |
| 141 | 1.3.3.1.4.3 | Define NGAO Uniqueness Space | 380d? | 2008-07-07 A | 2009-12-18 | 13% | 330.6d? | 66d | finish no earlier than 2009-12-18 | McGrath [0.7%]; Max [0.3%] | 30h | 3.9h | 1,500 | 195 |
| 142 | 1.3.3.1.5 | **User Community Liaison** | 445d? | 2008-05-19 A | 2010-01-29 | 14% | 382.32d? | 36d |  |  | 220h | 39.2h | 5,250 | 1,035 |
| 143 | 1.3.3.1.5.1 | Enlist People to work on new NGAO Science Aspects | 358d? | 2008-05-19 A | 2009-09-30 | 7% | 332.94d? | 123d | finish no earlier than 2009-09-30 | Max [1.4%]; McGrath [0.7%] | 60h | 4.2h | 1,500 | 105 |
| 144 | 1.3.3.1.5.2 | **SSC & Keck Science Meeting** | 435d? | 2008-06-02 A | 2010-01-29 | 17% | 361.05d? | 36d |  |  | 160h | 35h | 3,750 | 930 |
| 145 | 1.3.3.1.5.2.1 | Prepare & Give Presentations | 435d? | 2008-06-02 A | 2010-01-29 | 30% | 304.5d? | 36d | finish no earlier than 2010-01-29 | Max [2%]; McGrath [1.1%] | 110h | 33h | 3,000 | 900 |
| 146 | 1.3.3.1.5.2.2 | Obtain & Document Feedback | 435d? | 2008-06-02 A | 2010-01-29 | 4% | 417.6d? | 36d | finish no earlier than 2010-01-29 | Max [1.1%]; McGrath [0.3%] | 50h | 2h | 750 | 30 |
| 147 | 1.3.3.1.6 | **Science Advisory Team Meetings** | 385d? | 2008-06-09 A | 2009-11-27 | 19% | 310.11d? | 81d |  |  | 280h | 24h | 12,000 | 1,200 |
| 148 | 1.3.3.1.6.1 | Prepare Minutes, Presentations & KAONs | 385d? | 2008-06-09 | 2009-11-27 |  |  | 81d | finish no earlier than 2009-11-27 | Max [2.6%]; McGrath [2.6%]; Le Mignant [0.6%] | 180h |  | 7,500 |  |
| 149 | 1.3.3.1.6.2 | Refine Science Requirements | 355d? | 2008-07-21 A | 2009-11-27 | 40% | 213d? | 81d | finish no earlier than 2009-11-27 | Le Mignant [0.7%] | 20h | 8h | 1,500 | 600 |
| 150 | 1.3.3.1.6.3 | Evaluate Science Impact of Proposed Changes | 355d? | 2008-07-21 A | 2009-11-27 | 20% | 284d? | 81d | finish no earlier than 2009-11-27 | Max [1.4%]; McGrath [1.4%] | 80h | 16h | 3,000 | 600 |
| 151 | 1.3.3.2 | **Requirements** | 410d? | 2008-05-26 A | 2009-12-18 | 27% | 300.59d? | 66d |  |  | 970h | 246h | 72,750 | 18,450 |
| 152 | 1.3.3.2.1 | **Operations Concept Document (OCD)** | 410d? | 2008-05-26 A | 2009-12-18 | 19% | 330.8d? | 66d |  |  | 480h | 90h | 36,000 | 6,750 |
| 153 | 1.3.3.2.1.1 | OCD Outline | 10d? | 2008-05-26 A | 2008-06-06 A | 100% |  |  | start no earlier than 2008-05-26 | Le Mignant [40%]; Wizinowich [10%] | 40h | 40h | 3,000 | 3,000 |
| 154 | 1.3.3.2.1.2 | OCD Release 1 | 45d? | 2008-12-01 A | 2009-01-30 | 25% | 33.75d? | 296d | start no earlier than 2008-12-01 | Le Mignant [33.3%]; Neyman [13.9%]; Wizinowich [2.8%]; Johansson [5.6%] | 200h | 50h | 15,000 | 3,750 |
| 155 | 1.3.3.2.1.3 | OCD Release 2 | 55d? | 2009-10-05 | 2009-12-18 |  |  | 66d | start no earlier than 2009-10-05 | Le Mignant [36.4%]; Neyman [11.4%]; Johansson [4.5%]; Wizinowich [2.3%] | 240h |  | 18,000 |  |

Notes:
- 131: CM
- 134: CM
- 138: CM
- 142: CM
- 147: CM
- 151: EJ
- 152: DLM
- 153: DLM
- 154: DLM
- 155: DLM

| ID | WBS | Task | Duration | Start | Finish | Complete | Remaining | Total slack | Constraint | Resources | Work | Actual work | Cost | Actual cost |
| --- | --- | --- | --- | --- | --- | --- | --- | --- | --- | --- | --- | --- | --- | --- |
| 156 | 1.3.3.2.2 | **System Requirements (SRD)** | 270d? | 2008-12-01 | 2009-12-11 |  |  | 71d |  |  | 80h |  | 6,000 |  |
| 157 | 1.3.3.2.2.1 | SRD Release I | 10d? | 2008-12-01 | 2008-12-12 |  |  | 331d | finish no earlier than 2008-12-12 | Johansson [62.5%] | 50h |  | 3,750 |  |
| 158 | 1.3.3.2.2.2 | SRD Release 2 | 10d? | 2009-11-30 | 2009-12-11 |  |  | 71d | finish no earlier than 2009-12-11 | Johansson [37.5%] | 30h |  | 2,250 |  |
| 159 | 1.3.3.2.3 | **Functional Requirements (FRD)** | 375d? | 2008-07-14 A | 2009-12-18 | 27% | 272.91d? | 66d |  |  | 250h | 84h | 18,750 | 6,300 |
| 160 | 1.3.3.2.3.1 | FRD Release 1 | 35d? | 2008-07-14 A | 2008-08-29 | 70% | 10.5d? | 406d | start no earlier than 2008-07-14 | Johansson [14.3%]; Dekany [10.7%]; Wizinowich [7.1%]; Gavel [10.7%] | 120h | 84h | 9,000 | 6,300 |
| 161 | 1.3.3.2.3.2 | FRD Release 2 | 35d? | 2009-11-02 | 2009-12-18 |  |  | 66d | start no earlier than 2009-11-02 | Johansson [17.9%]; Dekany [7.1%] | 70h |  | 5,250 |  |
| 162 | 1.3.3.2.3.3 | Compliance Matrix | 20d? | 2008-10-06 | 2008-10-31 |  |  | 361d | finish no earlier than 2008-10-31 | Johansson [37.5%] | 60h |  | 4,500 |  |
| 163 | 1.3.3.2.4 | Software Standards (Define & Document) | 31d? | 2008-10-06 A | 2008-11-17 | 90% | 3.1d? | 350d | start no earlier than 2008-10-06 | Johansson [32.3%] | 80h | 72h | 6,000 | 5,400 |
| 164 | 1.3.3.2.5 | Component Standards (Define & Document) | 25d? | 2008-11-03 | 2008-12-05 |  |  | 336d | finish no earlier than 2008-12-05 | Johansson [40%] | 80h |  | 6,000 |  |
| 165 | 1.3.3.3 | **Systems Engineering Analysis** | 427d? | 2008-05-01 A | 2009-12-18 | 16% | 357.69d? | 66d |  |  | 1788h | 351.9h | 134,100 | 26,392.5 |
| 166 | 1.3.3.3.1 | **Performance Budgets** | 389d? | 2008-06-24 A | 2009-12-18 | 17% | 324.81d? | 66d |  |  | 828h | 111.9h | 62,100 | 8,392.5 |
| 167 | 1.3.3.3.1.1 | Requirements Flowdown Report | 15d? | 2009-11-30 | 2009-12-18 |  |  | 66d | start no earlier than 2009-11-30 | Dekany [50%] | 60h |  | 4,500 |  |
| 168 | 1.3.3.3.1.2 | **Throughput & Background Budget** | 30d? | 2008-11-03 A | 2008-12-12 | 35% | 19.5d? | 331d |  |  | 80h | 27.5h | 6,000 | 2,062.5 |
| 169 | 1.3.3.3.1.2.1 | Thermal Background Analysis Software with Documentation | 15d? | 2008-11-03 A | 2008-11-21 | 25% | 11.25d? | 346d | finish no earlier than 2008-11-21 | Bouchez [41.7%] | 50h | 12.5h | 3,750 | 937.5 |
| 170 | 1.3.3.3.1.2.2 | Thermal Analysis | 10d? | 2008-12-01 A | 2008-12-12 | 50% | 5d? | 331d | finish no earlier than 2008-12-12 | Bouchez [37.5%] | 30h | 15h | 2,250 | 1,125 |
| 171 | 1.3.3.3.1.3 | **Wavefront & Encircled Energy** | 260d? | 2008-09-01 A | 2009-08-28 | 29% | 184.96d? | 146d |  |  | 328h | 84.4h | 24,600 | 6,330 |
| 172 | 1.3.3.3.1.3.1 | **WFE/EE Budget Tool** | 213d? | 2008-09-01 A | 2009-06-24 | 38% | 132.95d? | 193d |  |  | 256h | 82h | 19,200 | 6,150 |
| 173 | 1.3.3.3.1.3.1.1 | NGS TT & TTFA Sharpening Budgets | 31.5d? | 2008-10-06 A | 2008-11-18 | 10% | 28.35d? | 349.5d | start no earlier than 2008-10-06 | Dekany [23.8%] | 60h | 6h | 4,500 | 450 |
| 174 | 1.3.3.3.1.3.1.2 | Improved Bandwidth Model | 25d? | 2008-12-01 | 2009-01-02 |  |  | 316d | start no earlier than 2008-12-01 | Dekany [4%]; Britton [36%] | 80h |  | 6,000 |  |
| 175 | 1.3.3.3.1.3.1.3 | Improved Atmospheric Dispersion Model | 15d? | 2008-09-01 | 2008-09-19 |  |  | 391d | start no earlier than 2008-09-01 | Britton [33.3%] | 40h |  | 3,000 |  |
| 176 | 1.3.3.3.1.3.1.4 | Other (NFIRAOS budget comparison) | 38d? | 2009-05-04 A | 2009-06-24 A | 100% |  |  | start no earlier than 2009-05-04 | Dekany [25%] | 76h | 76h | 5,700 | 5,700 |
| 177 | 1.3.3.3.1.3.2 | **WFE/EE Performance Analysis** | 65d? | 2009-06-01 A | 2009-08-28 | 5% | 61.75d? | 146d |  |  | 72h | 2.4h | 5,400 | 180 |
| 178 | 1.3.3.3.1.3.2.1 | Key Science Cases Analysis | 20d? | 2009-06-01 A | 2009-06-26 | 10% | 18d? | 191d | start no earlier than 2009-06-01 | Dekany [15%] | 24h | 2.4h | 1,800 | 180 |
| 179 | 1.3.3.3.1.3.2.2 | Additional Science Case Analysis | 20d? | 2009-08-03 | 2009-08-28 |  |  | 146d | start no earlier than 2009-08-03 | Dekany [30%] | 48h |  | 3,600 |  |

Notes:
- 156: EJ
- 157: EJ
- 158: EJ
- 159: EJ
- 160: EJ
- 161: EJ
- 162: EJ
- 163: EJ
- 164: EJ
- 165: RD
- 166: RD
- 167: RD
- 168: AB
- 171: RD
- 172: RD
- 177: RD

| ID | WBS | Task | Duration | Start | Finish | Predecessors | Complete | Remaining | Total slack | Free slack | Constraint | Resources | Work | Actual work | Cost | Actual cost |
| --- | --- | --- | --- | --- | --- | --- | --- | --- | --- | --- | --- | --- | --- | --- | --- | --- |
| 180 | 1.3.3.3.1.4 | **Astrometric Precision** | 105d? | 2008-10-06 | 2009-02-27 |  |  |  | 276d |  |  |  | 200h |  | 15,000 |  |
| 181 | 1.3.3.3.1.4.1 | Develop Astrometric Budget Tool | 55d? | 2008-10-06 | 2008-12-19 |  |  |  | 326d |  | start no earlier than 2008-10-06 | Britton [13.6%]; Wizinowich [13.6%] | 120h |  | 9,000 |  |
| 182 | 1.3.3.3.1.4.2 | Galactic Center Astrometric Analysis | 40d? | 2009-01-05 | 2009-02-27 |  |  |  | 276d |  | start no earlier than 2009-01-05 | Neyman [25%] | 80h |  | 6,000 |  |
| 183 | 1.3.3.3.1.5 | **Observing Efficiency** | 266d? | 2008-06-24 | 2009-06-30 |  |  |  | 189d |  |  |  | 80h |  | 6,000 |  |
| 184 | 1.3.3.3.1.5.1 | Observing Efficiency Tool | 5d? | 2008-06-24 | 2008-06-30 |  |  |  | 450d |  | finish no earlier than 2008-06-30 | Le Mignant | 40h |  | 3,000 |  |
| 185 | 1.3.3.3.1.5.2 | Observing Efficiency Analysis | 5d? | 2009-06-24 | 2009-06-30 |  |  |  | 189d |  | finish no earlier than 2009-06-30 | Le Mignant | 40h |  | 3,000 |  |
| 186 | 1.3.3.3.1.6 | **Observing Uptime** | 250d? | 2008-12-01 | 2009-11-13 |  |  |  | 91d |  |  |  | 80h |  | 6,000 |  |
| 187 | 1.3.3.3.1.6.1 | Observing Uptime Tool | 10d? | 2008-12-01 | 2008-12-12 |  |  |  | 331d |  | start no earlier than 2008-12-01 | Johansson [50%] | 40h |  | 3,000 |  |
| 188 | 1.3.3.3.1.6.2 | Observing Uptime Analysis | 10d? | 2009-11-02 | 2009-11-13 |  |  |  | 91d |  | start no earlier than 2009-11-02 | Johansson [50%] | 40h |  | 3,000 |  |
| 189 | 1.3.3.3.2 | **Modeling & Analysis** | 247d? | 2008-05-01 A | 2009-04-10 |  | 30% | 172.37d? | 246d |  |  |  | 880h | 240h | 66,000 | 18,000 |
| 190 | 1.3.3.3.2.1 | T/T Sharpening Study Report | 42d? | 2008-05-01 A | 2008-06-27 A |  | 100% |  |  |  | start no earlier than 2008-05-01 | Dekany [23.8%]; Neyman [47.6%] | 240h | 240h | 18,000 | 18,000 |
| 191 | 1.3.3.3.2.2 | Performance vs T/T NGS Report | 32d? | 2008-09-01 | 2008-10-14 |  |  |  | 374d |  | start no earlier than 2008-09-01 | Dekany [83.3%]; Neyman [62.5%] | 240h |  | 18,000 |  |
| 192 | 1.3.3.3.2.3 | Galactic Center Performance Report | 30d? | 2009-03-02 | 2009-04-10 |  |  |  | 246d |  | start no earlier than 2009-03-02 | Dekany [50%]; Neyman [50%] | 240h |  | 18,000 |  |
| 193 | 1.3.3.3.2.4 | PSF Libraries | 35d? | 2008-11-03 | 2008-12-19 |  |  |  | 326d |  | finish no earlier than 2008-12-19 | Neyman [57.1%] | 160h |  | 12,000 |  |
| 194 | 1.3.3.3.3 | PSF Calibration | 125d? | 2009-05-04 | 2009-10-23 |  |  |  | 106d |  | start no earlier than 2009-05-04 | Le Mignant [8%] | 80h |  | 6,000 |  |
| 195 | 1.3.3.4 | **System Architecture** | 411d? | 2008-05-05 A | 2009-11-30 |  | 12% | 360.21d? | 80d |  |  |  | 1070h | 225h | 80,250 | 16,875 |
| 196 | 1.3.3.4.1 | **System Hardware Architecture** | 391d? | 2008-06-02 A | 2009-11-30 |  | 29% | 275.84d? | 80d |  |  |  | 264h | 124h | 19,800 | 9,300 |
| 197 | 1.3.3.4.1.1 | Hybrid Rayleigh / Sodium Trade Study | 65d? | 2008-06-30 A | 2008-09-26 |  | 50% | 32.5d? | 386d |  | start no earlier than 2008-06-30 | Dekany [15.4%]; Neyman [15.4%] | 160h | 80h | 12,000 | 6,000 |
| 198 | 1.3.3.4.1.2 | Degraded Laser Power Trade Study | 10d? | 2008-08-04 A | 2008-08-15 |  | 70% | 3d? | 416d |  | start no earlier than 2008-08-04 | Neyman [50%] | 40h | 28h | 3,000 | 2,100 |
| 199 | 1.3.3.4.1.3 | System Architecture: Evaluate & Document Changes | 391d? | 2008-06-02 A | 2009-11-30 |  | 25% | 293.25d? | 80d |  | start no earlier than 2008-06-02 | Dekany [2%] | 64h | 16h | 4,800 | 1,200 |
| 200 | 1.3.3.4.2 | **Software Architecture** | 308d? | 2008-07-28 A | 2009-09-30 |  | 3% | 298d? | 123d |  |  |  | 162h | 25h | 12,150 | 1,875 |
| 201 | 1.3.3.4.2.1 | Evaluate Software Architecture Options | 20d? | 2008-07-28 A | 2008-08-22 |  | 50% | 10d? | 391d | 0d | start no earlier than 2008-07-28 | Johansson [21.9%]; Morrison [9.4%] | 50h | 25h | 3,750 | 1,875 |
| 202 | 1.3.3.4.2.2 | Determine/Document Software Arch Approach | 20d? | 2008-08-25 | 2008-09-19 | 201 |  |  | 391d |  | finish no earlier than 2008-09-19 | Johansson [25%]; Morrison [25%] | 80h |  | 6,000 |  |
| 203 | 1.3.3.4.2.3 | Software Architecture: Evaluate & Document Changes | 268d? | 2008-09-22 | 2009-09-30 |  |  |  | 123d |  | start no earlier than 2008-09-22 | Johansson [1.5%] | 32h |  | 2,400 |  |

Notes:
- 180: PW
- 183: DLM
- 186: EJ
- 189: RD
- 194: DLM
- 195: RD
- 196: RD
- 200: EJ
- 201: EJ
- 202: EJ
- 203: EJ

| ID | WBS | Task | Duration | Start | Finish | Predecessors | Complete | Remaining | Total slack | Free slack | Constraint | Resources | Work | Actual work | Cost | Actual cost |
| --- | --- | --- | --- | --- | --- | --- | --- | --- | --- | --- | --- | --- | --- | --- | --- | --- |
| 204 | 1.3.3.4.3 | **Control Systems Architecture** | 261d? | 2008-10-01 A | 2009-09-30 |  | 9% | 238.2d? | 123d |  |  |  | 420h | 76h | 31,500 | 5,700 |
| 205 | 1.3.3.4.3.1 | Evaluate Control Systems Arch Options | 33d? | 2008-10-01 A | 2008-11-14 |  | 50% | 16.5d? | 315d | 0d | finish no earlier than 2008-11-14 | Johansson [30.3%] | 80h | 40h | 6,000 | 3,000 |
| 206 | 1.3.3.4.3.2 | Determine/Document Control Systems Arch | 36d? | 2008-11-17 | 2009-01-05 | 205 |  |  | 315d |  | start no earlier than 2008-11-17 | Johansson [34.7%] | 100h |  | 7,500 |  |
| 207 | 1.3.3.4.3.3 | Evaluate Motion Control Arch Options | 37d? | 2009-01-08 A | 2009-02-27 |  | 30% | 25.9d? | 256d | 0d | finish no earlier than 2009-02-27 | Johansson [20.3%]; Wetherell [20.3%] | 120h | 36h | 9,000 | 2,700 |
| 208 | 1.3.3.4.3.4 | Determine/Document Motion Control Arch | 20d? | 2009-03-02 | 2009-03-27 | 207 |  |  | 256d |  | finish no earlier than 2009-03-27 | Johansson [18.8%]; Wetherell [18.8%] | 60h |  | 4,500 |  |
| 209 | 1.3.3.4.3.5 | Control Systems Architecture: Evaluate & Document Changes | 190d? | 2009-01-08 | 2009-09-30 |  |  |  | 123d |  | start no earlier than 2009-01-08 | Johansson [2.6%]; Wetherell [1.3%] | 60h |  | 4,500 |  |
| 210 | 1.3.3.4.4 | **Operations Sequences Architecture** | 330d? | 2008-05-05 | 2009-08-07 |  |  |  | 161d |  |  |  | 224h |  | 16,800 |  |
| 211 | 1.3.3.4.4.1 | Define Required System Level Sequences | 10d? | 2008-05-05 | 2008-05-16 |  |  |  | 481d |  | start no earlier than 2008-05-05 | Le Mignant [50%] | 40h |  | 3,000 |  |
| 212 | 1.3.3.4.4.2 | Develop System Level Sequences Approach | 15d? | 2008-05-19 | 2008-06-06 |  |  |  | 466d |  | finish no earlier than 2008-06-06 | Le Mignant [33.3%] | 40h |  | 3,000 |  |
| 213 | 1.3.3.4.4.3 | Sequences Definition Document | 15d? | 2008-06-09 | 2008-06-27 |  |  |  | 451d |  | start no earlier than 2008-06-09 | Le Mignant [66.7%] | 80h |  | 6,000 |  |
| 214 | 1.3.3.4.4.4 | Sequences: Evaluate & Document Changes | 285d? | 2008-07-07 | 2009-08-07 |  |  |  | 161d |  | start no earlier than 2008-07-07 | Le Mignant [2.8%] | 64h |  | 4,800 |  |
| 215 | 1.3.3.5 | **External Interface Control** | 100d? | 2008-10-06 A | 2009-02-20 |  | 5% | 95.5d? | 281d |  |  |  | 244h | 32h | 18,300 | 2,399.97 |
| 216 | 1.3.3.5.1 | **Observatory Interfaces** | 100d? | 2008-10-06 A | 2009-02-20 |  | 16% | 83.71d? | 281d |  |  |  | 120h | 30h | 9,000 | 2,249.97 |
| 217 | 1.3.3.5.1.1 | AO System ICD | 15d? | 2009-02-02 A | 2009-02-20 |  | 25% | 11.25d? | 281d |  | finish no earlier than 2009-02-20 | Neyman [33.3%] | 40h | 10h | 3,000 | 750 |
| 218 | 1.3.3.5.1.2 | Laser System ICD | 10d? | 2008-10-06 A | 2008-10-17 |  | 25% | 7.5d? | 371d |  | finish no earlier than 2008-10-17 | Chin [12.5%]; Neyman [25%]; Adkins [12.5%] | 40h | 10h | 3,000 | 750 |
| 219 | 1.3.3.5.1.3 | Science Tools ICD | 20d? | 2008-10-06 A | 2008-10-31 |  | 5% | 18.92d? | 361d |  | finish no earlier than 2008-10-31 | Le Mignant [15.6%]; Johansson | 40h | 10h | 3,000 | 749.97 |
| 220 | 1.3.3.5.2 | **Science Instrument Interfaces to NGAO** | 40d? | 2008-10-06 A | 2008-11-28 |  | 1% | 39.71d? | 341d |  |  |  | 124h | 2h | 9,300 | 150 |
| 221 | 1.3.3.5.2.1 | Generic Science Instrument ICD to AO | 20d? | 2008-10-06 A | 2008-10-31 |  | 5% | 19d? | 361d |  | finish no earlier than 2008-10-31 | Adkins [5%]; Neyman [12.5%]; Lockwood [2.5%]; Kupke [2.5%]; Bell [2.5%] | 40h | 2h | 3,000 | 150 |
| 222 | 1.3.3.5.2.2 | Generic Science Instrument ICD to NGAO Science Tools | 20d? | 2008-10-06 | 2008-10-31 |  |  |  | 361d |  | finish no earlier than 2008-10-31 | Adkins [9.4%]; Le Mignant [9.4%]; Johansson | 40h |  | 3,000 |  |
| 223 | 1.3.3.5.2.3 | Interferometer Specific ICD | 20d? | 2008-11-03 | 2008-11-28 |  |  |  | 341d |  | finish no earlier than 2008-11-28 | Neyman [7.5%] | 12h |  | 900 |  |
| 224 | 1.3.3.5.2.4 | OSIRIS Specific ICD | 20d? | 2008-11-03 | 2008-11-28 |  |  |  | 341d |  | start no earlier than 2008-11-03 | Adkins [2.5%]; Kupke [1.2%]; Bell [1.2%] | 8h |  | 600 |  |
| 225 | 1.3.3.5.2.5 | NIR Camera Specific ICD | 20d? | 2008-11-03 | 2008-11-28 |  |  |  | 341d |  | start no earlier than 2008-11-03 | Adkins [1.2%]; Kupke [0.6%]; Lockwood [0.6%] | 4h |  | 300 |  |
| 226 | 1.3.3.5.2.6 | Visible Camera Specific ICD | 20d? | 2008-11-03 | 2008-11-28 |  |  |  | 341d |  | start no earlier than 2008-11-03 | Adkins [1.2%]; Kupke [0.6%]; Lockwood [0.6%] | 4h |  | 300 |  |
| 227 | 1.3.3.5.2.7 | d-IFS Specific ICD | 20d? | 2008-11-03 | 2008-11-28 |  |  |  | 341d |  | start no earlier than 2008-11-03 | Adkins [6.2%]; Wizinowich [2.5%]; Bell [1.2%] | 16h |  | 1,200 |  |

Notes:
- 204: EJ
- 205: EJ
- 206: EJ
- 207: EJ
- 208: EJ
- 209: EJ
- 210: DLM
- 215: CN
- 216: CN
- 217: CN
- 218: CN
- 219: DLM
- 220: SA
- 221: CN
- 222: DLM
- 223: CN
- 224: SA
- 225: SA
- 226: SA
- 227: SA

| ID | WBS | Task | Duration | Start | Finish | Complete | Remaining | Total slack | Constraint | Resources | Work | Actual work | Cost | Actual cost |
| --- | --- | --- | --- | --- | --- | --- | --- | --- | --- | --- | --- | --- | --- | --- |
| 228 | 1.3.3.6 | **Internal Interface Control** | 100d? | 2008-08-04 A | 2008-12-19 | 25% | 75d? | 326d |  |  | 280h | 70h | 21,000 | 5,250 |
| 229 | 1.3.3.6.1 | Diagram & Document Draft Outline | 40d? | 2008-08-04 A | 2008-09-26 | 25% | 30d? | 386d | finish no earlier than 2008-09-26 | Neyman [12.5%]; Wizinowich [3.1%] | 50h | 12.5h | 3,750 | 937.5 |
| 230 | 1.3.3.6.2 | Interface N-Squared Diagram | 25d? | 2008-10-06 A | 2008-11-07 | 25% | 18.75d? | 356d | start no earlier than 2008-10-06 | Neyman [20%]; Gavel [20%]; Velur [10%] | 100h | 25h | 7,500 | 1,875 |
| 231 | 1.3.3.6.3 | Interface Definition Document | 40d? | 2008-10-27 A | 2008-12-19 | 25% | 30d? | 326d | start no earlier than 2008-10-27 | Neyman [28.1%]; Gavel [6.2%]; Velur [6.2%] | 130h | 32.5h | 9,750 | 2,437.5 |
| 232 | 1.3.3.7 | **Configuration Control** | 15d? | 2009-10-05 A | 2009-10-23 | 10% | 13.49d? | 106d |  |  | 218h | 43.6h | 16,350 | 3,269.86 |
| 233 | 1.3.3.7.1 | Change Control Guidelines & Tools Definition | 15d? | 2009-10-05 A | 2009-10-23 | 10% | 13.49d? | 106d | finish no earlier than 2009-10-23 | Wetherell [60.6%]; Johansson; Gavel [50%]; Dekany [50%]; Bell | 218h | 43.6h | 16,350 | 3,269.86 |
| 234 | 1.3.3.8 | **Documentation Control** | 5d? | 2009-01-12 | 2009-01-16 |  |  | 306d |  |  | 20h |  | 1,500 |  |
| 235 | 1.3.3.8.1 | Document Control Guidelines & Tools Definition | 5d? | 2009-01-12 | 2009-01-16 |  |  | 306d | finish no earlier than 2009-01-16 | Johansson [50%] | 20h |  | 1,500 |  |
| 236 | 1.3.3.9 | **Technical Risk Assessment & Mitigation** | 250d? | 2008-09-15 A | 2009-08-28 | 23% | 192.35d? | 146d |  |  | 700h | 120h | 52,500 | 9,000 |
| 237 | 1.3.3.9.1 | **Risk Assessment** | 229.2d? | 2008-10-13 | 2009-08-28 |  |  | 146d |  |  | 100h |  | 7,500 |  |
| 238 | 1.3.3.9.1.1 | Risk Assessment v1 | 13.2d? | 2008-10-13 | 2008-10-30 |  |  | 362d | finish no earlier than 2008-10-30 | Wizinowich [28.4%]; Dekany [28.4%] | 50h |  | 3,750 |  |
| 239 | 1.3.3.9.1.2 | Risk Assessment v2 | 12d? | 2009-08-13 | 2009-08-28 |  |  | 146d | finish no earlier than 2009-08-28 | Wizinowich [31.2%]; Dekany [31.2%] | 50h |  | 3,750 |  |
| 240 | 1.3.3.9.2 | **Risk Mitigation Efforts** | 150d? | 2008-09-15 A | 2009-04-10 | 26% | 111.7d? | 246d |  |  | 600h | 120h | 45,000 | 9,000 |
| 241 | 1.3.3.9.2.1 | **PSF Calibration** | 100d? | 2008-09-15 A | 2009-01-30 | 60% | 40d? | 296d |  |  | 200h | 120h | 15,000 | 9,000 |
| 242 | 1.3.3.9.2.1.1 | Support/Monitor Profiler Implementation | 100d? | 2008-09-15 A | 2009-01-30 | 60% | 40d? | 296d | start no earlier than 2008-09-15 | Neyman [22.5%]; Wizinowich [2.5%] | 200h | 120h | 15,000 | 9,000 |
| 243 | 1.3.3.9.2.2 | **Sky Coverage** | 135d? | 2008-10-06 | 2009-04-10 |  |  | 246d |  |  | 400h |  | 30,000 |  |
| 244 | 1.3.3.9.2.2.1 | Prototype NIR Tip/tilt Sensor | 135d? | 2008-10-06 | 2009-04-10 |  |  | 246d | start no earlier than 2008-10-06 | Zolkower [12%]; Velur [12%]; Britton [13%] | 400h |  | 30,000 |  |
| 245 | 1.3.3.10 | Preliminary Design Manual | 101.67d? | 2009-08-03 | 2009-12-22 |  |  | 64.33d | start no earlier than 2009-08-03 | Wizinowich [9.8%]; Dekany [4.4%]; Gavel [2.2%]; Reinig [0.2%]; Velur [0.4%]; Neyman [0.2%]; Le Mignant [0.4%]; Johansson [0.4%]; Kupke [0.2%]; Lockwood [0.2%] | 120h |  | 9,000 |  |
| 246 | 1.3.4 | **AO System Design** | 425d? | 2008-05-12 A | 2009-12-25 | 15% | 360.92d? | 61d |  |  | 10757h | 1431.3h | 806,774.97 | 107,347.44 |
| 247 | 1.3.4.1 | AO Enclosure | 130d? | 2008-10-01 | 2009-03-31 |  |  | 254d | finish no earlier than 2009-03-31 | Bell [28.8%] | 300h |  | 22,500 |  |
| 248 | 1.3.4.2 | **Opto-Mechanical** | 371d? | 2008-06-02 A | 2009-11-02 | 14% | 317.53d? | 100d |  |  | 5405h | 601.5h | 405,374.97 | 45,112.5 |
| 249 | 1.3.4.2.1 | AO Support Structure | 50d? | 2008-11-03 A | 2009-01-09 | 40% | 30d? | 311d | start no earlier than 2008-11-03 | Lockwood [36%]; Gavel [4%] | 160h | 64h | 12,000 | 4,800 |
| 250 | 1.3.4.2.2 | Rotator | 13d? | 2009-03-12 A | 2009-03-30 | 20% | 10.4d? | 255d | start no earlier than 2009-03-12 | Lockwood [86.5%]; Kupke [17.3%]; Gavel [11.5%] | 120h | 24h | 9,000 | 1,800 |
| 251 | 1.3.4.2.3 | Optical Relays | 80d? | 2008-12-29 A | 2009-04-17 | 50% | 40d? | 241d | start no earlier than 2008-12-28 | Lockwood [30.2%]; Kupke [45.3%]; Gavel [7.8%] | 533h | 266.5h | 39,975 | 19,987.5 |
| 252 | 1.3.4.2.4 | Optical Switchyard | 70d? | 2008-08-04 A | 2008-11-07 | 20% | 56d? | 356d | start no earlier than 2008-08-04 | Lockwood [38.6%]; Kupke [25.7%]; Gavel [7.1%] | 400h | 80h | 30,000 | 6,000 |

Notes:
- 228: CN
- 229: CN
- 230: CN
- 231: CN
- 232: EJ
- 233: EJ
- 234: EJ
- 235: EJ
- 236: PW
- 237: PW
- 238: PW
- 239: PW
- 240: PW
- 242: CN
- 244: VV
- 245: PW
- 246: DG
- 247: JB
- 248: DG
- 249: CL
- 250: CL
- 251: RK
- 252: RK

| ID | WBS | Task | Duration | Start | Finish | Predecessors | Complete | Remaining | Total slack | Free slack | Constraint | Resources | Work | Actual work | Cost | Actual cost |
| --- | --- | --- | --- | --- | --- | --- | --- | --- | --- | --- | --- | --- | --- | --- | --- | --- |
| 253 | 1.3.4.2.5 | **LGS Wavefront Sensor Assembly** | 202d? | 2008-06-02 A | 2009-03-10 |  | 2% | 198.08d? | 269d |  |  |  | 1520h | 24h | 113,999.98 | 1,800 |
| 254 | 1.3.4.2.5.1 | Review concept design for LGS WFS assembly (includes OSM) | 20d? | 2008-06-02 A | 2008-06-27 |  | 20% | 16d? | 269d | 0d | start no earlier than 2008-06-02 | Zolkower [25%]; Britton [25%]; Velur [25%] | 120h | 24h | 9,000 | 1,800 |
| 255 | 1.3.4.2.5.2 | Develop to preliminary design level the opto-mechanical design for the LGS wavefront sensor unit. | 70d? | 2008-06-30 | 2008-10-03 | 254 |  |  | 269d | 0d |  | Zolkower [25%]; Velur [25%]; Britton [25%] | 420h |  | 31,500 |  |
| 256 | 1.3.4.2.5.3 | Identify the issues with uplink TTM, asterism generation and OSM concepts to ensure it conforms to the dithering requirements. This is important when the LGSs have to move with the source | 19.25d? | 2008-10-06 | 2008-10-31 | 255 |  |  | 269d | 0d |  | Velur [18.7%]; Britton [50%] | 100h |  | 7,499.98 |  |
| 257 | 1.3.4.2.5.4 | Develop to preliminary design level the opto-mechanical design for the LGS OSM. (overlaps with TT(FA) OSMs; hence costed there) | 10d? | 2008-11-03 | 2008-11-14 | 256 |  |  | 269d | 0d | start no earlier than 2008-09-15 | Zolkower [25%]; Velur [25%] | 40h |  | 3,000 |  |
| 258 | 1.3.4.2.5.5 | Package and model the assembly. | 20d? | 2008-11-17 | 2008-12-25 | 257 |  |  | 269d | 0d |  | Zolkower [50%]; Velur [75%] | 200h |  | 15,000 |  |
| 259 | 1.3.4.2.5.6 | Develop background model and work out stray LGS light problems. | 13.33d? | 2008-12-25 | 2009-01-13 | 258 |  |  | 309.33d |  |  | Britton [75%] | 80h |  | 6,000 |  |
| 260 | 1.3.4.2.5.7 | Identify the motion control needs and specify solutions. | 20d? | 2008-12-25 | 2009-01-22 | 258 |  |  | 269d | 0d |  | Johansson [50%]; Hale [50%]; Velur [50%] | 240h |  | 18,000 |  |
| 261 | 1.3.4.2.5.8 | Identify design risks and mitigation of the identified risks. | 4.5d? | 2009-01-22 | 2009-01-28 | 260 |  |  | 269d | 0d |  | Zolkower [75%]; Britton [75%]; Velur [75%] | 80h |  | 6,000 |  |
| 262 | 1.3.4.2.5.9 | Develop a preliminary integration plan for the assembly. | 9.17d? | 2009-01-28 | 2009-02-10 | 261 |  |  | 269d | 0d |  | Britton [34.1%]; Zolkower [34.1%]; Velur [40.9%] | 80h |  | 6,000 |  |
| 263 | 1.3.4.2.5.10 | LGS WFS Assembly Documentation | 20d? | 2009-02-11 | 2009-03-10 | 262 |  |  | 269d |  |  | Zolkower [50%]; Velur [50%] | 160h |  | 12,000 |  |
| 264 | 1.3.4.2.6 | **NGS WFS/TWFS Assembly** | 143d? | 2009-04-16 | 2009-11-02 |  |  |  | 100d |  |  |  | 628h |  | 47,100 |  |
| 265 | 1.3.4.2.6.1 | Review concept design for NGS WFS and TWFS; jointly called NGS WFS assembly. | 10d? | 2009-04-16 | 2009-04-29 |  |  |  | 128.5d | 0d |  | Zolkower [25%]; Britton [25%] | 40h |  | 3,000 |  |
| 266 | 1.3.4.2.6.2 | Develop to preliminary design level the opto-mechanical design for the NGS wavefront sensor assembly. | 28d? | 2009-04-30 | 2009-06-08 | 265 |  |  | 128.5d | 0d | start no earlier than 2009-01-19 | Zolkower [44.6%]; Velur [44.6%] | 200h |  | 15,000 |  |
| 267 | 1.3.4.2.6.3 | Check compliance of design with the design of the field steering mirror assembly. | 14d? | 2009-06-09 | 2009-06-26 | 266 |  |  | 128.5d | 0d |  | Velur [44.6%]; Zolkower [44.6%] | 100h |  | 7,500 |  |
| 268 | 1.3.4.2.6.4 | Package and model the NGS WFS assembly. | 18d? | 2009-06-29 | 2009-08-20 | 267 |  |  | 128.5d | 0d |  | Zolkower [40.3%]; Velur [40.3%] | 116h |  | 8,700 |  |
| 269 | 1.3.4.2.6.5 | Identify the motion control needs and specify solutions. | 7d? | 2009-08-21 | 2009-08-31 | 268 |  |  | 128.5d | 0d |  | Hale [50%]; Johansson [50%] | 56h |  | 4,200 |  |
| 270 | 1.3.4.2.6.6 | Identify design risks and mitigation of the identified risks. | 4.67d? | 2009-09-01 | 2009-09-07 | 269 |  |  | 128.5d | 0d |  | Velur [75%] | 28h |  | 2,100 |  |
| 271 | 1.3.4.2.6.7 | Check compliance with alignment plan for the NGS OSM (written as part of opto-mechanical relay sub-system design effort). | 4.83d? | 2009-09-07 | 2009-09-14 | 270 |  |  | 128.5d | 28.5d |  | Zolkower [41.4%]; Velur [41.4%] | 32h |  | 2,400 |  |
| 272 | 1.3.4.2.6.8 | NGS WFS Assembly Documentation | 7d? | 2009-10-23 | 2009-11-02 | 271 |  |  | 100d |  | finish no earlier than 2009-11-02 | Velur [50%]; Zolkower [50%] | 56h |  | 4,200 |  |
| 273 | 1.3.4.2.7 | **Low Order Wavefront Sensor Assembly** | 321d? | 2008-08-11 A | 2009-11-02 |  | 6% | 301.19d? | 100d |  |  |  | 1596h | 32h | 119,700 | 2,400 |
| 274 | 1.3.4.2.7.1 | Review concept design for LOWFS assembly. | 26.67d? | 2008-08-11 A | 2008-09-16 |  | 50% | 13.33d? | 148d | 0d | start no earlier than 2008-08-11 | Zolkower [15%]; Hale [15%] | 64h | 32h | 4,800 | 2,400 |
| 275 | 1.3.4.2.7.2 | Investigate optimum method of dithering based on requirements. | 25.33d? | 2008-09-16 | 2008-10-21 | 274 |  |  | 148d | 2d |  | Hale [17.8%]; Dekany [17.8%]; Britton [19.7%] | 112h |  | 8,400 |  |
| 276 | 1.3.4.2.7.3 | Develop to preliminary design level the opto-mechanical design for the tip-tilt and the TTFA-TWFS wavefront sensor units | 24d? | 2009-01-12 | 2009-02-12 | 275 |  |  | 147d | 0d |  | Hale [50%]; Zolkower [50%]; Dekany [25%] | 240h |  | 18,000 |  |
| 277 | 1.3.4.2.7.4 | Develop to preliminary design level the opto-mechanical design for the LOWFS OSM | 13.33d? | 2009-02-13 | 2009-03-04 | 276 |  |  | 147d | 0d |  | Hale [75%]; Zolkower [75%]; Velur [75%] | 240h |  | 18,000 |  |
| 278 | 1.3.4.2.7.5 | Make sure that the design doesn't preclude the inclusion of a PSF monitor later | 3.33d? | 2009-03-04 | 2009-03-09 | 277 |  |  | 147d | 0d |  | Velur [75%] | 20h |  | 1,500 |  |
| 279 | 1.3.4.2.7.6 | Package and model the assembly. | 13.33d? | 2009-03-09 | 2009-03-26 | 278 |  |  | 147d | 0d |  | Zolkower [75%]; Velur [75%] | 160h |  | 12,000 |  |
| 280 | 1.3.4.2.7.7 | Develop thermal model and work emissivity details of the LOWFS assembly and feed into the overall emissivity budget | 10d? | 2009-03-27 | 2009-04-09 | 279 |  |  | 147d | 0d |  | Zolkower [50%] | 40h |  | 3,000 |  |
| 281 | 1.3.4.2.7.8 | Identify the motion control needs and specify solutions. | 60d? | 2009-04-10 | 2009-07-02 | 280 |  |  | 147d | 0d |  | Johansson [25%]; Hale [25%]; Velur [25%] | 360h |  | 27,000 |  |
| 282 | 1.3.4.2.7.9 | Identify design risks and mitigation of the identified risks. | 10d? | 2009-07-03 | 2009-07-16 | 281 |  |  | 147d | 0d |  | Hale [50%]; Velur [50%] | 80h |  | 6,000 |  |
| 283 | 1.3.4.2.7.10 | Develop a preliminary integration plan for the assembly. | 13.33d? | 2009-07-17 | 2009-08-05 | 282 |  |  | 147d | 0d |  | Velur [75%] | 80h |  | 6,000 |  |
| 284 | 1.3.4.2.7.11 | Develop a test plan based on the design to test performance | 10d? | 2009-08-05 | 2009-08-19 | 283 |  |  | 147d | 47d |  | Hale [75%]; Velur [75%] | 120h |  | 9,000 |  |
| 285 | 1.3.4.2.7.12 | LOWFS Assembly Documentation | 6.67d? | 2009-10-23 | 2009-11-02 | 284 |  |  | 100d |  | finish no earlier than 2009-11-02 | Hale [75%]; Velur [75%] | 80h |  | 6,000 |  |

Notes:
- 253: VV
- 264: VV
- 273: VV

| ID | WBS | Task | Duration | Start | Finish | Complete | Remaining | Total slack | Constraint | Resources | Work | Actual work | Cost | Actual cost |
| --- | --- | --- | --- | --- | --- | --- | --- | --- | --- | --- | --- | --- | --- | --- |
| 286 | 1.3.4.2.8 | **Tip/Tilt Vibration Mitigation** | 40d? | 2008-07-07 A | 2008-08-29 | 50% | 20d? | 406d |  |  | 80h | 40h | 6,000 | 3,000 |
| 287 | 1.3.4.2.8.1 | TT Vibration Mitigation Analysis | 40d? | 2008-07-07 A | 2008-08-29 | 50% | 20d? | 406d | start no earlier than 2008-07-07 | Neyman [25%] | 80h | 40h | 6,000 | 3,000 |
| 288 | 1.3.4.2.9 | **Acquisition Cameras** | 305d? | 2008-09-01 | 2009-10-30 |  |  | 101d |  |  | 128h |  | 9,600 |  |
| 289 | 1.3.4.2.9.1 | Implementation Issues | 20d? | 2008-09-01 | 2008-09-26 |  |  | 386d | start no earlier than 2008-09-01 | Neyman [12.5%]; Le Mignant [12.5%] | 40h |  | 3,000 |  |
| 290 | 1.3.4.2.9.2 | Opto-Mechanical Design | 20d? | 2009-10-01 | 2009-10-30 |  |  | 101d | start no earlier than 2009-10-01 | Neyman [35%]; Panteleev [10%]; Lockwood [10%] | 88h |  | 6,600 |  |
| 291 | 1.3.4.2.10 | **Atmospheric Dispersion Correctors** | 96d? | 2008-10-17 A | 2009-02-27 | 28% | 69.6d? | 276d |  |  | 240h | 71h | 18,000 | 5,325 |
| 292 | 1.3.4.2.10.1 | LOWFS ADCs | 10d? | 2008-10-17 A | 2008-10-30 | 40% | 6d? | 362d | finish no earlier than 2008-10-30 | Kupke; Lockwood [75%] | 140h | 56h | 10,500 | 4,200 |
| 293 | 1.3.4.2.10.2 | NIR Science ADC | 5d? | 2008-12-24 A | 2008-12-30 | 15% | 4.25d? | 319d | finish no earlier than 2008-12-30 | Kupke; Lockwood [25%] | 50h | 7.5h | 3,750 | 562.5 |
| 294 | 1.3.4.2.10.3 | Visible Science & NGS WFS ADC | 5d? | 2009-02-23 A | 2009-02-27 | 15% | 4.25d? | 276d | finish no earlier than 2009-02-27 | Kupke; Lockwood [25%] | 50h | 7.5h | 3,750 | 562.5 |
| 295 | 1.3.4.3 | **Alignment, Calibration & Diagnostics** | 90d? | 2009-02-02 | 2009-06-05 |  |  | 206d |  |  | 505h |  | 37,875 |  |
| 296 | 1.3.4.3.1 | **Simulator** | 45d? | 2009-02-02 | 2009-04-03 |  |  | 251d |  |  | 250h |  | 18,750 |  |
| 297 | 1.3.4.3.1.1 | Simulator Requirements & Interfaces | 10d? | 2009-02-02 | 2009-02-13 |  |  | 286d | finish no earlier than 2009-02-13 | Neyman [50%]; Wizinowich [12.5%] | 50h |  | 3,750 |  |
| 298 | 1.3.4.3.1.2 | Simulator Optical Design | 10d? | 2009-02-16 | 2009-02-27 |  |  | 276d | finish no earlier than 2009-02-27 | Neyman [12.5%]; Wizinowich [50%] | 50h |  | 3,750 |  |
| 299 | 1.3.4.3.1.3 | Simulator Mechanical Design | 10d? | 2009-03-02 | 2009-03-13 |  |  | 266d | finish no earlier than 2009-03-13 | Neyman [12.5%]; Bell [62.5%] | 60h |  | 4,500 |  |
| 300 | 1.3.4.3.1.4 | Simulator Electrical Design | 10d? | 2009-03-09 | 2009-03-20 |  |  | 261d | finish no earlier than 2009-03-20 | Neyman [25%]; Wetherell [37.5%] | 50h |  | 3,750 |  |
| 301 | 1.3.4.3.1.5 | Simulator Assembly, Alignment & Test Plans | 10d? | 2009-03-23 | 2009-04-03 |  |  | 251d | start no earlier than 2009-03-23 | Neyman [50%] | 40h |  | 3,000 |  |
| 302 | 1.3.4.3.2 | **System Alignment Tools** | 45d? | 2009-04-06 | 2009-06-05 |  |  | 206d |  |  | 255h |  | 19,125 |  |
| 303 | 1.3.4.3.2.1 | Alignment Requirements & Interfaces | 10d? | 2009-04-06 | 2009-04-17 |  |  | 241d | finish no earlier than 2009-04-17 | Neyman [50%]; Kupke [12.5%]; Wizinowich [12.5%] | 60h |  | 4,500 |  |
| 304 | 1.3.4.3.2.2 | Alignment Optical Design | 10d? | 2009-04-20 | 2009-05-01 |  |  | 231d | finish no earlier than 2009-05-01 | Neyman [12.5%]; Kupke [50%] | 50h |  | 3,750 |  |
| 305 | 1.3.4.3.2.3 | Alignment Mechanical Design | 10d? | 2009-05-04 | 2009-05-15 |  |  | 221d | finish no earlier than 2009-05-15 | Neyman [12.5%]; Lockwood [50%] | 50h |  | 3,750 |  |
| 306 | 1.3.4.3.2.4 | Alignment Electrical Design | 10d? | 2009-05-11 | 2009-05-22 |  |  | 216d | finish no earlier than 2009-05-22 | Neyman [25%]; Wetherell [18.8%] | 35h |  | 2,625 |  |
| 307 | 1.3.4.3.2.5 | Alignment Assembly, Alignment & Test Plans | 10d? | 2009-05-25 | 2009-06-05 |  |  | 206d | finish no earlier than 2009-06-05 | Neyman [50%]; Kupke [12.5%]; Wizinowich [12.5%] | 60h |  | 4,500 |  |
| 308 | 1.3.4.4 | **Non-real-time Control** | 130d? | 2009-01-19 A | 2009-07-17 |  | 129.61d? | 176d |  |  | 990h | 8h | 74,250 | 600 |
| 309 | 1.3.4.4.1 | AO Controls Infrastructure | 1d? | 2009-02-02 | 2009-02-02 |  |  | 295d | start no earlier than 2009-02-02 |  |  |  |  |  |

Notes:
- 286: CN
- 288: CN
- 291: RK
- 295: CN
- 296: CN
- 302: CN
- 308: EJ

| ID | WBS | Task | Type | Duration | Start | Finish | Complete | Remaining | Total slack | Constraint | Resources | Work | Actual work | Cost | Actual cost |
| --- | --- | --- | --- | --- | --- | --- | --- | --- | --- | --- | --- | --- | --- | --- | --- |
| 310 | 1.3.4.4.2 | **AO Sequencer** |  | 20d? | 2009-02-02 A | 2009-02-27 | 3% | 19.5d? | 276d |  |  | 140h | 8h | 10,500 | 600 |
| 311 | 1.3.4.4.2.1 | AO Sequencer: Architecture |  | 20d? | 2009-02-02 A | 2009-02-27 | 10% | 18d? | 276d | finish no earlier than 2009-02-27 | Johansson [50%] | 80h | 8h | 6,000 | 600 |
| 312 | 1.3.4.4.2.2 | AO Sequencer: Interface Control Document |  | 20d? | 2009-02-02 | 2009-02-27 |  |  | 276d | finish no earlier than 2009-02-27 | Johansson [12.5%] | 20h |  | 1,500 |  |
| 313 | 1.3.4.4.2.3 | AO Sequencer: Software Module Design |  | 20d? | 2009-02-02 | 2009-02-27 |  |  | 276d | finish no earlier than 2009-02-27 | Johansson [18.8%] | 30h |  | 2,250 |  |
| 314 | 1.3.4.4.2.4 | AO Sequencer: User Interface Design | milestone | 0d? | 2009-02-02 | 2009-02-02 |  |  | 296d | start no earlier than 2009-02-02 |  |  |  |  |  |
| 315 | 1.3.4.4.2.5 | AO Sequencer: Technical Specifications | milestone | 0d? | 2009-02-02 | 2009-02-02 |  |  | 296d | start no earlier than 2009-02-02 |  |  |  |  |  |
| 316 | 1.3.4.4.2.6 | AO Sequencer: Compliance Matrix | milestone | 0d? | 2009-02-02 | 2009-02-02 |  |  | 296d | start no earlier than 2009-02-02 |  |  |  |  |  |
| 317 | 1.3.4.4.2.7 | AO Sequencer: Test Plan | milestone | 0d? | 2009-02-02 | 2009-02-02 |  |  | 296d | start no earlier than 2009-02-02 |  |  |  |  |  |
| 318 | 1.3.4.4.2.8 | AO Sequencer: Summary Report |  | 20d? | 2009-02-02 | 2009-02-27 |  |  | 276d | finish no earlier than 2009-02-27 | Johansson [6.2%] | 10h |  | 750 |  |
| 319 | 1.3.4.4.3 | **AO Motion Control Software** |  | 40d? | 2009-03-02 | 2009-04-24 |  |  | 236d |  |  | 230h |  | 17,250 |  |
| 320 | 1.3.4.4.3.1 | Motion Control SW: Architecture |  | 40d? | 2009-03-02 | 2009-04-24 |  |  | 236d | start no earlier than 2009-03-02 | Johansson [15.6%]; Morrison [9.4%] | 80h |  | 6,000 |  |
| 321 | 1.3.4.4.3.2 | Motion Control SW: ICD |  | 40d? | 2009-03-02 | 2009-04-24 |  |  | 236d | start no earlier than 2009-03-02 | Johansson [6.2%]; Morrison [6.2%] | 40h |  | 3,000 |  |
| 322 | 1.3.4.4.3.3 | Motion Control SW: Module Design |  | 40d? | 2009-03-02 | 2009-04-24 |  |  | 236d | start no earlier than 2009-03-02 | Johansson [6.2%]; Morrison [21.9%] | 90h |  | 6,750 |  |
| 323 | 1.3.4.4.3.4 | Motion Control SW: User Interface Design | milestone | 0d? | 2009-03-02 | 2009-03-02 |  |  | 276d | start no earlier than 2009-03-02 |  |  |  |  |  |
| 324 | 1.3.4.4.3.5 | Motion Control SW: Technical Specifications | milestone | 0d? | 2009-03-02 | 2009-03-02 |  |  | 276d | start no earlier than 2009-03-02 |  |  |  |  |  |
| 325 | 1.3.4.4.3.6 | Motion Control SW: Compliance Matrix | milestone | 0d? | 2009-03-02 | 2009-03-02 |  |  | 276d | start no earlier than 2009-03-02 |  |  |  |  |  |
| 326 | 1.3.4.4.3.7 | Motion Control SW: Test Plan | milestone | 0d? | 2009-03-02 | 2009-03-02 |  |  | 276d | start no earlier than 2009-03-02 |  |  |  |  |  |
| 327 | 1.3.4.4.3.8 | Motion Control SW: Summary Report |  | 40d? | 2009-03-02 | 2009-04-24 |  |  | 236d | finish no earlier than 2009-04-24 | Johansson [6.2%] | 20h |  | 1,500 |  |
| 328 | 1.3.4.4.4 | **AO Device Control Software** |  | 55d? | 2009-05-04 | 2009-07-17 |  |  | 176d |  |  | 240h |  | 18,000 |  |
| 329 | 1.3.4.4.4.1 | Device Control: Software Architecture |  | 20d? | 2009-05-04 | 2009-05-29 |  |  | 211d | finish no earlier than 2009-05-29 | Morrison [50%] | 80h |  | 6,000 |  |
| 330 | 1.3.4.4.4.2 | Device Control: Interface Control Document |  | 15d? | 2009-05-25 | 2009-06-12 |  |  | 201d | finish no earlier than 2009-06-12 | Morrison [33.3%] | 40h |  | 3,000 |  |
| 331 | 1.3.4.4.4.3 | Device Control: Software Module Design |  | 25d? | 2009-06-15 | 2009-07-17 |  |  | 176d | finish no earlier than 2009-07-17 | Morrison [50%] | 100h |  | 7,500 |  |
| 332 | 1.3.4.4.4.4 | Device Control: User Interface Design | milestone | 0d? | 2009-06-15 | 2009-06-15 |  |  | 201d | start no earlier than 2009-06-15 |  |  |  |  |  |
| 333 | 1.3.4.4.4.5 | Device Control: Technical Specifications | milestone | 0d? | 2009-06-15 | 2009-06-15 |  |  | 201d | start no earlier than 2009-06-15 |  |  |  |  |  |
| 334 | 1.3.4.4.4.6 | Device Control: Compliance Matrix | milestone | 0d? | 2009-06-15 | 2009-06-15 |  |  | 201d | start no earlier than 2009-06-15 |  |  |  |  |  |
| 335 | 1.3.4.4.4.7 | Device Control: Test Plan | milestone | 0d? | 2009-06-15 | 2009-06-15 |  |  | 201d | start no earlier than 2009-06-15 |  |  |  |  |  |
| 336 | 1.3.4.4.4.8 | Device Control: Summary Report |  | 25d? | 2009-06-15 | 2009-07-17 |  |  | 176d | finish no earlier than 2009-07-17 | Morrison [10%] | 20h |  | 1,500 |  |

Notes:
- 310: EJ
- 319: EJ
- 328: DM

| ID | WBS | Task | Type | Duration | Start | Finish | Complete | Remaining | Total slack | Constraint | Resources | Work | Actual work | Cost | Actual cost |
| --- | --- | --- | --- | --- | --- | --- | --- | --- | --- | --- | --- | --- | --- | --- | --- |
| 337 | 1.3.4.4.5 | **AO Motion Control Electronics** |  | 30d? | 2009-01-19 | 2009-02-27 |  |  | 276d |  |  | 60h |  | 4,500 |  |
| 338 | 1.3.4.4.5.1 | Motion Control HW: Spreadsheet |  | 30d? | 2009-01-19 | 2009-02-27 |  |  | 276d | finish no earlier than 2009-02-27 | Wetherell [25%] | 60h |  | 4,500 |  |
| 339 | 1.3.4.4.6 | **Non-RTC Electronics** |  | 40d? | 2009-04-06 | 2009-05-29 |  |  | 211d |  |  | 160h |  | 12,000 |  |
| 340 | 1.3.4.4.6.1 | Non-RTC Electronics: Architecture |  | 40d? | 2009-04-06 | 2009-05-29 |  |  | 211d | finish no earlier than 2009-05-29 | Wetherell [25%] | 80h |  | 6,000 |  |
| 341 | 1.3.4.4.6.2 | Non-RTC Electronics: Selection/Specification |  | 40d? | 2009-04-06 | 2009-05-29 |  |  | 211d | start no earlier than 2009-04-06 | Wetherell [18.8%] | 60h |  | 4,500 |  |
| 342 | 1.3.4.4.6.3 | Non-RTC Electronics: Compliance Matrix |  | 1d? | 2009-04-06 | 2009-04-06 |  |  | 250d | start no earlier than 2009-04-06 |  |  |  |  |  |
| 343 | 1.3.4.4.6.4 | Non-RTC Electronics: Test Plan |  | 1d? | 2009-04-06 | 2009-04-06 |  |  | 250d | start no earlier than 2009-04-06 |  |  |  |  |  |
| 344 | 1.3.4.4.6.5 | Non-RTC Electronics: Documentation |  | 40d? | 2009-04-06 | 2009-05-29 |  |  | 211d | start no earlier than 2009-04-06 | Wetherell [6.2%] | 20h |  | 1,500 |  |
| 345 | 1.3.4.4.7 | **Non-RTC Lab System Integration & Test** |  | 0d? | 2009-02-02 | 2009-02-02 |  |  | 296d |  |  |  |  |  |  |
| 346 | 1.3.4.4.7.1 | Non-RTC I&T: Architecture | milestone | 0d? | 2009-02-02 | 2009-02-02 |  |  | 296d | start no earlier than 2009-02-02 |  |  |  |  |  |
| 347 | 1.3.4.4.7.2 | Non-RTC I&T: Electronics Specification & Selection | milestone | 0d? | 2009-02-02 | 2009-02-02 |  |  | 296d | start no earlier than 2009-02-02 |  |  |  |  |  |
| 348 | 1.3.4.4.7.3 | Non-RTC I&T: Test Plan | milestone | 0d? | 2009-02-02 | 2009-02-02 |  |  | 296d | start no earlier than 2009-02-02 |  |  |  |  |  |
| 349 | 1.3.4.4.7.4 | Non-RTC I&T: Summary Report | milestone | 0d? | 2009-02-02 | 2009-02-02 |  |  | 296d | start no earlier than 2009-02-02 |  |  |  |  |  |
| 350 | 1.3.4.4.8 | **Acquisition, Guiding & Offload (AGO) Control** |  | 47d? | 2009-04-27 | 2009-06-30 |  |  | 189d |  |  | 160h |  | 12,000 |  |
| 351 | 1.3.4.4.8.1 | AGO: Architecture |  | 47d? | 2009-04-27 | 2009-06-30 |  |  | 189d | finish no earlier than 2009-06-30 | Johansson [16%]; Le Mignant | 80h |  | 6,000 |  |
| 352 | 1.3.4.4.8.2 | AGO: ICD |  | 47d? | 2009-04-27 | 2009-06-30 |  |  | 189d | start no earlier than 2009-04-27 | Johansson [10.6%] | 40h |  | 3,000 |  |
| 353 | 1.3.4.4.8.3 | AGO: Software Module Design |  | 47d? | 2009-04-27 | 2009-06-30 |  |  | 189d | start no earlier than 2009-04-27 | Johansson [5.3%] | 20h |  | 1,500 |  |
| 354 | 1.3.4.4.8.4 | AGO: User Interface | milestone | 0d? | 2009-04-27 | 2009-04-27 |  |  | 236d | start no earlier than 2009-04-27 |  |  |  |  |  |
| 355 | 1.3.4.4.8.5 | AGO: Technical Specification | milestone | 0d? | 2009-04-27 | 2009-04-27 |  |  | 236d | start no earlier than 2009-04-27 |  |  |  |  |  |
| 356 | 1.3.4.4.8.6 | AGO: Compliance Matrix | milestone | 0d? | 2009-04-27 | 2009-04-27 |  |  | 236d | start no earlier than 2009-04-27 |  |  |  |  |  |
| 357 | 1.3.4.4.8.7 | AGO: Test Plan | milestone | 0d? | 2009-04-27 | 2009-04-27 |  |  | 236d | start no earlier than 2009-04-27 |  |  |  |  |  |
| 358 | 1.3.4.4.8.8 | AGO: Summary Report |  | 47d? | 2009-04-27 | 2009-06-30 |  |  | 189d | finish no earlier than 2009-06-30 | Johansson [5.3%] | 20h |  | 1,500 |  |
| 359 | 1.3.4.5 | **Real-time Control** |  | 425d? | 2008-05-12 A | 2009-12-25 | 25% | 316.87d? | 61d |  |  | 3357h | 821.8h | 251,775 | 61,634.94 |
| 360 | 1.3.4.5.1 | **RTC Processor** |  | 425d? | 2008-05-12 A | 2009-12-25 | 27% | 311.39d? | 61d |  |  | 3037h | 768.6h | 227,775 | 57,644.99 |
| 361 | 1.3.4.5.1.1 | RTC Technical Management |  | 3400h? | 2008-05-12 A | 2009-12-25 | 30% | 2380h? | 61d | start no earlier than 2008-05-12 | Reinig [9.2%]; Gavel [4.4%] | 463h | 138.9h | 34,725 | 10,417.5 |
| 362 | 1.3.4.5.1.2 | Centroid/Wavefront Reconstruction Processing Requirements |  | 105d? | 2008-05-12 A | 2008-10-03 | 30% | 73.5d? | 381d | start no earlier than 2008-05-12 | Electrical Engineer / Programmer [37.4%] | 314h | 94.2h | 23,550 | 7,065 |
| 363 | 1.3.4.5.1.3 | Centroid/Wavefront Reconstruction Test Definition |  | 47d? | 2008-09-08 | 2008-11-11 |  |  | 354d | start no earlier than 2008-09-08 | Electrical Engineer / Programmer [23.9%] | 90h |  | 6,750 |  |
| 364 | 1.3.4.5.1.4 | Preconditioning & Scaling Processing Requirements |  | 75d? | 2008-10-06 A | 2009-01-16 A | 100% |  |  | start no earlier than 2008-10-06 | Electrical Engineer / Programmer [51.7%] | 310h | 310h | 23,250 | 23,250 |
| 365 | 1.3.4.5.1.5 | Preconditioning & Scaling Processing Test Definition |  | 30d? | 2008-12-29 | 2009-02-06 |  |  | 291d | start no earlier than 2008-12-28 | Electrical Engineer / Programmer [37.5%] | 90h |  | 6,750 |  |
| 366 | 1.3.4.5.1.6 | Low Order WFS Processing Requirements |  | 65d? | 2009-02-09 | 2009-05-08 |  |  | 226d | start no earlier than 2009-02-08 | Electrical Engineer / Programmer [59.6%] | 310h |  | 23,250 |  |
| 367 | 1.3.4.5.1.7 | Low Order WFS Processing Test Definition |  | 11.25d? | 2009-05-18 | 2009-06-02 |  |  | 209.75d | start no earlier than 2009-05-17 | Electrical Engineer / Programmer | 90h |  | 6,750 |  |
| 368 | 1.3.4.5.1.8 | Layer Combining & DM Processing Requirements |  | 41d? | 2009-06-01 | 2009-07-27 |  |  | 170d | start no earlier than 2009-05-31 | Electrical Engineer / Programmer [94.5%] | 310h |  | 23,250 |  |
| 369 | 1.3.4.5.1.9 | Camera Data Transfer Issues |  | 24.19d? | 2009-07-27 A | 2009-08-28 | 35% | 15.73d? | 146.81d | start no earlier than 2009-07-26 | Electrical Engineer / Programmer [46.5%] | 90h | 31.5h | 6,750 | 2,362.49 |
| 370 | 1.3.4.5.1.10 | Radial versus Rectilinear Voxels Trade Study |  | 73d? | 2008-11-03 | 2009-02-11 |  |  | 288d | start no earlier than 2008-11-03 | Electrical Engineer / Programmer [37.7%] | 220h |  | 16,500 |  |
| 371 | 1.3.4.5.1.11 | Define Required Bit Resolution |  | 22d? | 2008-05-19 A | 2008-06-17 A | 100% |  |  | start no earlier than 2008-05-18 | Electrical Engineer / Programmer [36.9%] | 65h | 65h | 4,875 | 4,875 |
| 372 | 1.3.4.5.1.12 | Characterize Single Event Upset |  | 30d? | 2009-08-24 | 2009-10-02 |  |  | 121d | start no earlier than 2009-08-23 | Electrical Engineer / Programmer [27.1%] | 65h |  | 4,875 |  |
| 373 | 1.3.4.5.1.13 | Power Characterization and Parameter Estimation |  | 11.25d? | 2009-10-05 | 2009-10-20 |  |  | 109.75d | start no earlier than 2009-10-04 | Electrical Engineer / Programmer | 90h |  | 6,750 |  |
| 374 | 1.3.4.5.1.14 | Voxel Communication Parameters |  | 11.25d? | 2009-11-30 | 2009-12-15 |  |  | 69.75d | start no earlier than 2009-11-30 | Electrical Engineer / Programmer | 90h |  | 6,750 |  |
| 375 | 1.3.4.5.1.15 | Diagnostic Control & I/O Requirements |  | 30d? | 2009-02-02 A | 2009-03-13 | 65% | 10.5d? | 266d | start no earlier than 2009-02-02 | Electrical Engineer / Programmer [45.8%] | 110h | 71.5h | 8,250 | 5,362.5 |
| 376 | 1.3.4.5.1.16 | Monitoring Control & I/O Requirements |  | 40d? | 2009-10-12 | 2009-12-04 |  |  | 76d | start no earlier than 2009-10-11 | Electrical Engineer / Programmer [34.4%] | 110h |  | 8,250 |  |
| 377 | 1.3.4.5.1.17 | Define Testing Procedures |  | 45d? | 2008-09-29 A | 2008-11-28 | 35% | 29.25d? | 341d | start no earlier than 2008-09-28 | Electrical Engineer / Programmer [25%] | 90h | 31.5h | 6,750 | 2,362.5 |
| 378 | 1.3.4.5.1.18 | Documentation |  | 140d? | 2009-06-08 A | 2009-12-18 | 20% | 112d? | 66d | start no earlier than 2009-06-08 | Electrical Engineer / Programmer [11.6%] | 130h | 26h | 9,750 | 1,950 |

Notes:
- 337: EW
- 339: EW
- 350: EJ
- 359: DG
- 360: DG
- 361: MR

| ID | WBS | Task | Duration | Start | Finish | Complete | Remaining | Total slack | Constraint | Resources | Work | Actual work | Cost | Actual cost |
| --- | --- | --- | --- | --- | --- | --- | --- | --- | --- | --- | --- | --- | --- | --- |
| 379 | 1.3.4.5.2 | **DMs & Tip/Tilt Stages** | 105d? | 2008-10-06 A | 2009-02-27 | 19% | 84.92d? | 276d |  |  | 320h | 53.2h | 24,000 | 3,989.95 |
| 380 | 1.3.4.5.2.1 | **Woofer DM/TT** | 105d? | 2008-10-06 A | 2009-02-27 | 11% | 92.93d? | 276d |  |  | 132h | 12.4h | 9,900 | 929.95 |
| 381 | 1.3.4.5.2.1.1 | Define Requirements | 20d? | 2008-10-06 A | 2008-10-31 | 25% | 15d? | 361d | start no earlier than 2008-10-06 | Gavel [10%] | 16h | 4h | 1,200 | 300 |
| 382 | 1.3.4.5.2.1.2 | Evaluate Tip/Tilt Mount Options | 30d? | 2008-12-01 A | 2009-01-09 | 3% | 29.18d? | 311d | finish no earlier than 2009-01-09 | Lockwood [16.7%]; Gavel [50%] | 44h | 4.4h | 3,300 | 330 |
| 383 | 1.3.4.5.2.1.3 | Evaluate Combined DM & Tip/Tilt Performance | 10d? | 2009-01-12 A | 2009-01-23 | 10% | 9d? | 301d | finish no earlier than 2009-01-23 | Gavel [20%] | 16h | 1.6h | 1,200 | 120 |
| 384 | 1.3.4.5.2.1.4 | Select Tip/Tilt Mount | 5d? | 2009-01-26 A | 2009-01-30 | 2% | 4.91d? | 296d | finish no earlier than 2009-01-30 | Gavel [10%]; Lockwood | 8h | 0.8h | 600 | 59.95 |
| 385 | 1.3.4.5.2.1.5 | Design Mechanical Package | 10d? | 2009-02-16 | 2009-02-27 |  |  | 276d | finish no earlier than 2009-02-27 | Lockwood [50%] | 40h |  | 3,000 |  |
| 386 | 1.3.4.5.2.1.6 | Obtain Quotes | 20d? | 2009-01-05 A | 2009-01-30 | 20% | 16d? | 296d | finish no earlier than 2009-01-30 | Lockwood [5%] | 8h | 1.6h | 600 | 120 |
| 387 | 1.3.4.5.2.2 | **Tweeter DM/TT** | 95d? | 2008-10-06 A | 2009-02-13 | 28% | 68.29d? | 286d |  |  | 48h | 14h | 3,600 | 1,050 |
| 388 | 1.3.4.5.2.2.1 | Define Requirements | 20d? | 2008-10-06 A | 2008-10-31 | 50% | 10d? | 361d | finish no earlier than 2008-10-31 | Gavel [5%] | 8h | 4h | 600 | 300 |
| 389 | 1.3.4.5.2.2.2 | Evaluate Options & Select Tip/Tilt Mount | 20d? | 2008-11-03 A | 2008-11-28 | 8% | 18.32d? | 341d | finish no earlier than 2008-11-28 | Lockwood [12.5%]; Gavel [50%] | 28h | 8.4h | 2,100 | 630 |
| 390 | 1.3.4.5.2.2.3 | Design Mechanical Package | 10d? | 2009-02-02 | 2009-02-13 |  |  | 286d | finish no earlier than 2009-02-13 | Lockwood [10%] | 8h |  | 600 |  |
| 391 | 1.3.4.5.2.2.4 | Obtain Quotes | 20d? | 2008-11-03 A | 2008-11-28 | 40% | 12d? | 341d | finish no earlier than 2008-11-28 | Gavel [2.5%] | 4h | 1.6h | 300 | 120 |
| 392 | 1.3.4.5.2.3 | **LOWFS DM/TT** | 95d? | 2008-10-06 A | 2009-02-13 | 20% | 75.78d? | 286d |  |  | 140h | 26.8h | 10,500 | 2,010 |
| 393 | 1.3.4.5.2.3.1 | Define Requirements including LOWFS Interface | 20d? | 2008-10-06 A | 2008-10-31 | 30% | 14d? | 0d | finish no earlier than 2008-10-31 | Gavel [50%]; Velur [12.5%] | 28h | 14h | 2,100 | 1,050 |
| 394 | 1.3.4.5.2.3.2 | Evaluate Options & Select Tip/Tilt Mount | 20d? | 2008-11-03 A | 2008-11-28 | 16% | 16.8d? | 0d | finish no earlier than 2008-11-28 | Lockwood [12.5%]; Gavel [50%] | 28h | 11.2h | 2,100 | 840 |
| 395 | 1.3.4.5.2.3.3 | Design Mechanical Package | 25d? | 2009-01-12 | 2009-02-13 |  |  | 286d | finish no earlier than 2009-02-13 | Lockwood [40%] | 80h |  | 6,000 |  |
| 396 | 1.3.4.5.2.3.4 | Obtain Quotes | 20d? | 2008-11-03 A | 2008-11-28 | 40% | 12d? | 341d | finish no earlier than 2008-11-28 | Gavel [2.5%] | 4h | 1.6h | 300 | 120 |
| 397 | 1.3.4.6 | **AO System Lab I&T** | 40d? | 2009-07-06 | 2009-08-28 |  |  | 146d |  |  | 200h |  | 15,000 |  |
| 398 | 1.3.4.6.1 | AO System Lab I&T Scope Definition | 10d? | 2009-07-06 | 2009-07-17 |  |  | 176d | finish no earlier than 2009-07-17 | Wizinowich [20%] | 16h |  | 1,200 |  |
| 399 | 1.3.4.6.2 | AO System Lab Facility Plan | 30d? | 2009-07-20 | 2009-08-28 |  |  | 146d | finish no earlier than 2009-08-28 | Neyman [10%] | 24h |  | 1,800 |  |
| 400 | 1.3.4.6.3 | AO System Lab Integration Plan | 30d? | 2009-07-20 | 2009-08-28 |  |  | 146d | finish no earlier than 2009-08-28 | Neyman [33.3%] | 80h |  | 6,000 |  |
| 401 | 1.3.4.6.4 | AO System Lab Test Plan | 25d? | 2009-07-27 | 2009-08-28 |  |  | 146d | finish no earlier than 2009-08-28 | Neyman [40%] | 80h |  | 6,000 |  |
| 402 | 1.3.5 | **Laser System Design** | 390d? | 2008-05-05 A | 2009-10-30 | 27% | 285.73d? | 101d |  |  | 2964h | 483h | 222,300 | 36,225 |
| 403 | 1.3.5.1 | **Laser Enclosure (LE)** | 40d? | 2009-01-19 | 2009-03-13 |  |  | 266d |  |  | 160h |  | 12,000 |  |
| 404 | 1.3.5.1.1 | LE Requirements & Interfaces | 20d? | 2009-01-19 | 2009-02-13 |  |  | 286d | finish no earlier than 2009-02-13 | Chin [12.5%]; Medeiros [12.5%] | 40h |  | 3,000 |  |
| 405 | 1.3.5.1.2 | LE Mechanical Design | 10d? | 2009-02-16 | 2009-02-27 |  |  | 276d | finish no earlier than 2009-02-27 | Chin; Medeiros [50%] | 50h |  | 3,750 |  |
| 406 | 1.3.5.1.3 | LE Environmental Control Design | 10d? | 2009-02-16 | 2009-02-27 |  |  | 276d | finish no earlier than 2009-02-27 | Chin; Nance [50%] | 50h |  | 3,750 |  |
| 407 | 1.3.5.1.4 | LE Assembly & Test Plans | 10d? | 2009-03-02 | 2009-03-13 |  |  | 266d | finish no earlier than 2009-03-13 | Chin; Nance [10%]; Medeiros [10%] | 20h |  | 1,500 |  |

Notes:
- 379: DG
- 380: DG
- 387: DG
- 392: DG
- 397: CN
- 398: PW
- 399: CN
- 400: CN
- 401: CN
- 402: CN
- 403: JC
- 404: JC
- 405: DM
- 406: CN
- 407: JC

| ID | WBS | Task | Duration | Start | Finish | Predecessors | Complete | Remaining | Total slack | Free slack | Constraint | Resources | Work | Actual work | Cost | Actual cost |
| --- | --- | --- | --- | --- | --- | --- | --- | --- | --- | --- | --- | --- | --- | --- | --- | --- |
| 408 | 1.3.5.2 | **Laser** | 280d? | 2008-05-05 A | 2009-05-29 |  | 55% | 124.83d? | 211d |  |  |  | 820h | 430h | 61,500 | 32,250 |
| 409 | 1.3.5.2.1 | Laser Project Management | 280d? | 2008-05-05 A | 2009-05-29 |  | 50% | 140d? | 211d |  | finish no earlier than 2009-05-29 | Adkins [6.7%]; Kissner [6.7%] | 300h | 150h | 22,500 | 11,250 |
| 410 | 5.2.3.1 | **Laser Requirements** | 110d | 2008-05-05 A | 2008-10-03 |  | 61% | 42.5d | 381d |  |  |  | 160h | 90h | 12,000 | 6,750 |
| 411 | 5.2.3.1.1 | Laser Performance Analysis | 20d | 2008-05-05 | 2008-05-30 |  |  |  | 441d | 0d | start no earlier than 2008-05-05 | Adkins [25%] | 40h |  | 3,000 |  |
| 412 | 5.2.3.1.2 | Laser Requirements Analysis | 20d | 2008-06-02 A | 2008-06-27 | 411 | 75% | 5d | 426d | 0d |  | Adkins [25%] | 40h | 30h | 3,000 | 2,250 |
| 413 | 5.2.3.1.3 | Laser Requirements Development | 20d | 2008-06-30 A | 2008-07-25 | 412 | 75% | 5d | 411d | 0d |  | Adkins [25%] | 40h | 30h | 3,000 | 2,250 |
| 414 | 5.2.3.1.4 | Laser Requirements Drafting and Revisions | 50d | 2008-07-28 A | 2008-10-03 | 413 | 75% | 12.5d | 381d |  |  | Adkins [10%] | 40h | 30h | 3,000 | 2,250 |
| 415 | 5.2.3.2 | **Laser Preliminary ICD** | 20d | 2008-07-28 | 2008-08-22 |  |  |  | 411d |  |  |  | 40h |  | 3,000 |  |
| 416 | 5.2.3.2.1 | Laser ICD Drafting and Revisions | 20d | 2008-07-28 | 2008-08-22 | 413 |  |  | 411d |  |  | Adkins [25%] | 40h |  | 3,000 |  |
| 417 | 5.2.3.3 | **Laser Request for Proposals (RFP)** | 90d | 2008-10-06 A | 2009-02-06 A |  | 100% |  |  |  |  |  | 120h | 120h | 9,000 | 9,000 |
| 418 | 5.2.3.3.1 | Laser Proposal Drafting | 20d | 2008-10-06 A | 2008-10-31 A | 414 | 100% |  |  |  |  | Adkins [25%] | 40h | 40h | 3,000 | 3,000 |
| 419 | 5.2.3.3.2 | Laser Proposal Release | 10d | 2008-11-03 A | 2008-11-14 A | 418 | 100% |  |  |  |  | Adkins [25%]; Kissner [30%] | 40h | 40h | 3,000 | 3,000 |
| 420 | 5.2.3.3.3 | Laser Proposal Response Period | 3mo | 2008-11-17 A | 2009-02-06 A | 419 | 100% |  |  |  |  | Adkins [3.3%]; Kissner [5%] | 40h | 40h | 3,000 | 3,000 |
| 421 | 5.2.3.4 | **Laser RFP Response Report** | 40d | 2009-02-09 A | 2009-04-03 |  | 50% | 20d | 251d |  |  |  | 120h | 60h | 9,000 | 4,500 |
| 422 | 5.2.3.4.1 | Laser Proposal Evaluation | 20d | 2009-02-09 A | 2009-03-06 A | 420 | 100% |  |  |  |  | Adkins [25%] | 40h | 40h | 3,000 | 3,000 |
| 423 | 5.2.3.4.2 | Laser Response Discussions | 20d | 2009-03-09 A | 2009-04-03 | 422 | 25% | 15d | 251d |  |  | Adkins [25%] | 40h | 10h | 3,000 | 750 |
| 424 | 5.2.3.4.3 | Laser Report Drafting and Revisions | 20d | 2009-03-09 A | 2009-04-03 | 422 | 25% | 15d | 216d | 0d |  | Adkins [25%] | 40h | 10h | 3,000 | 750 |
| 425 | 5.2.3.5 | **Laser Contract** | 40d | 2009-04-06 A | 2009-05-29 |  | 13% | 35d | 211d |  |  |  | 80h | 10h | 6,000 | 750 |
| 426 | 5.2.3.5.1 | Laser Contract Drafting and Revisions | 20d | 2009-04-06 A | 2009-05-01 | 424 | 25% | 15d | 211d | 0d |  | Adkins [25%] | 40h | 10h | 3,000 | 750 |
| 427 | 5.2.3.5.2 | Laser Contract Negotiations | 20d | 2009-05-04 | 2009-05-29 | 426 |  |  | 211d |  |  | Adkins [25%] | 40h |  | 3,000 |  |
| 428 | 1.3.5.3 | **Laser Launch Facility (LLF)** | 170d? | 2009-01-19 A | 2009-09-11 |  | 10% | 153.25d? | 136d |  |  |  | 856h | 29h | 64,200 | 2,175 |
| 429 | 1.3.5.3.1 | LLF Requirements & Interfaces | 20d? | 2009-01-19 A | 2009-02-13 |  | 2% | 19.58d? | 286d |  | finish no earlier than 2009-02-13 | Neyman [50%]; Chin | 100h | 5h | 7,500 | 375 |
| 430 | 1.3.5.3.2 | LLF Optical Design | 53d? | 2009-04-01 | 2009-06-12 |  |  |  | 201d |  | finish no earlier than 2009-06-12 | Neyman [14.2%]; Panteleev [47.2%] | 260h |  | 19,500 |  |
| 431 | 1.3.5.3.3 | LLF Launch Telescope Preliminary Design Contract | 100d? | 2009-03-16 A | 2009-07-31 |  | 25% | 75d? | 166d |  | start no earlier than 2009-03-16 | Neyman [9%]; Chin [3%] | 96h | 24h | 7,200 | 1,800 |
| 432 | 1.3.5.3.4 | LLF Mechanical Design | 45d? | 2009-06-01 | 2009-07-31 |  |  |  | 166d |  | finish no earlier than 2009-07-31 | Neyman; Medeiros [55.6%] | 220h |  | 16,500 |  |
| 433 | 1.3.5.3.5 | LLF Electrical Design | 30d? | 2009-07-20 | 2009-08-28 |  |  |  | 146d |  | finish no earlier than 2009-08-28 | Neyman; Wetherell [41.7%] | 120h |  | 9,000 |  |
| 434 | 1.3.5.3.6 | LLF Assembly, Alignment & Test Plans | 10d? | 2009-08-31 | 2009-09-11 |  |  |  | 136d |  | finish no earlier than 2009-09-11 | Neyman [62.5%]; Chin | 60h |  | 4,500 |  |

Notes:
- 408: SA
- 409: SA
- 410: SA
- 415: SA
- 417: SA
- 421: SA
- 425: SA
- 428: CN

| ID | WBS | Task | Duration | Start | Finish | Complete | Remaining | Total slack | Constraint | Resources | Work | Actual work | Cost | Actual cost |
| --- | --- | --- | --- | --- | --- | --- | --- | --- | --- | --- | --- | --- | --- | --- |
| 435 | 1.3.5.4 | **Laser Safety Systems** | 65d? | 2009-08-03 | 2009-10-30 |  |  | 101d |  |  | 170h |  | 12,750 |  |
| 436 | 1.3.5.4.1 | **Personnel & Equipment Safety System** | 43d? | 2009-08-03 | 2009-09-30 |  |  | 123d |  |  | 130h |  | 9,750 |  |
| 437 | 1.3.5.4.1.1 | Safety Requirements & Interfaces | 10d? | 2009-08-03 | 2009-08-14 |  |  | 156d | start no earlier than 2009-08-03 | Chin [50%] | 40h |  | 3,000 |  |
| 438 | 1.3.5.4.1.2 | Safety Algorithms, Diagrams & Dataflow | 33d? | 2009-08-17 | 2009-09-30 |  |  | 123d | start no earlier than 2009-08-17 | Wetherell [7.6%] | 20h |  | 1,500 |  |
| 439 | 1.3.5.4.1.3 | Safety Communication Protocols & Methods | 33d? | 2009-08-17 | 2009-09-30 |  |  | 123d | start no earlier than 2009-08-17 | Wetherell [7.6%] | 20h |  | 1,500 |  |
| 440 | 1.3.5.4.1.4 | Safety Performance Estimate | 33d? | 2009-08-17 | 2009-09-30 |  |  | 123d | start no earlier than 2009-08-17 | Wetherell [7.6%] | 20h |  | 1,500 |  |
| 441 | 1.3.5.4.1.5 | Safety Electronics, Shutter & Interlocks | 33d? | 2009-08-17 | 2009-09-30 |  |  | 123d | start no earlier than 2009-08-17 | Wetherell [3.8%] | 10h |  | 750 |  |
| 442 | 1.3.5.4.1.6 | Safety Test Plans | 33d? | 2009-08-17 | 2009-09-30 |  |  | 123d | start no earlier than 2009-08-17 | Chin [3.8%]; Wetherell [3.8%] | 20h |  | 1,500 |  |
| 443 | 1.3.5.4.2 | **Laser Traffic Control System (LTCS) Modifications** | 20d? | 2009-10-05 | 2009-10-30 |  |  | 101d |  |  | 40h |  | 3,000 |  |
| 444 | 1.3.5.4.2.1 | LTCS Requirements & Interfaces | 20d? | 2009-10-05 | 2009-10-30 |  |  | 101d | start no earlier than 2009-10-05 | Summers [5%] | 8h |  | 600 |  |
| 445 | 1.3.5.4.2.2 | LTCS Algorithms, Diagrams & Dataflow | 20d? | 2009-10-05 | 2009-10-30 |  |  | 101d | start no earlier than 2009-10-05 | Summers [5%] | 8h |  | 600 |  |
| 446 | 1.3.5.4.2.3 | LTCS Communication Protocols & Methods | 20d? | 2009-10-05 | 2009-10-30 |  |  | 101d | start no earlier than 2009-10-05 | Summers [5%] | 8h |  | 600 |  |
| 447 | 1.3.5.4.2.4 | LTCS Performance Estimate | 20d? | 2009-10-05 | 2009-10-30 |  |  | 101d | start no earlier than 2009-10-05 | Summers [5%] | 8h |  | 600 |  |
| 448 | 1.3.5.4.2.5 | LTCS Test Plans | 20d? | 2009-10-05 | 2009-10-30 |  |  | 101d | start no earlier than 2009-10-05 | Summers [5%] | 8h |  | 600 |  |
| 449 | 1.3.5.5 | **Laser System Control (LSC)** | 98.33d? | 2009-04-28 A | 2009-09-11 | 3% | 95.72d? | 136d |  |  | 910h | 24h | 68,250 | 1,800 |
| 450 | 1.3.5.5.1 | **LSC Software** | 53d? | 2009-07-01 A | 2009-09-11 | 4% | 51.04d? | 136d |  |  | 600h | 24h | 45,000 | 1,800 |
| 451 | 1.3.5.5.1.1 | LSC Software Requirements & Interfaces | 8d? | 2009-07-01 | 2009-07-10 |  |  | 181d | start no earlier than 2009-07-01 | Johansson [62.5%]; Neyman [93.8%]; Chin [31.2%] | 120h |  | 9,000 |  |
| 452 | 1.3.5.5.1.2 | LSC Sequencer Software | 40d? | 2009-07-13 A | 2009-09-04 | 10% | 36d? | 141d | finish no earlier than 2009-09-04 | Johansson [25%]; Morrison [50%] | 240h | 24h | 18,000 | 1,800 |
| 453 | 1.3.5.5.1.3 | LSC Motion Control Software | 30d? | 2009-07-20 | 2009-08-28 |  |  | 146d | finish no earlier than 2009-08-28 | Morrison [50%] | 120h |  | 9,000 |  |
| 454 | 1.3.5.5.1.4 | LSC Device Control Software | 30d? | 2009-08-03 | 2009-09-11 |  |  | 136d | finish no earlier than 2009-09-11 | Morrison [50%] | 120h |  | 9,000 |  |
| 455 | 1.3.5.5.2 | **LSC Hardware** | 33.33d? | 2009-04-28 | 2009-06-12 |  |  | 201d |  |  | 310h |  | 23,250 |  |
| 456 | 1.3.5.5.2.1 | LSC Hardware Requirements & Interfaces | 13.33d? | 2009-04-28 | 2009-05-15 |  |  | 221d | finish no earlier than 2009-05-15 | Neyman [37.5%]; Wetherell [28.1%]; Chin [18.8%] | 90h |  | 6,750 |  |
| 457 | 1.3.5.5.2.2 | LSC Motion Control Hardware | 15d? | 2009-05-18 | 2009-06-05 |  |  | 206d | start no earlier than 2009-05-18 | Wetherell | 120h |  | 9,000 |  |
| 458 | 1.3.5.5.2.3 | LSC Device Control Hardware | 14.29d? | 2009-05-25 | 2009-06-12 |  |  | 201d | finish no earlier than 2009-06-12 | Wetherell [87.5%] | 100h |  | 7,500 |  |
| 459 | 1.3.5.6 | Laser System Lab I&T Plan | 20d? | 2009-10-05 | 2009-10-30 |  |  | 101d | finish no earlier than 2009-10-30 | Neyman [20%]; Chin; Nance | 48h |  | 3,600 |  |

Notes:
- 435: JC
- 436: JC
- 443: DS
- 449: EJ
- 450: EJ
- 451: EJ
- 452: EJ
- 453: EJ
- 455: EW
- 456: EW
- 457: EW
- 458: EW
- 459: CN

| ID | WBS | Task | Duration | Start | Finish | Complete | Remaining | Total slack | Constraint | Resources | Work | Actual work | Cost | Actual cost |
| --- | --- | --- | --- | --- | --- | --- | --- | --- | --- | --- | --- | --- | --- | --- |
| 460 | 1.3.6 | **Science Operations Tools Design** | 349d? | 2008-07-01 A | 2009-10-30 |  | 348.99d? | 101d |  |  | 1800h | 4h | 135,000 | 300.06 |
| 461 | 1.3.6.1 | **Multi-Systems Command Sequencer (MCS)** | 155d? | 2008-07-01 A | 2009-02-02 |  | 154.96d? | 295d |  |  | 620h | 4h | 46,500 | 300.06 |
| 462 | 1.3.6.1.1 | **MCS Infrastructure** | 80d? | 2008-07-07 A | 2008-10-24 |  | 79.93d? | 366d |  |  | 180h | 4h | 13,500 | 300.06 |
| 463 | 1.3.6.1.1.1 | **MCS Infrastructure Architecture** | 80d? | 2008-07-07 A | 2008-10-24 |  | 79.88d? | 366d |  |  | 140h | 4h | 10,500 | 300.06 |
| 464 | 1.3.6.1.1.1.1 | MCS Architecture | 80d? | 2008-07-07 A | 2008-10-24 | 1% | 79.52d? | 366d | finish no earlier than 2008-10-24 | Johansson [4.7%]; Le Mignant | 40h | 4h | 3,000 | 300.06 |
| 465 | 1.3.6.1.1.1.2 | MCS Operations Concept Document | 80d? | 2008-07-07 | 2008-10-24 |  |  | 366d | start no earlier than 2008-07-07 | Johansson [6.2%] | 40h |  | 3,000 |  |
| 466 | 1.3.6.1.1.1.3 | MCS Software Requirements | 80d? | 2008-07-07 | 2008-10-24 |  |  | 366d | start no earlier than 2008-07-07 | Johansson [6.2%] | 40h |  | 3,000 |  |
| 467 | 1.3.6.1.1.1.4 | MCS Module Definitions | 80d? | 2008-07-07 | 2008-10-24 |  |  | 366d | start no earlier than 2008-07-07 | Johansson [3.1%] | 20h |  | 1,500 |  |
| 468 | 1.3.6.1.1.2 | **Coordination Sequence Support Library** | 80d? | 2008-07-07 | 2008-10-24 |  |  | 366d |  |  | 20h |  | 1,500 |  |
| 469 | 1.3.6.1.1.2.1 | Functional Requirements | 80d? | 2008-07-07 | 2008-10-24 |  |  | 366d | start no earlier than 2008-07-07 | Johansson [3.1%] | 20h |  | 1,500 |  |
| 470 | 1.3.6.1.1.2.2 | Interface Definitions | 1d? | 2008-07-07 | 2008-07-07 |  |  | 445d | start no earlier than 2008-07-07 |  |  |  |  |  |
| 471 | 1.3.6.1.1.3 | **Command Interface** | 80d? | 2008-07-07 | 2008-10-24 |  |  | 366d |  |  | 10h |  | 750 |  |
| 472 | 1.3.6.1.1.3.1 | Functional Requirements | 80d? | 2008-07-07 | 2008-10-24 |  |  | 366d | start no earlier than 2008-07-07 | Johansson [1.6%] | 10h |  | 750 |  |
| 473 | 1.3.6.1.1.3.2 | Interface Definitions | 1d? | 2008-07-07 | 2008-07-07 |  |  | 445d | finish no earlier than 2008-07-07 |  |  |  |  |  |
| 474 | 1.3.6.1.1.4 | **System Health** | 80d? | 2008-07-07 | 2008-10-24 |  |  | 366d |  |  | 10h |  | 750 |  |
| 475 | 1.3.6.1.1.4.1 | Functional Requirements | 80d? | 2008-07-07 | 2008-10-24 |  |  | 366d | start no earlier than 2008-07-07 | Johansson [1.6%] | 10h |  | 750 |  |
| 476 | 1.3.6.1.1.4.2 | Interface Definitions | 1d? | 2008-07-07 | 2008-07-07 |  |  | 445d | start no earlier than 2008-07-07 |  |  |  |  |  |
| 477 | 1.3.6.1.2 | **Setup Sequences: Configuration & Calibration** | 89d? | 2008-07-01 | 2008-10-31 |  |  | 361d |  |  | 100h |  | 7,500 |  |
| 478 | 1.3.6.1.2.1 | **Setup Sequences Common Structure** | 89d? | 2008-07-01 | 2008-10-31 |  |  | 361d |  |  | 60h |  | 4,500 |  |
| 479 | 1.3.6.1.2.1.1 | Setup Sequences Operations Concept Document | 89d? | 2008-07-01 | 2008-10-31 |  |  | 361d | finish no earlier than 2008-10-31 | Johansson [2.8%] | 20h |  | 1,500 |  |
| 480 | 1.3.6.1.2.1.2 | Setup Sequences Software Requirements | 89d? | 2008-07-01 | 2008-10-31 |  |  | 361d | finish no earlier than 2008-10-31 | Johansson [2.8%] | 20h |  | 1,500 |  |
| 481 | 1.3.6.1.2.1.3 | Setup Sequences Module Definitions | 89d? | 2008-07-01 | 2008-10-31 |  |  | 361d | finish no earlier than 2008-10-31 | Johansson [2.8%] | 20h |  | 1,500 |  |
| 482 | 1.3.6.1.2.2 | **Configuration Sequences** | 89d? | 2008-07-01 | 2008-10-31 |  |  | 361d |  |  | 20h |  | 1,500 |  |
| 483 | 1.3.6.1.2.2.1 | Functional Requirements | 89d? | 2008-07-01 | 2008-10-31 |  |  | 361d | finish no earlier than 2008-10-31 | Le Mignant [2.8%] | 20h |  | 1,500 |  |
| 484 | 1.3.6.1.2.2.2 | Interface Definitions | 1d? | 2008-07-01 | 2008-07-01 |  |  | 449d | start no earlier than 2008-07-01 |  |  |  |  |  |

Notes:
- 460: DLM
- 461: EJ

| ID | WBS | Task | Duration | Start | Finish | Total slack | Constraint | Resources | Work | Cost |
| --- | --- | --- | --- | --- | --- | --- | --- | --- | --- | --- |
| 485 | 1.3.6.1.2.3 | **Calibration Sequences** | 89d? | 2008-07-01 | 2008-10-31 | 361d |  |  | 20h | 1,500 |
| 486 | 1.3.6.1.2.3.1 | Functional Requirements | 89d? | 2008-07-01 | 2008-10-31 | 361d | finish no earlier than 2008-10-31 | Le Mignant [2.8%] | 20h | 1,500 |
| 487 | 1.3.6.1.2.3.2 | Interface Definitions | 1d? | 2008-07-01 | 2008-07-01 | 449d | start no earlier than 2008-07-01 |  |  |  |
| 488 | 1.3.6.1.3 | **Observing Sequences** | 89d? | 2008-10-01 | 2009-02-02 | 295d |  |  | 240h | 18,000 |
| 489 | 1.3.6.1.3.1 | **Observing Sequences Common Structure** | 89d? | 2008-10-01 | 2009-02-02 | 295d |  |  | 120h | 9,000 |
| 490 | 1.3.6.1.3.1.1 | Observing Sequences Operations Concept Document | 89d? | 2008-10-01 | 2009-02-02 | 295d | finish no earlier than 2009-02-02 | Le Mignant [4.2%]; Johansson [1.4%] | 40h | 3,000 |
| 491 | 1.3.6.1.3.1.2 | Observing Sequences Software Requirements | 89d? | 2008-10-01 | 2009-02-02 | 295d | start no earlier than 2008-10-01 | Johansson [5.6%] | 40h | 3,000 |
| 492 | 1.3.6.1.3.1.3 | Observing Sequences Module Definitions | 89d? | 2008-10-01 | 2009-02-02 | 295d | finish no earlier than 2009-02-02 | Johansson [2.8%]; Le Mignant [2.8%] | 40h | 3,000 |
| 493 | 1.3.6.1.3.2 | **Acquisition Sequences** | 89d? | 2008-10-01 | 2009-02-02 | 295d |  |  | 60h | 4,500 |
| 494 | 1.3.6.1.3.2.1 | Functional Requirements | 89d? | 2008-10-01 | 2009-02-02 | 295d | finish no earlier than 2009-02-02 | Le Mignant [4.2%]; Johansson [1.4%] | 40h | 3,000 |
| 495 | 1.3.6.1.3.2.2 | Interface Definitions | 89d? | 2008-10-01 | 2009-02-02 | 295d | finish no earlier than 2009-02-02 | Johansson [2.8%] | 20h | 1,500 |
| 496 | 1.3.6.1.3.3 | **Observing Sequences** | 89d? | 2008-10-01 | 2009-02-02 | 295d |  |  | 20h | 1,500 |
| 497 | 1.3.6.1.3.3.1 | Functional Requirements | 89d? | 2008-10-01 | 2009-02-02 | 295d | finish no earlier than 2009-02-02 | Le Mignant [2.8%] | 20h | 1,500 |
| 498 | 1.3.6.1.3.3.2 | Interface Definitions | 1d? | 2008-10-01 | 2008-10-01 | 383d | start no earlier than 2008-10-01 |  |  |  |
| 499 | 1.3.6.1.3.4 | **Quality Monitoring Sequences** | 89d? | 2008-10-01 | 2009-02-02 | 295d |  |  | 20h | 1,500 |
| 500 | 1.3.6.1.3.4.1 | Functional Requirements | 89d? | 2008-10-01 | 2009-02-02 | 295d | finish no earlier than 2009-02-02 | Le Mignant [2.8%] | 20h | 1,500 |
| 501 | 1.3.6.1.3.4.2 | Interface Definitions | 1d? | 2008-10-01 | 2008-10-01 | 383d | start no earlier than 2008-10-01 |  |  |  |
| 502 | 1.3.6.1.3.5 | **Optimization Sequences** | 89d? | 2008-10-01 | 2009-02-02 | 295d |  |  | 20h | 1,500 |
| 503 | 1.3.6.1.3.5.1 | Functional Requirements | 89d? | 2008-10-01 | 2009-02-02 | 295d | finish no earlier than 2009-02-02 | Le Mignant [2.8%] | 20h | 1,500 |
| 504 | 1.3.6.1.3.5.2 | Interface Definitions | 1d? | 2008-10-01 | 2008-10-01 | 383d | start no earlier than 2008-10-01 |  |  |  |
| 505 | 1.3.6.1.4 | **Alarm Handler & Troubleshooting Sequences** | 89d? | 2008-10-01 | 2009-02-02 | 295d |  |  | 100h | 7,500 |
| 506 | 1.3.6.1.4.1 | **Alarm Handler & Troubleshooting Common Structure** | 89d? | 2008-10-01 | 2009-02-02 | 295d |  |  | 100h | 7,500 |
| 507 | 1.3.6.1.4.1.1 | Alarm & Troubleshooting Operations Concept Document | 89d? | 2008-10-01 | 2009-02-02 | 295d | finish no earlier than 2009-02-02 | Le Mignant [4.2%]; Johansson [1.4%] | 40h | 3,000 |
| 508 | 1.3.6.1.4.1.2 | Alarm & Troubleshooting Software Requirements | 89d? | 2008-10-01 | 2009-02-02 | 295d | finish no earlier than 2009-02-02 | Johansson [2.8%] | 20h | 1,500 |
| 509 | 1.3.6.1.4.1.3 | Alarm & Troubleshooting Module Definitions | 89d? | 2008-10-01 | 2009-02-02 | 295d | finish no earlier than 2009-02-02 | Johansson [2.8%]; Le Mignant [2.8%] | 40h | 3,000 |

| ID | WBS | Task | Duration | Start | Finish | Total slack | Constraint | Resources | Work | Cost |
| --- | --- | --- | --- | --- | --- | --- | --- | --- | --- | --- |
| 510 | 1.3.6.1.4.2 | **Alarm Handler Sequences** | 1d? | 2008-10-01 | 2008-10-01 | 383d |  |  |  |  |
| 511 | 1.3.6.1.4.2.1 | Functional Requirements | 1d? | 2008-10-01 | 2008-10-01 | 383d | start no earlier than 2008-10-01 |  |  |  |
| 512 | 1.3.6.1.4.2.2 | Interface Definitions | 1d? | 2008-10-01 | 2008-10-01 | 383d | start no earlier than 2008-10-01 |  |  |  |
| 513 | 1.3.6.1.4.3 | **Troubleshooting Sequences** | 1d? | 2008-10-01 | 2008-10-01 | 383d |  |  |  |  |
| 514 | 1.3.6.1.4.3.1 | Functional Requirements | 1d? | 2008-10-01 | 2008-10-01 | 383d | start no earlier than 2008-10-01 |  |  |  |
| 515 | 1.3.6.1.4.3.2 | Interface Definitions | 1d? | 2008-10-01 | 2008-10-01 | 383d | start no earlier than 2008-10-01 |  |  |  |
| 516 | 1.3.6.2 | **User Interfaces** | 239d? | 2008-07-01 | 2009-05-29 | 211d |  |  | 500h | 37,500 |
| 517 | 1.3.6.2.1 | **User Interface (UI) Infrastructure** | 89d? | 2008-07-01 | 2008-10-31 | 361d |  |  | 180h | 13,500 |
| 518 | 1.3.6.2.1.1 | **UI Infrastructure Architecture** | 89d? | 2008-07-01 | 2008-10-31 | 361d |  |  | 120h | 9,000 |
| 519 | 1.3.6.2.1.1.1 | UI Architecture | 89d? | 2008-07-01 | 2008-10-31 | 361d | finish no earlier than 2008-10-31 | Johansson [4.9%]; Le Mignant | 40h | 3,000 |
| 520 | 1.3.6.2.1.1.2 | UI Operations Concept Document | 89d? | 2008-07-01 | 2008-10-31 | 361d | finish no earlier than 2008-10-31 | Le Mignant [2.8%]; Johansson [2.8%] | 40h | 3,000 |
| 521 | 1.3.6.2.1.1.3 | UI Software Requirements | 89d? | 2008-07-01 | 2008-10-31 | 361d | finish no earlier than 2008-10-31 | Johansson [2.8%] | 20h | 1,500 |
| 522 | 1.3.6.2.1.1.4 | UI Module Definitions | 89d? | 2008-07-01 | 2008-10-31 | 361d | finish no earlier than 2008-10-31 | Johansson [2.8%] | 20h | 1,500 |
| 523 | 1.3.6.2.1.2 | **UI Command Interface to MCS** | 89d? | 2008-07-01 | 2008-10-31 | 361d |  |  | 40h | 3,000 |
| 524 | 1.3.6.2.1.2.1 | Functional Requirements | 89d? | 2008-07-01 | 2008-10-31 | 361d | finish no earlier than 2008-10-31 | Johansson [2.8%] | 20h | 1,500 |
| 525 | 1.3.6.2.1.2.2 | Interface Definitions | 89d? | 2008-07-01 | 2008-10-31 | 361d | finish no earlier than 2008-10-31 | Johansson [2.8%] | 20h | 1,500 |
| 526 | 1.3.6.2.1.3 | **UI Command Interface to Pre- & Post-Observing Tools** | 89d? | 2008-07-01 | 2008-10-31 | 361d |  |  | 20h | 1,500 |
| 527 | 1.3.6.2.1.3.1 | Functional Requirements | 89d? | 2008-07-01 | 2008-10-31 | 361d | finish no earlier than 2008-10-31 | Johansson [2.8%] | 20h | 1,500 |
| 528 | 1.3.6.2.1.3.2 | Interface Definitions | 89d? | 2008-07-01 | 2008-10-31 | 361d | finish no earlier than 2008-10-31 |  |  |  |
| 529 | 1.3.6.2.2 | **Setup User Interfaces** | 130d? | 2008-10-01 | 2009-03-31 | 254d |  |  | 80h | 6,000 |
| 530 | 1.3.6.2.2.1 | **Setup UI Common Structure** | 130d? | 2008-10-01 | 2009-03-31 | 254d |  |  | 50h | 3,750 |
| 531 | 1.3.6.2.2.1.1 | Setup UI Operations Concept Document | 130d? | 2008-10-01 | 2009-03-31 | 254d | start no earlier than 2008-10-01 | Le Mignant [1.9%] | 20h | 1,500 |
| 532 | 1.3.6.2.2.1.2 | Setup UI Software Requirements | 130d? | 2008-10-01 | 2009-03-31 | 254d | finish no earlier than 2009-03-31 | Johansson [1%] | 10h | 750 |
| 533 | 1.3.6.2.2.1.3 | Setup UI Module Definitions | 130d? | 2008-10-01 | 2009-03-31 | 254d | finish no earlier than 2009-03-31 | Johansson [1.9%] | 20h | 1,500 |

Notes:
- 516: DLM

| ID | WBS | Task | Duration | Start | Finish | Total slack | Constraint | Resources | Work | Cost |
| --- | --- | --- | --- | --- | --- | --- | --- | --- | --- | --- |
| 534 | 1.3.6.2.2.2 | **Setup UI Configurations** | 130d? | 2008-10-01 | 2009-03-31 | 254d |  |  | 15h | 1,125 |
| 535 | 1.3.6.2.2.2.1 | Functional Requirements | 130d? | 2008-10-01 | 2009-03-31 | 254d | finish no earlier than 2009-03-31 | Le Mignant [1.4%] | 15h | 1,125 |
| 536 | 1.3.6.2.2.2.2 | Interface Definitions | 130d? | 2008-10-01 | 2009-03-31 | 254d | finish no earlier than 2009-03-31 |  |  |  |
| 537 | 1.3.6.2.2.3 | **Setup UI Calibrations** | 130d? | 2008-10-01 | 2009-03-31 | 254d |  |  | 15h | 1,125 |
| 538 | 1.3.6.2.2.3.1 | Functional Requirements | 130d? | 2008-10-01 | 2009-03-31 | 254d | finish no earlier than 2009-03-31 | Le Mignant [1.4%] | 15h | 1,125 |
| 539 | 1.3.6.2.2.3.2 | Interface Definitions | 130d? | 2008-10-01 | 2009-03-31 | 254d | finish no earlier than 2009-03-31 |  |  |  |
| 540 | 1.3.6.2.3 | **Observations User Interfaces** | 173d? | 2008-10-01 | 2009-05-29 | 211d |  |  | 240h | 18,000 |
| 541 | 1.3.6.2.3.1 | **Observations UI Common Structure** | 173d? | 2008-10-01 | 2009-05-29 | 211d |  |  | 130h | 9,750 |
| 542 | 1.3.6.2.3.1.1 | Observations UI Operations Concept Document | 173d? | 2008-10-01 | 2009-05-29 | 211d | finish no earlier than 2009-05-29 | Le Mignant [2.2%]; Johansson | 40h | 3,000 |
| 543 | 1.3.6.2.3.1.2 | Observations UI Software Requirements | 173d? | 2008-10-01 | 2009-05-29 | 211d | finish no earlier than 2009-05-29 | Johansson [0.7%] | 10h | 750 |
| 544 | 1.3.6.2.3.1.3 | Observations UI Module Definitions | 173d? | 2008-10-01 | 2009-05-29 | 211d | finish no earlier than 2009-05-29 | Johansson [2.9%]; Le Mignant [2.9%] | 80h | 6,000 |
| 545 | 1.3.6.2.3.2 | **Acquisition & AO Control UI** | 173d? | 2008-10-01 | 2009-05-29 | 211d |  |  | 30h | 2,250 |
| 546 | 1.3.6.2.3.2.1 | Functional Requirements | 173d? | 2008-10-01 | 2009-05-29 | 211d | finish no earlier than 2009-05-29 | Le Mignant [1.4%] | 20h | 1,500 |
| 547 | 1.3.6.2.3.2.2 | Interface Definitions | 173d? | 2008-10-01 | 2009-05-29 | 211d | finish no earlier than 2009-05-29 | Johansson [0.7%] | 10h | 750 |
| 548 | 1.3.6.2.3.3 | **Observing Sequences UI** | 173d? | 2008-10-01 | 2009-05-29 | 211d |  |  | 20h | 1,500 |
| 549 | 1.3.6.2.3.3.1 | Functional Requirements | 173d? | 2008-10-01 | 2009-05-29 | 211d | finish no earlier than 2009-05-29 | Le Mignant [1.4%] | 20h | 1,500 |
| 550 | 1.3.6.2.3.3.2 | Interface Definitions | 173d? | 2008-10-01 | 2009-05-29 | 211d | finish no earlier than 2009-05-29 |  |  |  |
| 551 | 1.3.6.2.3.4 | **Status & Graph UI** | 173d? | 2008-10-01 | 2009-05-29 | 211d |  |  | 20h | 1,500 |
| 552 | 1.3.6.2.3.4.1 | Functional Requirements | 173d? | 2008-10-01 | 2009-05-29 | 211d | finish no earlier than 2009-05-29 | Le Mignant [1.4%] | 20h | 1,500 |
| 553 | 1.3.6.2.3.4.2 | Interface Definitions | 173d? | 2008-10-01 | 2009-05-29 | 211d | finish no earlier than 2009-05-29 |  |  |  |
| 554 | 1.3.6.2.3.5 | **Advanced Monitoring UI** | 173d? | 2008-10-01 | 2009-05-29 | 211d |  |  | 20h | 1,500 |
| 555 | 1.3.6.2.3.5.1 | Functional Requirements | 173d? | 2008-10-01 | 2009-05-29 | 211d | finish no earlier than 2009-05-29 | Le Mignant [1.4%] | 20h | 1,500 |
| 556 | 1.3.6.2.3.5.2 | Interface Definitions | 173d? | 2008-10-01 | 2009-05-29 | 211d | finish no earlier than 2009-05-29 |  |  |  |
| 557 | 1.3.6.2.3.6 | **Optimization & Troubleshooting UI** | 173d? | 2008-10-01 | 2009-05-29 | 211d |  |  | 20h | 1,500 |
| 558 | 1.3.6.2.3.6.1 | Functional Requirements | 173d? | 2008-10-01 | 2009-05-29 | 211d | finish no earlier than 2009-05-29 | Le Mignant [1.4%] | 20h | 1,500 |
| 559 | 1.3.6.2.3.6.2 | Interface Definitions | 173d? | 2008-10-01 | 2009-05-29 | 211d | finish no earlier than 2009-05-29 |  |  |  |

| ID | WBS | Task | Duration | Start | Finish | Total slack | Constraint | Resources | Work | Cost |
| --- | --- | --- | --- | --- | --- | --- | --- | --- | --- | --- |
| 560 | 1.3.6.3 | **Pre- & Post-Observing Science Support Tools** | 217d? | 2009-01-01 | 2009-10-30 | 101d |  |  | 610h | 45,750 |
| 561 | 1.3.6.3.1 | **User Documentation** | 174d? | 2009-01-01 | 2009-09-01 | 144d |  |  | 20h | 1,500 |
| 562 | 1.3.6.3.1.1 | User Documentation Operations Concept | 174d? | 2009-01-01 | 2009-09-01 | 144d | finish no earlier than 2009-09-01 | Le Mignant [0.7%] | 10h | 750 |
| 563 | 1.3.6.3.1.2 | User Documentation Functional Requirements | 174d? | 2009-01-01 | 2009-09-01 | 144d | finish no earlier than 2009-09-01 | Le Mignant [0.7%] | 10h | 750 |
| 564 | 1.3.6.3.2 | **Science Observations Planning Tools** | 148d? | 2009-01-07 | 2009-07-31 | 166d |  |  | 340h | 25,500 |
| 565 | 1.3.6.3.2.1 | **NGS Star Finder** | 148d? | 2009-01-07 | 2009-07-31 | 166d |  |  | 60h | 4,500 |
| 566 | 1.3.6.3.2.1.1 | Operations Concept | 148d? | 2009-01-07 | 2009-07-31 | 166d | finish no earlier than 2009-07-31 | Le Mignant [1.7%] | 20h | 1,500 |
| 567 | 1.3.6.3.2.1.2 | Functional Requirements & Use Case Definitions | 148d? | 2009-01-07 | 2009-07-31 | 166d | finish no earlier than 2009-07-31 | Le Mignant [3.4%] | 40h | 3,000 |
| 568 | 1.3.6.3.2.1.3 | Interface Definitions | 148d? | 2009-01-07 | 2009-07-31 | 166d | finish no earlier than 2009-07-31 |  |  |  |
| 569 | 1.3.6.3.2.1.4 | Module Definitions | 148d? | 2009-01-07 | 2009-07-31 | 166d | finish no earlier than 2009-07-31 |  |  |  |
| 570 | 1.3.6.3.2.2 | **Performance Prediction Tool** | 148d? | 2009-01-07 | 2009-07-31 | 166d |  |  | 140h | 10,500 |
| 571 | 1.3.6.3.2.2.1 | Operations Concept | 148d? | 2009-01-07 | 2009-07-31 | 166d | finish no earlier than 2009-07-31 | Le Mignant [3.4%] | 40h | 3,000 |
| 572 | 1.3.6.3.2.2.2 | Functional Requirements & Use Case Definitions | 148d? | 2009-01-07 | 2009-07-31 | 166d | finish no earlier than 2009-07-31 | Le Mignant [3.4%] | 40h | 3,000 |
| 573 | 1.3.6.3.2.2.3 | Interface Definitions | 148d? | 2009-01-07 | 2009-07-31 | 166d | finish no earlier than 2009-07-31 | Johansson [1.7%] | 20h | 1,500 |
| 574 | 1.3.6.3.2.2.4 | Module Definitions | 148d? | 2009-01-07 | 2009-07-31 | 166d | finish no earlier than 2009-07-31 | Johansson [1.7%]; Le Mignant [1.7%] | 40h | 3,000 |
| 575 | 1.3.6.3.2.3 | **Observation Planning & Efficiency Tool** | 148d? | 2009-01-07 | 2009-07-31 | 166d |  |  | 140h | 10,500 |
| 576 | 1.3.6.3.2.3.1 | Operations Concept | 148d? | 2009-01-07 | 2009-07-31 | 166d | finish no earlier than 2009-07-31 | Le Mignant [3.4%] | 40h | 3,000 |
| 577 | 1.3.6.3.2.3.2 | Functional Requirements & Use Case Definitions | 148d? | 2009-01-07 | 2009-07-31 | 166d | finish no earlier than 2009-07-31 | Le Mignant [3.4%] | 40h | 3,000 |
| 578 | 1.3.6.3.2.3.3 | Interface Definitions | 148d? | 2009-01-07 | 2009-07-31 | 166d | finish no earlier than 2009-07-31 | Johansson [1.7%] | 20h | 1,500 |
| 579 | 1.3.6.3.2.3.4 | Module Definitions | 148d? | 2009-01-07 | 2009-07-31 | 166d | finish no earlier than 2009-07-31 | Johansson [1.7%]; Le Mignant [1.7%] | 40h | 3,000 |
| 580 | 1.3.6.3.2.4 | **Laser Clearinghouse Coordination Tool** | 148d? | 2009-01-07 | 2009-07-31 | 166d |  |  |  |  |
| 581 | 1.3.6.3.2.4.1 | Operations Concept | 148d? | 2009-01-07 | 2009-07-31 | 166d | finish no earlier than 2009-07-31 |  |  |  |
| 582 | 1.3.6.3.2.4.2 | Functional Requirements & Use Case Definitions | 148d? | 2009-01-07 | 2009-07-31 | 166d | finish no earlier than 2009-07-31 |  |  |  |
| 583 | 1.3.6.3.2.4.3 | Interface Definitions | 148d? | 2009-01-07 | 2009-07-31 | 166d | finish no earlier than 2009-07-31 |  |  |  |
| 584 | 1.3.6.3.2.4.4 | Module Definitions | 148d? | 2009-01-07 | 2009-07-31 | 166d | finish no earlier than 2009-07-31 |  |  |  |

Notes:
- 560: DLM

| ID | WBS | Task | Type | Duration | Start | Finish | Total slack | Constraint | Resources | Work | Cost |
| --- | --- | --- | --- | --- | --- | --- | --- | --- | --- | --- | --- |
| 585 | 1.3.6.3.3 | **Data Products** |  | 195d? | 2009-02-02 | 2009-10-30 | 101d |  |  | 250h | 18,750 |
| 586 | 1.3.6.3.3.1 | **Generic Data Products** |  | 152d? | 2009-02-02 | 2009-09-01 | 144d |  |  | 80h | 6,000 |
| 587 | 1.3.6.3.3.1.1 | Operations Concept |  | 152d? | 2009-02-02 | 2009-09-01 | 144d | finish no earlier than 2009-09-01 | Le Mignant [1.6%] | 20h | 1,500 |
| 588 | 1.3.6.3.3.1.2 | Functional Requirements & Use Case Definitions |  | 152d? | 2009-02-02 | 2009-09-01 | 144d | finish no earlier than 2009-09-01 | Le Mignant [3.3%] | 40h | 3,000 |
| 589 | 1.3.6.3.3.1.3 | Interface Definitions |  | 152d? | 2009-02-02 | 2009-09-01 | 144d | finish no earlier than 2009-09-01 | Johansson [1.6%] | 20h | 1,500 |
| 590 | 1.3.6.3.3.2 | **Science Data Quality Assessment** |  | 195d? | 2009-02-02 | 2009-10-30 | 101d |  |  | 160h | 12,000 |
| 591 | 1.3.6.3.3.2.1 | **Quality Metrics & Logged Information** |  | 152d? | 2009-02-02 | 2009-09-01 | 144d |  |  | 80h | 6,000 |
| 592 | 1.3.6.3.3.2.1.1 | Operations Concept |  | 152d? | 2009-02-02 | 2009-09-01 | 144d | finish no earlier than 2009-09-01 | Le Mignant [3.3%] | 40h | 3,000 |
| 593 | 1.3.6.3.3.2.1.2 | Functional Requirements & Use Case Definitions |  | 152d? | 2009-02-02 | 2009-09-01 | 144d | finish no earlier than 2009-09-01 | Le Mignant [3.3%] | 40h | 3,000 |
| 594 | 1.3.6.3.3.2.1.3 | Interface Definitions |  | 152d? | 2009-02-02 | 2009-09-01 | 144d | finish no earlier than 2009-09-01 |  |  |  |
| 595 | 1.3.6.3.3.2.2 | **PSF Calibration** |  | 195d? | 2009-02-02 | 2009-10-30 | 101d |  |  | 80h | 6,000 |
| 596 | 1.3.6.3.3.2.2.1 | Operations Concept |  | 195d? | 2009-02-02 | 2009-10-30 | 101d | finish no earlier than 2009-10-30 | Le Mignant [2.6%] | 40h | 3,000 |
| 597 | 1.3.6.3.3.2.2.2 | Functional Requirements & Use Case Definitions |  | 195d? | 2009-02-02 | 2009-10-30 | 101d | finish no earlier than 2009-10-30 | Le Mignant [2.6%] | 40h | 3,000 |
| 598 | 1.3.6.3.3.2.2.3 | Interface Definitions |  | 195d? | 2009-02-02 | 2009-10-30 | 101d | finish no earlier than 2009-10-30 |  |  |  |
| 599 | 1.3.6.3.3.2.2.4 | Module Definitions |  | 195d? | 2009-02-02 | 2009-10-30 | 101d | finish no earlier than 2009-10-30 |  |  |  |
| 600 | 1.3.6.3.3.3 | **Science Data Archiving** |  | 195d? | 2009-02-02 | 2009-10-30 | 101d |  |  | 10h | 750 |
| 601 | 1.3.6.3.3.3.1 | Operations Concept |  | 195d? | 2009-02-02 | 2009-10-30 | 101d | finish no earlier than 2009-10-30 | Le Mignant [0.6%] | 10h | 750 |
| 602 | 1.3.6.3.3.3.2 | Functional Requirements & Use Case Definitions |  | 195d? | 2009-02-02 | 2009-10-30 | 101d | finish no earlier than 2009-10-30 |  |  |  |
| 603 | 1.3.6.3.3.3.3 | Interface Definitions |  | 195d? | 2009-02-02 | 2009-10-30 | 101d | finish no earlier than 2009-10-30 |  |  |  |
| 604 | 1.3.6.4 | **Data Server** |  | 195d? | 2009-02-02 | 2009-10-30 | 101d |  |  | 70h | 5,250 |
| 605 | 1.3.6.4.1 | Data Server: Architecture |  | 195d? | 2009-02-02 | 2009-10-30 | 101d | finish no earlier than 2009-10-30 | Johansson [2.6%] | 40h | 3,000 |
| 606 | 1.3.6.4.2 | Data Server: HW & SW Specification & Selection |  | 195d? | 2009-02-02 | 2009-10-30 | 101d | finish no earlier than 2009-10-30 | Johansson [1.3%] | 20h | 1,500 |
| 607 | 1.3.6.4.3 | Data Server: Software Design | milestone | 0d? | 2009-02-02 | 2009-02-02 | 296d | start no earlier than 2009-02-02 |  |  |  |
| 608 | 1.3.6.4.4 | Data Server: Compliance Matrix | milestone | 0d? | 2009-02-02 | 2009-02-02 | 296d | start no earlier than 2009-02-02 |  |  |  |
| 609 | 1.3.6.4.5 | Data Server: Test Plan | milestone | 0d? | 2009-02-02 | 2009-02-02 | 296d | start no earlier than 2009-02-02 |  |  |  |
| 610 | 1.3.6.4.6 | Data Server: Summary Report |  | 195d? | 2009-02-02 | 2009-10-30 | 101d | finish no earlier than 2009-10-30 | Johansson [0.6%] | 10h | 750 |

Notes:
- 604: EJ

| ID | WBS | Task | Duration | Start | Finish | Total slack | Constraint | Resources | Work | Cost |
| --- | --- | --- | --- | --- | --- | --- | --- | --- | --- | --- |
| 611 | 1.3.7 | **Telescope & Summit Engineering Design** | 215d? | 2008-12-08 | 2009-10-02 | 121d |  |  | 1101h | 82,575 |
| 612 | 1.3.7.1 | Telescope Performance | 1d? | 2009-05-04 | 2009-05-04 | 230d | start no earlier than 2009-05-04 |  |  |  |
| 613 | 1.3.7.2 | **Infrastructure Modifications for AO** | 110d? | 2009-05-04 | 2009-10-02 | 121d |  |  | 660h | 49,500 |
| 614 | 1.3.7.2.1 | Infrastructure Requirements & Interfaces | 20d? | 2009-05-04 | 2009-05-29 | 211d | finish no earlier than 2009-05-29 | Bell [37.5%]; Wetherell; Wizinowich [60%] | 90h | 6,750 |
| 615 | 1.3.7.2.2 | Infrastructure Mechanical Modifications | 45d? | 2009-06-01 | 2009-07-31 | 166d | finish no earlier than 2009-07-31 | Bell; Medeiros [33.3%]; Mogensen | 160h | 12,000 |
| 616 | 1.3.7.2.3 | Infrastructure Electrical Modifications | 45d? | 2009-07-06 | 2009-09-04 | 141d | finish no earlier than 2009-09-04 | Nance [33.3%] | 120h | 9,000 |
| 617 | 1.3.7.2.4 | Infrastructure Glycol Cooling Modifications | 45d? | 2009-07-13 | 2009-09-11 | 136d | finish no earlier than 2009-09-11 | Nance [38.9%] | 140h | 10,500 |
| 618 | 1.3.7.2.5 | Infrastructure CCR Modifications | 45d? | 2009-07-13 | 2009-09-11 | 136d | finish no earlier than 2009-09-11 | Nance [11.1%] | 40h | 3,000 |
| 619 | 1.3.7.2.6 | Infrastructure Implementation & Test Plans | 25d? | 2009-08-31 | 2009-10-02 | 121d | finish no earlier than 2009-10-02 | Bell [25%]; Medeiros; Nance; Chin | 110h | 8,250 |
| 620 | 1.3.7.3 | **Infrastructure modifications for Laser System** | 110d? | 2009-05-04 | 2009-10-02 | 121d |  |  | 280h | 21,000 |
| 621 | 1.3.7.3.1 | Infrastructure Requirements & Interfaces | 20d? | 2009-05-04 | 2009-05-29 | 211d | finish no earlier than 2009-05-29 | Bell [25%]; Chin; Nance | 70h | 5,250 |
| 622 | 1.3.7.3.2 | Infrastructure Mechanical Modifications | 45d? | 2009-06-29 | 2009-08-28 | 146d | finish no earlier than 2009-08-28 | Medeiros [13.9%] | 50h | 3,750 |
| 623 | 1.3.7.3.3 | Infrastructure Electrical Modifications | 45d? | 2009-07-06 | 2009-09-04 | 141d | finish no earlier than 2009-09-04 | Nance [11.1%] | 40h | 3,000 |
| 624 | 1.3.7.3.4 | Infrastructure Glycol Cooling Modifications | 45d? | 2009-07-13 | 2009-09-11 | 136d | finish no earlier than 2009-09-11 | Nance [13.9%] | 50h | 3,750 |
| 625 | 1.3.7.3.5 | Infrastructure Implementation & Test Plans | 25d? | 2009-08-31 | 2009-10-02 | 121d | finish no earlier than 2009-10-02 | Bell [20%]; Chin; Medeiros; Nance | 70h | 5,250 |
| 626 | 1.3.7.4 | OSIRIS Modifications | 15d? | 2009-01-12 | 2009-01-30 | 296d | start no earlier than 2009-01-12 | Adkins [16.7%]; Wetherell [33.3%]; Medeiros [33.3%] | 100h | 7,500 |
| 627 | 1.3.7.5 | **Interferometer Modifications** | 40d? | 2008-12-08 | 2009-01-30 | 296d |  |  | 61h | 4,575 |
| 628 | 1.3.7.5.1 | Optical Design of Post Field Selector Optics | 40d? | 2008-12-08 | 2009-01-30 | 296d | finish no earlier than 2009-01-30 | Wizinowich [7.8%]; Kupke [6.2%] | 45h | 3,375 |
| 629 | 1.3.7.5.2 | Evaluation of Optical Design Impact on Interferometer | 40d? | 2008-12-08 | 2009-01-30 | 296d | start no earlier than 2008-12-08 | Wizinowich [5%] | 16h | 1,200 |
| 630 | 1.3.8 | **Telescope Integration & Test** | 55d? | 2009-10-05 | 2009-12-18 | 66d |  |  | 622h | 46,650 |
| 631 | 1.3.8.1 | **Old AO/Laser Removal** | 20d? | 2009-10-05 | 2009-10-30 | 101d |  |  | 120h | 9,000 |
| 632 | 1.3.8.1.1 | AO Removal Plan | 20d? | 2009-10-05 | 2009-10-30 | 101d | start no earlier than 2009-10-05 | Nance [7.5%]; Bell [15%]; Wetherell [12.5%]; Wizinowich [2.5%]; Doyle | 60h | 4,500 |
| 633 | 1.3.8.1.2 | Laser Removal Plan | 20d? | 2009-10-05 | 2009-10-30 | 101d | start no earlier than 2009-10-05 | Chin [2.5%]; Medeiros [12.5%]; Doyle [5%]; Grace [10%]; Nance [7.5%] | 60h | 4,500 |
| 634 | 1.3.8.2 | Laser Enclosure Integration | 1d? | 2009-10-05 | 2009-10-05 | 120d | start no earlier than 2009-10-05 |  |  |  |
| 635 | 1.3.8.3 | AO Enclosure Integration | 1d? | 2009-10-05 | 2009-10-05 | 120d | start no earlier than 2009-10-05 |  |  |  |

Notes:
- 611: CN
- 613: JB
- 614: JB
- 615: DM
- 616: CN
- 617: CN
- 618: CN
- 619: JB
- 620: JB
- 621: JB
- 622: DM
- 623: CN
- 624: CN
- 625: JB
- 626: SA
- 627: PW
- 628: PW
- 629: PW
- 630: CN
- 631: JB
- 632: JB
- 633: DM

| ID | WBS | Task | Duration | Start | Finish | Total slack | Constraint | Resources | Work | Cost |
| --- | --- | --- | --- | --- | --- | --- | --- | --- | --- | --- |
| 636 | 1.3.8.4 | **AO System Install + I&T** | 35d? | 2009-11-02 | 2009-12-18 | 66d |  |  | 170h | 12,750 |
| 637 | 1.3.8.4.1 | Opto-Mechanical Integration Plan | 27d? | 2009-11-02 | 2009-12-08 | 74d | start no earlier than 2009-11-02 | Wizinowich [1.9%]; Bell [9.3%]; Neyman [16.7%] | 60h | 4,500 |
| 638 | 1.3.8.4.2 | Electronics Integration Plan | 35d? | 2009-11-02 | 2009-12-18 | 66d | start no earlier than 2009-11-02 | Wetherell [14.3%] | 40h | 3,000 |
| 639 | 1.3.8.4.3 | Computer Integration Plan | 35d? | 2009-11-02 | 2009-12-18 | 66d | start no earlier than 2009-11-02 | Chock [7.1%] | 20h | 1,500 |
| 640 | 1.3.8.4.4 | AO System Integration Plan | 35d? | 2009-11-02 | 2009-12-18 | 66d | start no earlier than 2009-11-02 | Neyman [14.3%] | 40h | 3,000 |
| 641 | 1.3.8.4.5 | AO System Test Plan | 35d? | 2009-11-02 | 2009-12-18 | 66d | start no earlier than 2009-11-02 | Neyman [3.6%] | 10h | 750 |
| 642 | 1.3.8.5 | **Laser System Install + I&T** | 35d? | 2009-11-02 | 2009-12-18 | 66d |  |  | 212h | 15,900 |
| 643 | 1.3.8.5.1 | Laser System Installation & Integration Plan | 35d? | 2009-11-02 | 2009-12-18 | 66d | finish no earlier than 2009-12-18 | Chin [21.4%]; Nance [7.1%]; Medeiros [7.1%]; Wetherell [7.1%]; Neyman [7.1%]; Adkins [2.9%] | 148h | 11,100 |
| 644 | 1.3.8.5.2 | Laser System Test Plan | 35d? | 2009-11-02 | 2009-12-18 | 66d | start no earlier than 2009-11-02 | Neyman [14.3%]; Wetherell [1.4%]; Johansson [2.9%]; Chin [2.9%]; Adkins [1.4%] | 64h | 4,800 |
| 645 | 1.3.8.6 | LGS AO System On-sky I&T Plan | 10d? | 2009-11-02 | 2009-11-13 | 91d | finish no earlier than 2009-11-13 | Le Mignant [25%]; Wizinowich [25%] | 40h | 3,000 |
| 646 | 1.3.8.7 | Performance Characterization | 1d? | 2009-11-02 | 2009-11-02 | 100d | start no earlier than 2009-11-02 |  |  |  |
| 647 | 1.3.8.8 | Science Verification Plan | 20d? | 2009-11-02 | 2009-11-27 | 81d | finish no earlier than 2009-11-27 | Le Mignant [37.5%]; Wizinowich [12.5%] | 80h | 6,000 |
| 648 | 1.3.9 | **Operations Transition** | 232d? | 2009-01-09 | 2009-11-30 | 80d |  |  | 166h | 12,450 |
| 649 | 1.3.9.1 | **Operations Plans** | 65d? | 2009-09-01 | 2009-11-30 | 80d |  |  | 96h | 7,200 |
| 650 | 1.3.9.1.1 | Operations Support Plan | 65d? | 2009-09-01 | 2009-11-30 | 80d | finish no earlier than 2009-11-30 | Le Mignant [7.7%] | 40h | 3,000 |
| 651 | 1.3.9.1.2 | Operations Maintenance & Spares Plan Template | 65d? | 2009-09-01 | 2009-11-30 | 80d | start no earlier than 2009-09-01 | Wetherell [5.4%]; Bell [3.1%]; Lockwood [1.2%]; Velur [1.2%] | 56h | 4,200 |
| 652 | 1.3.9.2 | **Operations Handover** | 232d? | 2009-01-09 | 2009-11-30 | 80d |  |  | 70h | 5,250 |
| 653 | 1.3.9.2.1 | Operations Personnel Training Plan | 65d? | 2009-09-01 | 2009-11-30 | 80d | finish no earlier than 2009-11-30 | Le Mignant [7.7%]; Wizinowich [1.9%] | 50h | 3,750 |
| 654 | 1.3.9.2.2 | Documentation Transition Plan | 232d? | 2009-01-09 | 2009-11-30 | 80d | finish no earlier than 2009-11-30 | Le Mignant [1.1%] | 20h | 1,500 |

Notes:
- 636: CN
- 637: CN
- 638: EW
- 639: JC
- 640: CN
- 641: CN
- 642: JC
- 643: JC
- 644: CN
- 645: DLM
- 647: DLM
- 648: DLM
- 649: DLM
- 650: DLM
- 651: EW
- 652: DLM
- 653: DLM
- 654: DLM
